# Proyecto CRM - Corporacion Union

Schedule from MS Project, 2006-08-07 to 2006-12-11.

## Calendars

- Estándar: Mon-Fri 08:00-12:00, 13:00-17:00; Sat-Sun off.

## Resources

| Resource |
| --- |
| Beta (GWT) |
| Gustavo (GWT) |
| Leonel (GWT) |
| Arne (Tierra) |
| Aron (GWT) |
| Listbeth (GWT) |
| Gus |

## Schedule

| ID | WBS | Task | Type | Duration | Start | Finish | Predecessors | Total slack | Free slack | Constraint | Resources | Work |
| --- | --- | --- | --- | --- | --- | --- | --- | --- | --- | --- | --- | --- |
| 1 | 1 | **Total Dealer's Website** |  | 90.75d? | 2006-08-07 08:00 | 2006-12-11 15:00 |  | 0d |  |  |  | 264h |
| 2 | 1.1 | Kickoff meeting |  | 2h | 2006-11-01 08:00 | 2006-11-01 10:00 |  | 28.5d |  | start no earlier than 2006-11-01 08:00 | Beta (GWT); Listbeth (GWT) | 4h |
| 3 | 1.2 | **Follow up sessions** |  | 75.12d | 2006-08-07 08:00 | 2006-11-20 09:00 |  | 15.62d |  |  |  | 6h |
| 4 | 1.2.1 | Work session #1 |  | 0.12d | 2006-11-06 08:00 | 2006-11-06 09:00 |  | 25.62d |  | start no earlier than 2006-11-06 08:00 | Beta (GWT); Listbeth (GWT) | 2h |
| 5 | 1.2.2 | Work session #2 |  | 0.12d | 2006-08-07 08:00 | 2006-08-07 09:00 |  | 90.62d |  |  | Beta (GWT); Listbeth (GWT) | 2h |
| 6 | 1.2.3 | Work session #3 |  | 0.12d | 2006-11-20 08:00 | 2006-11-20 09:00 |  | 15.62d |  | start no earlier than 2006-11-20 08:00 | Beta (GWT); Listbeth (GWT) | 2h |
| 7 | 1.3 | **Requirements** |  | 4.92d | 2006-11-01 08:00 | 2006-11-07 16:20 |  | 23.83d |  |  |  | 26h |
| 8 | 1.3.1 | Analisis and Requirements Elicitation |  | 0.33d | 2006-11-01 08:00 | 2006-11-01 10:40 |  | 23.83d | 0d | start no earlier than 2006-11-01 08:00 | Listbeth (GWT); Beta (GWT); Gustavo (GWT) | 8h |
| 9 | 1.3.2 | Requirements Specifications |  | 0.33d | 2006-11-01 10:40 | 2006-11-01 14:20 | 8 | 23.83d | 0d | start no earlier than 2006-08-25 08:00 | Listbeth (GWT); Beta (GWT); Gustavo (GWT) | 8h |
| 10 | 1.3.3 | Requirement Specifications Report Elaboration |  | 3.75d | 2006-11-01 14:20 | 2006-11-07 11:20 | 9 | 23.83d | 0d |  | Listbeth (GWT) [10%]; Gustavo (GWT) [50%] | 6h |
| 11 | 1.3.4 | Document Turn in to the Total Project Team for revision | milestone | 0d | 2006-11-07 11:20 | 2006-11-07 11:20 | 10 | 23.83d | 0d | finish no earlier than 2006-10-27 17:00 | Arne (Tierra) [10%] |  |
| 12 | 1.3.5 | Total Project Team's document revision | milestone | 0d | 2006-11-07 11:20 | 2006-11-07 11:20 | 11 | 23.83d | 0d | finish no earlier than 2006-10-31 17:00 | Arne (Tierra) [10%] |  |
| 13 | 1.3.6 | Recommended document adjustemts reception | milestone | 0d | 2006-11-07 11:20 | 2006-11-07 11:20 | 12 | 23.83d | 0d | start no earlier than 2006-11-01 08:00 | Listbeth (GWT) [10%] |  |
| 14 | 1.3.7 | Requirement Specification Report Adjustements |  | 0.5d | 2006-11-07 11:20 | 2006-11-07 16:20 | 13 | 23.83d | 0d |  | Beta (GWT) [50%]; Gustavo (GWT) [50%] | 4h |
| 15 | 1.3.8 | Document Turn in to the Total Project Team for approval | milestone | 0d | 2006-11-07 16:20 | 2006-11-07 16:20 | 14 | 23.83d |  | start no earlier than 2006-11-03 08:00 | Arne (Tierra) [10%] |  |
| 16 | 1.3.9 | Requirement Specification Report Approval | milestone | 0d | 2006-11-07 08:00 | 2006-11-07 08:00 |  | 24d | 0d | start no earlier than 2006-11-07 08:00 | Arne (Tierra) [10%] |  |
| 17 | 1.3.10 | Requirement Specification Report Approved | milestone | 0d | 2006-11-07 08:00 | 2006-11-07 08:00 | 16 | 24d |  |  | Arne (Tierra) [10%] |  |
| 18 | 1.4 | **Base information preparation for the implementation** |  | 1.25d | 2006-11-07 08:00 | 2006-11-08 10:00 |  | 23.5d |  |  |  | 9h |
| 19 | 1.4.1 | Data Model Definition and Documentation |  | 0.5d | 2006-11-07 08:00 | 2006-11-07 12:00 |  | 24.25d |  | start no earlier than 2006-11-07 08:00 | Beta (GWT); Gustavo (GWT) | 8h |
| 20 | 1.4.2 | BackOffice Profiles Definition |  | 0.25d | 2006-11-08 08:00 | 2006-11-08 10:00 |  | 23.5d |  | start no earlier than 2006-11-08 08:00 | Beta (GWT) [50%] | 1h |
| 21 | 1.5 | **Design Specifications** |  | 0d? | 2006-11-07 08:00 | 2006-11-07 08:00 |  | 19d | 0d |  |  |  |
| 22 | 1.5.1 | Design Document turn in (colors, typography, images, web pages section sizes) | milestone | 0d? | 2006-11-07 08:00 | 2006-11-07 08:00 |  | 19d |  | start no earlier than 2006-11-07 08:00 | Arne (Tierra) [10%] |  |
| 23 | 1.6 | **Configuration and Development** |  | 22d | 2006-11-08 08:00 | 2006-12-07 17:00 | 21 | 0d |  |  |  | 151h |
| 24 | 1.6.1 | WIB3 Application Configuration |  | 0.5d | 2006-11-08 08:00 | 2006-11-08 12:00 |  | 21.5d |  | start no earlier than 2006-11-08 08:00 | Gustavo (GWT) [50%] | 2h |
| 25 | 1.6.2 | N2C Application Configuration |  | 0.5d | 2006-11-09 08:00 | 2006-11-09 12:00 |  | 20.5d |  | start no earlier than 2006-11-09 08:00 | Leonel (GWT) [50%] | 2h |

| ID | WBS | Task | Duration | Start | Finish | Predecessors | Total slack | Free slack | Constraint | Resources | Work |
| --- | --- | --- | --- | --- | --- | --- | --- | --- | --- | --- | --- |
| 26 | 1.6.3 | **WIB3 Configuration** | 4d | 2006-11-09 08:00 | 2006-11-14 17:00 |  | 17d |  |  |  | 16h |
| 27 | 1.6.3.1 | General Web Site Template Definition (Page Divisions, General Style, Site Assistant) | 3d | 2006-11-09 08:00 | 2006-11-13 17:00 |  | 17d | 0d | start no earlier than 2006-11-09 08:00 | Beta (GWT) [50%] | 12h |
| 28 | 1.6.3.2 | Page Definition (Content Pages, Application Pages) | 1d | 2006-11-14 08:00 | 2006-11-14 17:00 | 27 | 17d |  |  | Leonel (GWT) [50%] | 4h |
| 29 | 1.6.4 | **Functionalities Implementation** | 18d | 2006-11-14 08:00 | 2006-12-07 17:00 |  | 0d |  |  |  | 131h |
| 30 | 1.6.4.1 | **News** | 1.5d | 2006-11-14 08:00 | 2006-11-15 12:00 |  | 16.5d |  |  |  | 8h |
| 31 | 1.6.4.1.1 | Public Home and User Home News | 1d | 2006-11-14 08:00 | 2006-11-14 17:00 |  | 16.5d | 0d | start no earlier than 2006-11-14 08:00 | Gustavo (GWT) [50%] | 4h |
| 32 | 1.6.4.1.2 | Dealerpanel News | 0.5d | 2006-11-15 08:00 | 2006-11-15 12:00 | 31 | 16.5d |  |  | Gustavo (GWT) | 4h |
| 33 | 1.6.4.2 | Public Home and User Home Poll | 1.5d | 2006-11-15 08:00 | 2006-11-16 12:00 |  | 15.5d |  | start no earlier than 2006-11-15 08:00 | Leonel (GWT) | 12h |
| 34 | 1.6.4.3 | **Marketing Actions** | 2d | 2006-11-17 08:00 | 2006-11-20 17:00 |  | 13d |  |  |  | 16h |
| 35 | 1.6.4.3.1 | Pulbic and User Home Marketing Actions | 1.5d | 2006-11-17 08:00 | 2006-11-20 12:00 |  | 13d | 0d | start no earlier than 2006-11-17 08:00 | Leonel (GWT) [50%]; Gustavo (GWT) [50%] | 12h |
| 36 | 1.6.4.3.2 | Retail-Marketing Actions | 0.5d | 2006-11-20 13:00 | 2006-11-20 17:00 | 35 | 13d |  |  | Leonel (GWT) | 4h |
| 37 | 1.6.4.4 | Login/Logout/ Password Change | 1d | 2006-11-20 08:00 | 2006-11-20 17:00 |  | 11.5d | 0d | start no earlier than 2006-11-20 08:00 | Beta (GWT) [50%] | 4h |
| 38 | 1.6.4.5 | User Registration | 1.5d | 2006-11-21 08:00 | 2006-11-22 12:00 | 37 | 11.5d |  |  | Gustavo (GWT) | 12h |
| 39 | 1.6.4.6 | Price Chart (Like to have) | 1d | 2006-11-22 08:00 | 2006-11-22 17:00 |  | 10d | 0d | start no earlier than 2006-11-22 08:00 | Leonel (GWT) | 8h |
| 40 | 1.6.4.7 | Links Page (Linkpagina) | 1d | 2006-11-23 08:00 | 2006-11-23 17:00 | 39 | 10d |  |  | Leonel (GWT) [50%] | 4h |
| 41 | 1.6.4.8 | **Mailings** | 4d | 2006-11-24 08:00 | 2006-11-29 17:00 |  | 6d |  |  |  | 16h |
| 42 | 1.6.4.8.1 | User home Mailing | 2d | 2006-11-24 08:00 | 2006-11-27 17:00 |  | 6d | 0d | start no earlier than 2006-11-24 08:00 | Beta (GWT) [50%] | 8h |
| 43 | 1.6.4.8.2 | Retail-Marketing Mailing | 0.25d | 2006-11-28 08:00 | 2006-11-28 10:00 | 42 | 6d | 0d |  | Beta (GWT) [50%] | 1h |
| 44 | 1.6.4.8.3 | Retail-Top Service & Training Mailing | 0.25d | 2006-11-28 10:00 | 2006-11-28 12:00 | 43 | 6d | 0d |  | Beta (GWT) [50%] | 1h |
| 45 | 1.6.4.8.4 | Retail-Shop Food & Services Mailing | 0.25d | 2006-11-28 13:00 | 2006-11-28 15:00 | 44 | 6d | 0d |  | Beta (GWT) [50%] | 1h |
| 46 | 1.6.4.8.5 | Retail-Enginoring Mailing | 0.25d | 2006-11-28 15:00 | 2006-11-28 17:00 | 45 | 6d | 0d |  | Beta (GWT) [50%] | 1h |
| 47 | 1.6.4.8.6 | Retail-Customer Service Mailing | 0.25d | 2006-11-29 08:00 | 2006-11-29 10:00 | 46 | 6d | 0d | start no earlier than 2006-11-28 08:00 | Beta (GWT) [50%] | 1h |
| 48 | 1.6.4.8.7 | Retail-Power Points Mailing | 0.25d | 2006-11-29 10:00 | 2006-11-29 12:00 | 47 | 6d | 0d | start no earlier than 2006-11-28 08:00 | Beta (GWT) [50%] | 1h |
| 49 | 1.6.4.8.8 | Cards Mailings | 0.25d | 2006-11-29 13:00 | 2006-11-29 15:00 | 48 | 6d | 0d | start no earlier than 2006-11-28 08:00 | Beta (GWT) [50%] | 1h |
| 50 | 1.6.4.8.9 | Lubricants Mailings | 0.25d | 2006-11-29 15:00 | 2006-11-29 17:00 | 49 | 6d |  | start no earlier than 2006-11-28 08:00 | Beta (GWT) [50%] | 1h |
| 51 | 1.6.4.9 | Pesonal Agenda | 1d | 2006-11-29 08:00 | 2006-11-29 17:00 |  | 6d |  | start no earlier than 2006-11-29 08:00 | Leonel (GWT) | 8h |
| 52 | 1.6.4.10 | Meeting Agenda | 1.5d | 2006-11-30 08:00 | 2006-12-01 12:00 |  | 4.5d |  | start no earlier than 2006-11-30 08:00 | Gustavo (GWT) | 12h |

| ID | WBS | Task | Type | Duration | Start | Finish | Predecessors | Total slack | Free slack | Constraint | Resources | Work |
| --- | --- | --- | --- | --- | --- | --- | --- | --- | --- | --- | --- | --- |
| 53 | 1.6.4.11 | **Contact Forms** |  | 3.75d | 2006-12-04 08:00 | 2006-12-07 15:00 |  | 0.25d |  |  |  | 15h |
| 54 | 1.6.4.11.1 | Retail-Sales Contact |  | 1.5d | 2006-12-04 08:00 | 2006-12-05 12:00 |  | 0.25d | 0d | start no earlier than 2006-12-04 08:00 | Leonel (GWT) [66.7%] | 8h |
| 55 | 1.6.4.11.2 | Retail-Marketing Contact |  | 0.25d | 2006-12-05 13:00 | 2006-12-05 15:00 | 54 | 0.25d | 0d | start no earlier than 2006-12-05 08:00 | Leonel (GWT) [50%] | 1h |
| 56 | 1.6.4.11.3 | Retail-Top Service & Training Contact |  | 0.25d | 2006-12-05 15:00 | 2006-12-05 17:00 | 55 | 0.25d | 0d | start no earlier than 2006-12-05 08:00 | Leonel (GWT) [50%] | 1h |
| 57 | 1.6.4.11.4 | Retail-Shop Food & Services Contact |  | 0.25d | 2006-12-06 08:00 | 2006-12-06 10:00 | 56 | 0.25d | 0d | start no earlier than 2006-12-06 08:00 | Leonel (GWT) [50%] | 1h |
| 58 | 1.6.4.11.5 | Retail-Customer Service Contact |  | 0.25d | 2006-12-06 10:00 | 2006-12-06 12:00 | 57 | 0.25d | 0d | start no earlier than 2006-12-06 08:00 | Leonel (GWT) [50%] | 1h |
| 59 | 1.6.4.11.6 | Retail-Power Points Contact |  | 0.25d | 2006-12-06 13:00 | 2006-12-06 15:00 | 58 | 0.25d | 0d | start no earlier than 2006-12-06 08:00 | Leonel (GWT) [50%] | 1h |
| 60 | 1.6.4.11.7 | Cards Contact |  | 0.5d | 2006-12-06 15:00 | 2006-12-07 10:00 | 59 | 0.25d | 0d | start no earlier than 2006-12-06 08:00 | Leonel (GWT) [25%] | 1h |
| 61 | 1.6.4.11.8 | Dealerpanel Contact |  | 0.5d | 2006-12-07 10:00 | 2006-12-07 15:00 | 60 | 0.25d |  | start no earlier than 2006-12-07 08:00 | Leonel (GWT) [25%] | 1h |
| 62 | 1.6.4.12 | Acts Module |  | 1d | 2006-12-07 08:00 | 2006-12-07 17:00 |  | 0d |  | start no earlier than 2006-12-07 08:00 | Gustavo (GWT); Beta (GWT) | 16h |
| 63 | 1.7 | **Testing Plan** |  | 0.5d | 2006-12-08 08:00 | 2006-12-08 12:00 | 23 | 0d |  |  |  | 8h |
| 64 | 1.7.1 | Testing Plan Elaboration |  | 0.24d | 2006-12-08 08:00 | 2006-12-08 09:54 | 23 | 0.26d |  |  | Beta (GWT) [50%]; Gustavo (GWT) [50%]; Listbeth (GWT) [10%]; Leonel (GWT) | 4h |
| 65 | 1.7.2 | Testing Plan revision with Total Work Team |  | 0.5d | 2006-12-08 08:00 | 2006-12-08 12:00 |  | 0d |  |  | Arne (Tierra) [50%] | 2h |
| 66 | 1.7.3 | Recommended Adjustments to the Testing Plan |  | 0.25d | 2006-12-08 08:00 | 2006-12-08 10:00 |  | 0.25d |  |  | Beta (GWT) [50%]; Gustavo (GWT) [50%] | 2h |
| 67 | 1.8 | Revised Testing Plan |  | 0.5d | 2006-12-08 08:00 | 2006-12-08 12:00 |  | 1.25d |  | start no earlier than 2006-12-08 08:00 |  |  |
| 68 | 1.9 | **Certification Testing** |  | 1d | 2006-12-08 13:00 | 2006-12-11 12:00 | 63 | 0d |  |  |  | 28h |
| 69 | 1.9.1 | Testing Preparation |  | 0.25d | 2006-12-08 13:00 | 2006-12-08 15:00 |  | 0.75d |  |  | Gustavo (GWT); Beta (GWT) | 4h |
| 70 | 1.9.2 | Functionalities Testing |  | 1d | 2006-12-08 13:00 | 2006-12-11 12:00 |  | 0d |  |  | Aron (GWT) | 8h |
| 71 | 1.9.3 | Recommended Adjustments |  | 0.67d | 2006-12-08 13:00 | 2006-12-11 09:20 |  | 0.33d |  |  | Beta (GWT); Gustavo (GWT); Leonel (GWT) | 16h |
| 72 | 1.10 | Certified Testing | milestone | 0d | 2006-12-08 08:00 | 2006-12-08 08:00 |  | 1.75d |  | start no earlier than 2006-12-08 08:00 | Arne (Tierra) [10%] |  |
| 73 | 1.11 | **Documentation** |  | 23.29d | 2006-11-07 08:00 | 2006-12-08 10:17 |  | 1.46d |  |  |  | 20h |
| 74 | 1.11.1 | Technical documentation consolidation and structuring |  | 1d | 2006-11-07 08:00 | 2006-11-07 17:00 | 21 | 23.75d |  |  | Leonel (GWT); Gustavo (GWT) [50%]; Beta (GWT) [50%] | 16h |
| 75 | 1.11.2 | Documentation Adjustements |  | 0.29d | 2006-12-08 08:00 | 2006-12-08 10:17 | 23 | 1.46d |  |  | Beta (GWT) [50%]; Gustavo (GWT) [50%]; Leonel (GWT) | 4h |
| 76 | 1.12 | **Project Management** |  | 1d? | 2006-10-23 08:00 | 2006-10-23 17:00 |  | 34.75d |  |  |  | 8h |
| 77 | 1.12.1 | Planification |  | 1d? | 2006-10-23 08:00 | 2006-10-23 17:00 |  | 34.75d |  | start no earlier than 2006-10-23 08:00 |  | 8h |

| ID | WBS | Task | Duration | Start | Finish | Predecessors | Total slack | Resources | Work |
| --- | --- | --- | --- | --- | --- | --- | --- | --- | --- |
| 78 | 1.13 | **Project Closure** | 0.25d | 2006-12-11 13:00 | 2006-12-11 15:00 | 68 | 0d |  | 4h |
| 79 | 1.13.1 | Project Closure Presentation Elaboration | 0.25d | 2006-12-11 13:00 | 2006-12-11 15:00 |  | 0d | Listbeth (GWT) [50%]; Beta (GWT) [50%] | 2h |
| 80 | 1.13.2 | Project Closure Meeting | 0.25d | 2006-12-11 13:00 | 2006-12-11 15:00 |  | 0d | Listbeth (GWT) [50%]; Beta (GWT) [50%] | 2h |
