# Vendinet

Schedule from MS Project, 2007-05-14 to 2007-06-20, costs in Bs.
GlobalWebTek

## Calendars

- Standard: Mon-Fri 08:00-12:00, 13:00-17:00; Sat-Sun off.

## Resources

| Resource | Rate |
| --- | --- |
| MR | 15000 |
| FB | 6250 |
| OP | 15000 |
| FA |  |
| LA |  |
| JP |  |

## Schedule

| ID | WBS | Task | Duration | Start | Finish | Predecessors | Total slack | Free slack | Constraint | Resources | Work | Cost |
| --- | --- | --- | --- | --- | --- | --- | --- | --- | --- | --- | --- | --- |
| 1 | 1 | **VendiShop** | 27.52d? | 2007-05-14 | 2007-06-20 |  | 0d |  |  |  | 213h | 300,000 |
| 2 | 1.1 | **Construcción** | 20.52d? | 2007-05-18 | 2007-06-15 |  | 0d |  |  |  | 177h |  |
| 3 | 1.1.1 | Instalación WIB / N2C | 0.62d? | 2007-05-18 | 2007-05-18 |  | 0d |  | start no earlier than 2007-05-18 |  | 5h |  |
| 4 | 1.1.2 | **Vendinet SAV** | 18.9d? | 2007-05-18 | 2007-06-14 |  | 0d |  |  |  | 46h |  |
| 5 | 1.1.2.1 | Vendinet SAV paquetizable | 2.25d? | 2007-05-18 | 2007-05-22 | 3 | 16.15d | 0d | start no earlier than 2007-05-15 | JP | 18h |  |
| 6 | 1.1.2.2 | Ajustes en FCK | 0.5d? | 2007-05-22 | 2007-05-23 | 5 | 16.15d |  |  | JP | 4h |  |
| 7 | 1.1.2.3 | Ajustes para registros no ML | 1.5d? | 2007-06-08 | 2007-06-14 | 11 | 0d |  |  | LA; JP | 24h |  |
| 8 | 1.1.3 | **Backoffice** | 1.25d? | 2007-05-18 | 2007-05-21 |  | 0d |  |  |  | 12h |  |
| 9 | 1.1.3.1 | Registro Artículo | 0.25d? | 2007-05-18 | 2007-05-18 | 3 | 0d |  |  | LA | 2h |  |
| 10 | 1.1.3.2 | Módulo Contáctanos | 1.25d? | 2007-05-18 | 2007-05-21 | 3 | 13.25d | 0d |  | JP | 10h |  |
| 11 | 1.1.4 | **Sitio Web** | 15d? | 2007-05-18 | 2007-06-08 |  | 0d |  |  |  | 78h |  |
| 12 | 1.1.4.1 | Registro de Cliente y Autenticación | 0.5d? | 2007-05-18 | 2007-05-21 | 9 | 0d |  |  | LA | 4h |  |
| 13 | 1.1.4.2 | Módulo Contáctanos | 0.75d? | 2007-05-21 | 2007-05-22 | 10 | 13.25d |  |  | JP | 6h |  |
| 14 | 1.1.4.3 | Compra de Artículos | 5d? | 2007-05-21 | 2007-05-28 | 12 | 0d |  |  | LA | 40h |  |
| 15 | 1.1.4.4 | Ofertas y Recomendados | 2d? | 2007-06-05 | 2007-06-07 | 20 | 0d |  |  | JP | 16h |  |
| 16 | 1.1.4.5 | Filtro para búsqueda de productos | 0.25d? | 2007-06-07 | 2007-06-07 | 15 | 0d |  |  | JP; LA | 4h |  |
| 17 | 1.1.4.6 | Enlaces por Tipo y Categorías en Menú | 0.5d? | 2007-06-07 | 2007-06-08 | 16 | 0d |  |  | LA | 4h |  |
| 18 | 1.1.4.7 | FAQ y Noticias | 0.5d? | 2007-06-08 | 2007-06-08 | 17 | 0d |  |  | JP | 4h |  |
| 19 | 1.1.5 | Pruebas y Ajustes | 1d | 2007-06-14 | 2007-06-15 | 4 | 0d |  |  | LA; JP | 16h |  |
| 20 | 1.1.6 | **Diseño Gráfico** | 6.25d | 2007-05-28 | 2007-06-05 |  | 0d |  |  |  | 20h |  |
| 21 | 1.1.6.1 | **Diseño de (3) Plantillas en Formato PNG** | 3.75d | 2007-05-28 | 2007-06-01 |  | 0d |  |  |  | 12h |  |
| 22 | 1.1.6.1.1 | Plantilla 1 (home) | 10h | 2007-05-28 | 2007-05-29 | 14 | 0d |  |  | FA [40%] | 4h |  |
| 23 | 1.1.6.1.2 | Plantilla 2 (contenido) | 10h | 2007-05-29 | 2007-05-30 | 22 | 0d |  |  | FA [40%] | 4h |  |
| 24 | 1.1.6.1.3 | Plantilla 3 (vista reporte) | 10h | 2007-05-30 | 2007-06-01 | 23 | 0d |  |  | FA [40%] | 4h |  |
| 25 | 1.1.6.2 | Desarrollo de CSS | 12.5h | 2007-06-01 | 2007-06-04 | 24 | 0d |  |  | FA [40%] | 5h |  |
| 26 | 1.1.6.3 | Busqueda de Material y Montaje final | 7.5h | 2007-06-04 | 2007-06-05 | 25 | 0d |  |  | FA [40%] | 3h |  |

Notes:
- 3: Incluye la creación de scripts para creación de modelo de datos, copia de archivos de programas y de plantillas para aplicación en N2C y Sitio Web respectivamente.
- 14: Incluye Despliegue de Galería de Artículos, su Búsqueda por tres categorías y un tipo, registro del pago en tablas de Vendinet SAV

| ID | WBS | Task | Duration | Start | Finish | Predecessors | Total slack | Constraint | Resources | Work | Cost |
| --- | --- | --- | --- | --- | --- | --- | --- | --- | --- | --- | --- |
| 27 | 1.2 | **Documentación** | 1d? | 2007-06-15 | 2007-06-18 |  | 0d |  |  | 16h |  |
| 28 | 1.2.1 | Instrucciones para creación de copia del paquete | 1d? | 2007-06-15 | 2007-06-18 | 2 | 0d |  | LA; JP | 16h |  |
| 29 | 1.3 | **Puesta en Marcha** | 1d | 2007-06-18 | 2007-06-19 |  | 0d |  |  | 8h | 120,000 |
| 30 | 1.3.1 | Implantación | 1d | 2007-06-18 | 2007-06-19 | 27 | 0d |  | OP | 8h | 120,000 |
| 31 | 1.4 | **Gerencia de Proyecto** | 27.52d? | 2007-05-14 | 2007-06-20 |  | 0d |  |  | 12h | 180,000 |
| 32 | 1.4.1 | Planificación, Control, Seguimiento | 21.75d | 2007-05-14 | 2007-06-15 |  | 2.77d | finish no earlier than 2007-06-15 | MR [10%] | 12h | 180,000 |
| 33 | 1.4.2 | GSMBlue en Producción | 1d? | 2007-06-19 | 2007-06-20 | 30 | 0d |  |  |  |  |
