# Proyecto CRM - Corporacion Union

Schedule from MS Project, 2007-05-15 to 2007-10-25, A marks actual dates.

## Calendars

- Estándar: Mon-Fri 08:00-12:00, 13:00-17:00; Sat-Sun off. Exceptions (off unless hours are given): 2007-07-24, 2007-10-12.

## Resources

| Resource |
| --- |
| Hertz |
| TCU |
| MR |
| GM |
| AG |

## Schedule

| ID | WBS | Task | Duration | Start | Finish | Predecessors | Complete | Remaining | Total slack | Free slack | Constraint | Resources | Work | Actual work |
| --- | --- | --- | --- | --- | --- | --- | --- | --- | --- | --- | --- | --- | --- | --- |
| 1 | 1 | **Proyecto Módulo Mantenimiento Génesis** | 115.88d? | 2007-05-15 A | 2007-10-25 |  | 35% | 74.76d? | 0d |  |  |  | 317h | 149.2h |
| 2 | 1.1 | Reunión con CU | 0.38d | 2007-05-15 A | 2007-05-15 A |  | 100% |  |  |  | start no earlier than 2007-05-15 | MR; GM | 6h | 6h |
| 3 | 1.2 | **Adaptación Funcional** | 58d? | 2007-08-02 A | 2007-10-23 |  | 39% | 35.59d? | 2d |  |  |  | 192h | 109.2h |
| 4 | 1.2.1 | Análisis | 1d? | 2007-08-02 A | 2007-08-02 A |  | 100% |  |  |  | start no earlier than 2007-08-02 | MR | 8h | 8h |
| 5 | 1.2.2 | Descarga de Inventario en OT | 1.75d? | 2007-08-03 A | 2007-08-07 A | 4 | 100% |  |  |  |  | AG | 14h | 14h |
| 6 | 1.2.3 | Devolución a Inventario de Productos descargados en OT | 1.75d? | 2007-08-07 A | 2007-08-09 A | 5 | 100% |  |  |  |  | AG | 14h | 14h |
| 7 | 1.2.4 | Llamada a Webservices | 1d? | 2007-09-18 A | 2007-09-18 |  | 90% | 0.1d? | 1.8d | 0d | start no earlier than 2007-09-18 |  | 4h | 3.6h |
| 8 | 1.2.5 | Traslado por Mantenimiento | 3d? | 2007-08-09 A | 2007-08-14 | 6 | 90% | 0.3d? | 50.5d | 0d |  | AG | 24h | 21.6h |
| 9 | 1.2.6 | Cierre de Traslado por Mantenimiento | 1.5d? | 2007-08-14 A | 2007-08-15 | 8 | 90% | 0.15d? | 49.15d | 0d |  | AG | 12h | 10.8h |
| 10 | 1.2.7 | Consulta de Traslado por Mantenimiento | 1d? | 2007-08-16 A | 2007-08-16 | 9 | 90% | 0.1d? | 48.25d | 0d |  | AG | 8h | 7.2h |
| 11 | 1.2.8 | Ajustes en OT y Facturación a Terceros | 1.5d? | 2007-08-17 A | 2007-08-20 | 10 | 50% | 0.75d? | 47.5d |  |  | AG | 12h | 6h |
| 12 | 1.2.9 | Consulta de movimientos de inventario | 2d? | 2007-09-19 A | 2007-09-20 | 7, 11 | 90% | 0.2d? | 3d | 0d |  | AG | 16h | 14.4h |
| 13 | 1.2.10 | Consulta de Detalles de OT con productos asociados | 2d? | 2007-09-21 A | 2007-09-24 | 12 | 20% | 1.6d? | 0.8d | 0d |  | AG | 16h | 3.2h |
| 14 | 1.2.11 | Facturación a terceros, confirmación y descarga de inventario | 4d? | 2007-09-25 A | 2007-09-28 | 13 | 20% | 3.2d? | 0d |  |  | AG | 32h | 6.4h |
| 15 | 1.2.12 | Pruebas y Ajustes | 16d? | 2007-10-01 | 2007-10-23 | 14 |  |  | 0d |  |  | MR [25%] | 32h |  |
| 16 | 1.3 | **Pruebas de Certificación** | 4d? | 2007-10-03 | 2007-10-09 |  |  |  | 11.25d |  |  |  | 24h |  |
| 17 | 1.3.1 | Realización de Ajustes recomendados | 3d | 2007-10-03 | 2007-10-08 |  |  |  | 11.25d | 0d | start no earlier than 2007-10-03 | AG | 24h |  |
| 18 | 1.3.2 | Pruebas Certificadas | 1d? | 2007-10-08 | 2007-10-09 | 17 |  |  | 11.25d |  |  |  |  |  |
| 19 | 1.4 | **Documentación** | 2d | 2007-10-24 | 2007-10-25 |  |  |  | 0d |  |  |  | 16h |  |
| 20 | 1.4.1 | Consolidación y estructuración de documentos técnicos | 0.5d | 2007-10-24 | 2007-10-24 | 15 |  |  | 0d |  | start no earlier than 2007-09-21 | AG | 4h |  |
| 21 | 1.4.2 | Ajustes a la documentación | 1.5d | 2007-10-24 | 2007-10-25 | 20 |  |  | 0d |  |  | AG | 12h |  |
| 22 | 1.5 | **Gerencia de Proyecto** | 51.25d | 2007-08-03 A | 2007-10-16 |  | 37% | 32.48d | 7d |  |  |  | 76h | 34h |
| 23 | 1.5.1 | Planificación | 1d | 2007-08-03 A | 2007-08-06 A | 4 | 100% |  |  |  | start no earlier than 2007-06-04 | MR | 8h | 8h |
| 24 | 1.5.2 | Control y Seguimiento | 50d | 2007-08-06 A | 2007-10-16 | 23 | 50% | 25d | 7d |  | finish no earlier than 2007-10-16 | MR [13%] | 52h | 26h |
| 25 | 1.5.3 | Asesoría experto de negocio | 20d | 2007-09-11 | 2007-10-08 |  |  |  | 12d |  | start no earlier than 2007-09-11 | GM [10%] | 16h |  |

Notes:
- 5: Involucra registro de Transacción de Salida
- 6: Involucra registro de Transacción de Entrada
- 23: Incluye tiempo de revisión de documento de especificaciones y comunicación con TCU (Tecnología Conexión Union) aclarando dudas.

| ID | WBS | Task | Duration | Start | Finish | Predecessors | Total slack | Free slack | Constraint | Resources | Work |
| --- | --- | --- | --- | --- | --- | --- | --- | --- | --- | --- | --- |
| 26 | 1.6 | **Cierre** | 0.21d | 2007-10-11 | 2007-10-11 |  | 9.79d |  |  |  | 3h |
| 27 | 1.6.1 | Generación Acta de Cierre | 0.12d | 2007-10-11 | 2007-10-11 |  | 9.79d | 0d | start no earlier than 2007-10-11 | MR | 1h |
| 28 | 1.6.2 | Reunión Cierre de Proyecto | 0.08d | 2007-10-11 | 2007-10-11 | 27 | 9.79d |  | start no earlier than 2007-06-11 | Hertz; MR; GM | 2h |
