# Proyecto CRM - Corporacion Union

Schedule from MS Project, 2008-07-28 to 2009-02-23, status date 2007-03-19, A marks actual dates.

## Calendars

- Estándar: Mon-Fri 08:00-12:00, 13:00-17:00; Sat-Sun off. Exceptions (off unless hours are given): 2008-07-31 to 2008-08-05, 2008-08-27, 2008-12-19 to 2009-01-13.

## Resources

| Resource |
| --- |
| MR |
| MV |
| OP |

## Schedule

| ID | WBS | Task | Type | Duration | Start | Finish | Predecessors | Complete | Remaining | Baseline start | Baseline finish | Baseline duration | Total slack | Free slack | Constraint | Resources | Work | Actual work |
| --- | --- | --- | --- | --- | --- | --- | --- | --- | --- | --- | --- | --- | --- | --- | --- | --- | --- | --- |
| 1 | 1 | **Sito Web amigoscarental.com - Fase II** |  | 127.75d? | 2008-07-28 A | 2009-02-23 |  | 34% | 84.23d? | 2007-03-05 | 2007-05-29 | 57.31d | 0d |  |  |  | 417h | 114.27h |
| 2 | 1.1 | **Inicio** |  | 0.12d | 2008-07-28 A | 2008-07-28 A |  | 100% |  | 2007-03-05 | 2007-03-05 | 0.75d |  |  |  |  | 2h | 2h |
| 3 | 1.1.1 | Reunión de Arranque (Kickoff) |  | 0.25d | 2008-07-28 A | 2008-07-28 A |  | 100% |  | 2007-03-05 | 2007-03-05 | 0.25d |  |  | start no earlier than 2008-07-28 | MR | 2h | 2h |
| 4 | 1.2 | **Especificación de Requerimientos** |  | 11.75d | 2008-07-29 A | 2008-08-19 A |  | 100% |  | 2007-03-07 | 2007-03-19 | 8.75d |  |  |  |  | 12h | 12h |
| 5 | 1.2.1 | Elaboración del Informe Esp. de Req. y Matriz de Req. |  | 2d | 2008-07-29 A | 2008-07-30 A |  | 100% |  | 2007-03-07 | 2007-03-09 | 3d |  |  | start no earlier than 2008-07-29 | MR [50%] | 8h | 8h |
| 6 | 1.2.2 | Ajustes al Informe Especificación de Requerimientos |  | 1d | 2008-08-06 A | 2008-08-06 A | 5 | 100% |  | 2007-03-14 | 2007-03-15 | 2d |  |  |  | MR [50%] | 4h | 4h |
| 7 | 1.2.3 | Entrega de Especificación de Requerimientos para aprobación | milestone | 0d | 2008-08-06 A | 2008-08-06 A | 6 | 100% |  | 2007-03-15 | 2007-03-15 | 0d |  |  |  |  |  |  |
| 8 | 1.2.4 | Revisión por parte del Cliente |  | 9d | 2008-08-07 A | 2008-08-19 A | 7 | 100% |  | 2007-03-15 | 2007-03-19 | 2d |  |  |  |  |  |  |
| 9 | 1.2.5 | Aprobación del Informe Especificación de Requerimientos | milestone | 0d | 2008-08-19 A | 2008-08-19 A | 8 | 100% |  | 2007-03-19 | 2007-03-19 | 0d |  |  |  |  |  |  |
| 10 | 1.3 | Informe Especificación de Requerimientos Aprobado | milestone | 0d | 2008-08-19 A | 2008-08-19 A | 9 | 100% |  | 2007-03-19 | 2007-03-19 | 0d |  |  |  |  |  |  |
| 11 | 1.4 | **Configuración y Desarrollo** |  | 64.83d | 2008-09-16 A | 2008-12-15 |  | 31% | 44.83d | 2007-03-07 | 2007-04-17 | 27.6d | 0.08d |  |  |  | 266h | 80h |
| 12 | 1.4.1 | Análisis y Diseño (incluye creación de tablas en BD) |  | 4d | 2008-09-16 A | 2008-09-19 A | 50 | 100% |  | 2007-03-07 | 2007-03-08 | 2d |  |  | start no earlier than 2008-09-16 | MV [50%] | 16h | 16h |
| 13 | 1.4.2 | **Reestructuración visual (F-ACR-01)** |  | 16d | 2008-09-22 A | 2008-10-13 A |  | 100% |  | 2007-03-19 | 2007-03-23 | 4.06d |  |  |  |  | 64h | 64h |
| 14 | 1.4.2.1 | Modificación de estructura actual - tres columnas |  | 4d | 2008-09-22 A | 2008-09-25 A | 12 | 100% |  | 2007-03-19 | 2007-03-20 | 0.56d |  |  |  | MV [50%] | 16h | 16h |
| 15 | 1.4.2.2 | Reorganización de componentes existentes |  | 7d | 2008-09-26 A | 2008-10-06 A | 14 | 100% |  | 2007-03-20 | 2007-03-20 | 0.28d |  |  |  | MV [50%] | 28h | 28h |
| 16 | 1.4.2.3 | Ajustes en CSS |  | 5d | 2008-10-07 A | 2008-10-13 A | 15 | 100% |  |  |  |  |  |  |  | MV [50%] | 20h | 20h |
| 17 | 1.4.3 | **Reservación En-línea (F-ACR-02)** |  | 18d | 2008-10-14 | 2008-11-06 |  |  |  | 2007-03-23 | 2007-04-17 | 14.8d | 0.08d | 0d |  |  | 72h |  |
| 18 | 1.4.3.1 | Ajustes en Formulario de Solicitud de Reserva |  | 10d | 2008-10-14 | 2008-10-27 | 13 |  |  | 2007-03-23 | 2007-03-26 | 1d | 0.08d | 0d |  | MV [50%] | 40h |  |
| 19 | 1.4.3.2 | Detección de Usuario autenticado |  | 5d | 2008-10-28 | 2008-11-03 | 18 |  |  | 2007-04-11 | 2007-04-12 | 1d | 0.08d | 0d |  | MV [50%] | 20h |  |
| 20 | 1.4.3.3 | Email con Reservación |  | 3d | 2008-11-04 | 2008-11-06 | 19 |  |  | 2007-04-12 | 2007-04-13 | 1d | 0.08d |  |  | MV [50%] | 12h |  |
| 21 | 1.4.4 | **Consulta de Reservaciones (F- ACR-04 )** |  | 7d | 2008-11-07 | 2008-11-17 |  |  |  |  |  |  | 0.08d | 0d |  |  | 28h |  |
| 22 | 1.4.4.1 | Ajustes en la consulta de Reservaciones del Backoffice |  | 3d | 2008-11-07 | 2008-11-11 | 17 |  |  |  |  |  | 0.08d | 0d |  | MV [50%] | 12h |  |
| 23 | 1.4.4.2 | Ajustes en actualización de Reserva - Envío de Email a Cliente |  | 4d | 2008-11-12 | 2008-11-17 | 22 |  |  |  |  |  | 0.08d |  |  | MV [50%] | 16h |  |
| 24 | 1.4.5 | **Consulta de Reservaciones por Sitio Web (F- ACR-03)** |  | 4.5d | 2008-11-18 | 2008-11-24 |  |  |  |  |  |  | 0.08d | 0d |  |  | 18h |  |
| 25 | 1.4.5.1 | Creación de opción de consulta |  | 0.5d | 2008-11-18 | 2008-11-18 | 21 |  |  |  |  |  | 0.08d | 0d |  | MV [50%] | 2h |  |
| 26 | 1.4.5.2 | Listado de Reservas del Cliente (con su status y enlace a detalle) |  | 4d | 2008-11-18 | 2008-11-24 | 25 |  |  |  |  |  | 0.08d |  |  | MV [50%] | 16h |  |

| ID | WBS | Task | Type | Duration | Start | Finish | Predecessors | Complete | Remaining | Baseline start | Baseline finish | Baseline duration | Total slack | Free slack | Resources | Work | Actual work |
| --- | --- | --- | --- | --- | --- | --- | --- | --- | --- | --- | --- | --- | --- | --- | --- | --- | --- |
| 27 | 1.4.6 | **Pago de Reservación por Internet (F- ACR-03)** |  | 15.33d | 2008-11-24 | 2008-12-15 |  |  |  |  |  |  | 0.08d | 0d |  | 68h |  |
| 28 | 1.4.6.1 | Configuración de Boton de Pago de Todo1 |  | 3.33d | 2008-11-24 | 2008-11-27 | 24 |  |  |  |  |  | 0.08d | 0d | OP [25%]; MV [50%] | 20h |  |
| 29 | 1.4.6.2 | Boton de Pago desde listado de Reservaciones (para pagos pendientes) |  | 4d | 2008-11-27 | 2008-12-03 | 28 |  |  |  |  |  | 0.08d | 0d | MV [50%] | 16h |  |
| 30 | 1.4.6.3 | Formulario para pago con TDC |  | 4d | 2008-12-03 | 2008-12-09 | 29 |  |  |  |  |  | 0.08d | 0d | MV [50%] | 16h |  |
| 31 | 1.4.6.4 | Pruebas de pago y ajustes (con data de prueba con el Banco) |  | 4d | 2008-12-09 | 2008-12-15 | 30 |  |  |  |  |  | 0.08d |  | MV [50%] | 16h |  |
| 32 | 1.5 | Pruebas Internas y Ajustes |  | 18.75d | 2008-12-15 | 2009-02-04 | 27 |  |  | 2007-04-17 | 2007-04-25 | 5d | 0.08d | 0d | MV [50%]; MR [10%] | 40h |  |
| 33 | 1.6 | **Documentación** |  | 7d? | 2009-02-04 | 2009-02-13 |  |  |  | 2007-04-25 | 2007-05-21 | 17.34d | 6.17d |  |  | 28h |  |
| 34 | 1.6.1 | Guia de Usuarios Módulo Reservaciones En Línea |  | 5d | 2009-02-04 | 2009-02-11 | 32 |  |  | 2007-04-25 | 2007-05-18 | 16.34d | 6.17d | 0d | MV [50%] | 20h |  |
| 35 | 1.6.2 | Ajustes en Documento Técnico realizado en Fase I |  | 2d? | 2009-02-11 | 2009-02-13 | 34 |  |  |  |  |  | 6.17d |  | MV [50%] | 8h |  |
| 36 | 1.7 | **Adiestramiento** |  | 0.5d? | 2009-02-11 | 2009-02-12 |  |  |  | 2007-04-17 | 2007-05-28 | 27.34d | 7.67d |  |  | 4h |  |
| 37 | 1.7.1 | Presentación para adiestramiento |  | 0.25d? | 2009-02-11 | 2009-02-11 | 34 |  |  |  |  |  | 7.67d | 0d | MR | 2h |  |
| 38 | 1.7.2 | Adiestramiento Módulo de Reservaciones En-Linea |  | 0.25d | 2009-02-11 | 2009-02-12 | 37 |  |  |  |  |  | 7.67d |  | MR | 2h |  |
| 39 | 1.8 | Fase II de Sitio Web |  | 1d | 2009-02-04 | 2009-02-05 | 32 |  |  | 2007-04-25 | 2007-04-26 | 1d | 0.08d | 0d |  |  |  |
| 40 | 1.9 | **Pruebas de Certificación** |  | 9d | 2009-02-05 | 2009-02-18 |  |  |  | 2007-04-26 | 2007-05-10 | 9d | 0.08d | 0d |  | 16h |  |
| 41 | 1.9.1 | Realización de Pruebas de Funcionalidad por parte de Cliente |  | 5d | 2009-02-05 | 2009-02-12 | 39 |  |  | 2007-04-26 | 2007-05-04 | 5d | 0.08d | 0d |  |  |  |
| 42 | 1.9.2 | Realización de Ajustes recomendados |  | 4d | 2009-02-12 | 2009-02-18 | 41 |  |  | 2007-05-04 | 2007-05-10 | 4d | 0.08d | 0d | MV [50%] | 16h |  |
| 43 | 1.9.3 | Certificación del Sistema | milestone | 0d | 2009-02-18 | 2009-02-18 | 42 |  |  | 2007-05-10 | 2007-05-10 | 0d | 0.08d |  |  |  |  |
| 44 | 1.10 | **Puesta en Producción** |  | 2.67d | 2009-02-18 | 2009-02-23 |  |  |  | 2007-05-10 | 2007-05-18 | 6d | 0.08d | 0d |  | 4h |  |
| 45 | 1.10.1 | Implantación/Entonación |  | 1.67d | 2009-02-18 | 2009-02-20 | 40 |  |  | 2007-05-10 | 2007-05-11 | 1d | 0.08d | 0d | OP [30%] | 4h |  |
| 46 | 1.10.2 | Sistema en Producción |  | 1d | 2009-02-20 | 2009-02-23 | 45 |  |  | 2007-05-17 | 2007-05-18 | 1d | 0.08d |  |  |  |  |
| 47 | 1.11 | **Cierre** |  | 0.42d | 2009-02-23 | 2009-02-23 |  |  |  | 2007-05-28 | 2007-05-29 | 0.38d | 0.08d |  |  | 1h |  |
| 48 | 1.11.1 | Preparación y envio de Acta de Cierre |  | 0.42d | 2009-02-23 | 2009-02-23 | 44 |  |  | 2007-05-28 | 2007-05-29 | 0.12d | 0.08d |  | MR [30%] | 1h |  |
| 49 | 1.12 | **Gerencia de Proyecto** |  | 115d | 2008-08-19 A | 2009-02-23 |  | 41% | 68.4d | 2007-03-09 | 2007-04-27 | 32.38d | 0d |  |  | 44h | 20.27h |
| 50 | 1.12.1 | Planificación |  | 1d | 2008-08-19 A | 2008-08-20 A | 10 | 100% |  | 2007-03-19 | 2007-03-20 | 1.11d |  |  | MR [50%] | 4h | 4h |
| 51 | 1.12.2 | Control y Seguimiento |  | 113.88d | 2008-08-20 A | 2009-02-23 | 50 | 40% | 68.33d | 2007-03-09 | 2007-04-27 | 32.5d | 0d |  | MR [6%] | 40h | 16.27h |
