# Nuevo Pendientes-Factibles

Schedule from MS Project, 2008-06-03 to 2008-10-15, A marks actual dates.
KATET

## Calendars

- Estándar: Mon-Fri 09:00-13:00, 15:00-19:00; Sat-Sun off.

## Resources

| Resource |
| --- |
| GP |
| OP |
| DS |
| Cines Unidos |

## Schedule

| ID | WBS | Task | Type | Duration | Start | Finish | Predecessors | Complete | Remaining | Total slack | Free slack | Constraint | Resources | Work | Actual work |
| --- | --- | --- | --- | --- | --- | --- | --- | --- | --- | --- | --- | --- | --- | --- | --- |
| 1 | 1 | **Cines Unidos** |  | 97d? | 2008-06-03 A | 2008-10-15 |  | 45% | 53.4d? | 0d |  |  |  | 494h | 209.02h |
| 2 | 1.1 | **Etapa I y II** |  | 73.75d? | 2008-07-04 A | 2008-10-15 |  | 36% | 47.36d? | 0.25d |  |  |  | 330h | 80h |
| 3 | 1.1.1 | Pase de BD a Pippin |  | 0.5d? | 2008-08-11 A | 2008-08-11 A |  | 100% |  |  |  | start no earlier than 2008-08-11 | OP | 4h | 4h |
| 4 | 1.1.2 | Configuración de dominio web en Pippin |  | 1d? | 2008-08-08 | 2008-08-08 |  |  |  | 44d | 0d | start no earlier than 2008-08-08 | Cines Unidos | 8h |  |
| 5 | 1.1.3 | Configuración (producción) CRM - Contacto |  | 0.5d? | 2008-08-11 | 2008-08-11 | 4 |  |  | 44d | 0d |  | DS [75%]; OP [75%] | 6h |  |
| 6 | 1.1.4 | Limpieza de tablas en Pippin |  | 0.25d? | 2008-08-11 | 2008-08-11 | 5 |  |  | 44d | 0d |  | DS | 2h |  |
| 7 | 1.1.5 | Adiestramiento a personal Cines Unidos de Manejo de Contactos |  | 0.25d? | 2008-08-14 | 2008-08-14 | 6FS+3d |  |  | 44d |  | start no earlier than 2008-08-14 | GP | 2h |  |
| 8 | 1.1.6 | **Fase III - Integración** |  | 60.75d? | 2008-07-04 A | 2008-09-26 |  | 43% | 34.62d? | 0.25d | 0d |  |  | 236h | 76h |
| 9 | 1.1.6.1 | Integración Pagina Web (sin valores foraneos) |  | 20d | 2008-07-04 A | 2008-07-31 A |  | 100% |  |  |  | start no earlier than 2008-07-04 | DS [25%] | 40h | 40h |
| 10 | 1.1.6.2 | Entrega de Data en mdb Tiendas |  | 1d? | 2008-08-06 A | 2008-08-06 A |  | 100% |  |  |  | start no earlier than 2008-08-06 |  |  |  |
| 11 | 1.1.6.3 | Integración Tienda Cines Unidos |  | 8d | 2008-08-07 A | 2008-08-18 A | 10 | 100% |  |  |  |  | DS [50%] | 32h | 32h |
| 12 | 1.1.6.4 | Integración Transacciones Web |  | 8d | 2008-08-19 | 2008-08-28 | 11 |  |  | 21d |  |  | DS [50%] | 32h |  |
| 13 | 1.1.6.5 | Entrega a GWT de lista de valores Ciudad, Estado, Cinemas Sitio Web | milestone | 0d? | 2008-08-13 | 2008-08-13 |  |  |  | 0.25d | 0d | start no earlier than 2008-08-13 | Cines Unidos |  |  |
| 14 | 1.1.6.6 | Ajuste con Listas de Valores en Integración Sitio Web |  | 1d? | 2008-08-13 A | 2008-08-13 A | 13 | 100% |  |  |  |  | DS [50%] | 4h | 4h |
| 15 | 1.1.6.7 | Integración Vista |  | 7d | 2008-08-14 | 2008-08-22 | 14 |  |  | 0.25d | 0d |  | DS [50%] | 28h |  |
| 16 | 1.1.6.8 | Integración CC Vista |  | 12d | 2008-08-25 | 2008-09-09 | 15 |  |  | 0.25d | 0d |  | DS [50%] | 48h |  |
| 17 | 1.1.6.9 | Pruebas internas |  | 3.75d | 2008-09-10 | 2008-09-15 | 16 |  |  | 0.25d | 0d |  | GP [10%]; DS | 32h |  |
| 18 | 1.1.6.10 | Ajustes recomendados |  | 4d | 2008-09-15 | 2008-09-19 | 17 |  |  | 0.25d | 0d |  | DS [50%] | 16h |  |
| 19 | 1.1.6.11 | Apoyo en Pruebas de Certificación |  | 5d | 2008-09-19 | 2008-09-26 | 18 |  |  | 0.25d |  |  | DS [10%] | 4h |  |
| 20 | 1.1.7 | Migración de Programas de Integración a Pippin |  | 2d | 2008-09-26 | 2008-09-30 | 8 |  |  | 0.25d | 0d |  | DS [50%]; OP [25%] | 8h |  |
| 21 | 1.1.8 | Preparación Pruebas de Certificación |  | 3d | 2008-09-30 | 2008-10-03 | 20 |  |  | 0.25d | 0d |  | DS [50%] | 12h |  |
| 22 | 1.1.9 | Pruebas de Certificación |  | 5d | 2008-10-03 | 2008-10-10 | 21 |  |  | 0.25d | 0d |  | Cines Unidos | 40h |  |
| 23 | 1.1.10 | Pase a Producción de Integraciones |  | 3d | 2008-10-10 | 2008-10-15 | 22 |  |  | 0.25d |  |  | OP [50%] | 12h |  |
| 24 | 1.2 | **Etapa III - Inteligencia de Negocio** |  | 11.14d | 2008-06-10 A | 2008-06-25 A |  | 100% |  |  |  |  |  | 98h | 98h |
| 25 | 1.2.1 | Evaluación tecnológica de Pentaho |  | 11.14d | 2008-06-10 A | 2008-06-25 A |  | 100% |  |  |  | finish no earlier than 2008-06-25 | DS; GP [10%] | 98h | 98h |
| 26 | 1.3 | Gerencia de Proyectos |  | 82.5d | 2008-06-03 A | 2008-10-15 |  | 47% | 43.73d | 0d |  | finish no earlier than 2008-10-15 | GP [10%] | 66h | 31.02h |

Notes:
- 7: Depende de las actividades anteriores
