# Nuevo Pendientes-Factibles

Schedule from MS Project, 2008-06-10 to 2008-10-28, A marks actual dates.
KATET

## Calendars

- Estándar: Mon-Fri 09:00-13:00, 15:00-19:00; Sat-Sun off.

## Resources

| Resource |
| --- |
| GP |
| OP |
| DS |
| Cines Unidos |

## Schedule

| ID | WBS | Task | Type | Duration | Start | Finish | Predecessors | Complete | Remaining | Total slack | Free slack | Constraint | Resources | Work | Actual work |
| --- | --- | --- | --- | --- | --- | --- | --- | --- | --- | --- | --- | --- | --- | --- | --- |
| 1 | 1 | **Cines Unidos** |  | 99.9d | 2008-06-10 A | 2008-10-28 |  | 56% | 44.34d | 0d |  |  |  | 434h | 229.8h |
| 2 | 1.1 | **Etapa I y II** |  | 82.76d | 2008-07-04 A | 2008-10-28 |  | 38% | 51.1d | 0d |  |  |  | 282h | 94h |
| 3 | 1.1.1 | Pase de BD a Pippin |  | 0.5d | 2008-08-11 A | 2008-08-11 A |  | 100% |  |  |  | start no earlier than 2008-08-11 | OP | 4h | 4h |
| 4 | 1.1.2 | **Fase III - Integración** |  | 70.76d | 2008-07-04 A | 2008-10-10 |  | 47% | 37.38d | 0d |  |  |  | 250h | 90h |
| 5 | 1.1.2.1 | Integración Pagina Web (sin valores foráneos) |  | 20d | 2008-07-04 A | 2008-07-31 A |  | 100% |  |  |  | start no earlier than 2008-07-04 | DS [25%] | 40h | 40h |
| 6 | 1.1.2.2 | Entrega de Data en mdb Tiendas |  | 1d | 2008-08-06 A | 2008-08-06 A |  | 100% |  |  |  | start no earlier than 2008-08-06 |  |  |  |
| 7 | 1.1.2.3 | Integración Tienda Cines Unidos |  | 8d | 2008-08-07 A | 2008-08-18 A | 6 | 100% |  |  |  |  | DS [50%] | 32h | 32h |
| 8 | 1.1.2.4 | Ajuste con Listas de Valores en Integración Sitio Web |  | 1d | 2008-08-13 A | 2008-08-13 A | 7 | 100% |  |  |  |  | DS [50%] | 4h | 4h |
| 9 | 1.1.2.5 | Modificación Formulario de Contacto para Sitio Web |  | 1d | 2008-08-21 A | 2008-08-21 A |  | 100% |  |  |  | start no earlier than 2008-08-21 | DS | 8h | 8h |
| 10 | 1.1.2.6 | Pruebas de Certificación de Módulo de Contacto en Pippin |  | 1d | 2008-08-22 A | 2008-08-22 A | 9 | 100% |  |  |  |  | Cines Unidos |  |  |
| 11 | 1.1.2.7 | Entrega a GWT de lista de valores Ciudad, Estado y Cinemas de Sitio Web | milestone | 0d | 2008-08-22 A | 2008-08-22 |  | 90% | 0d | 0d |  | start no earlier than 2008-08-22 |  |  |  |
| 12 | 1.1.2.8 | Ajuste de Integración Sitio Web con listas de valores reales |  | 0.5d | 2008-08-22 | 2008-08-22 | 11 |  |  | 35.26d |  |  | DS [50%] | 2h |  |
| 13 | 1.1.2.9 | Preparación material para adiestramiento Módulo de Contacto |  | 0.5d | 2008-08-25 A | 2008-08-25 A |  | 100% |  |  |  | start no earlier than 2008-08-25 | GP | 4h | 4h |
| 14 | 1.1.2.10 | Adiestramiento a personal Cines Unidos en Manejo de Contactos |  | 0.25d | 2008-08-27 A | 2008-08-27 A |  | 100% |  |  |  | start no earlier than 2008-08-27 | GP | 2h | 2h |
| 15 | 1.1.2.11 | Limpieza de tablas en Pippin |  | 0.4d | 2008-08-27 | 2008-08-27 | 14 |  |  | 31.11d | 0d |  | DS [50%]; OP [25%] | 2h |  |
| 16 | 1.1.2.12 | CRM con Módulo de Contacto en Producción |  | 1d | 2008-08-27 | 2008-08-28 | 15 |  |  | 31.11d |  |  |  |  |  |
| 17 | 1.1.2.13 | Integración Transacciones Web |  | 8d | 2008-08-25 | 2008-09-03 |  |  |  | 0d |  | start no earlier than 2008-08-25 | DS [50%] | 32h |  |
| 18 | 1.1.2.14 | Integración Vista |  | 7d | 2008-09-04 | 2008-09-12 | 17 |  |  | 0d |  |  | DS [50%] | 28h |  |
| 19 | 1.1.2.15 | Integración CC Vista |  | 12d | 2008-09-15 | 2008-09-30 | 18 |  |  | 0d |  |  | DS [50%] | 48h |  |
| 20 | 1.1.2.16 | Pruebas internas |  | 3.76d | 2008-10-01 | 2008-10-06 | 19 |  |  | 0d |  |  | GP [10%]; DS | 32h |  |
| 21 | 1.1.2.17 | Ajustes recomendados |  | 4d | 2008-10-06 | 2008-10-10 | 20 |  |  | 0d |  |  | DS [50%] | 16h |  |
| 22 | 1.1.3 | Migración de Programas de Integración a Pippin (dir desarrollo) |  | 2d | 2008-10-10 | 2008-10-14 | 4 |  |  | 0d |  |  | DS [50%]; OP [25%] | 8h |  |
| 23 | 1.1.4 | Preparación Pruebas de Certificación |  | 3d | 2008-10-14 | 2008-10-17 | 22 |  |  | 0d |  |  | DS [50%] | 12h |  |
| 24 | 1.1.5 | Apoyo en Pruebas de Certificación |  | 5d | 2008-10-17 | 2008-10-24 | 23 |  |  | 2d |  |  | DS [10%] | 4h |  |
| 25 | 1.1.6 | Pruebas de Certificación por parte de Cines Unidos |  | 5d | 2008-10-17 | 2008-10-24 | 23 |  |  | 0d |  |  |  |  |  |
| 26 | 1.1.7 | Pase a Producción de Integraciones |  | 1d | 2008-10-24 | 2008-10-27 | 25 |  |  | 0d |  |  | OP [50%] | 4h |  |
| 27 | 1.1.8 | CRM completo en Producción | milestone | 1d | 2008-10-27 | 2008-10-28 | 26 |  |  | 0d |  |  |  |  |  |

| ID | WBS | Task | Type | Duration | Start | Finish | Predecessors | Complete | Remaining | Total slack | Constraint | Resources | Work | Actual work |
| --- | --- | --- | --- | --- | --- | --- | --- | --- | --- | --- | --- | --- | --- | --- |
| 28 | 1.2 | **Etapa III - Inteligencia de Negocio** |  | 12.14d | 2008-06-10 A | 2008-06-26 A |  | 100% |  |  |  |  | 98h | 98h |
| 29 | 1.2.1 | Evaluación tecnológica de Pentaho |  | 11.14d | 2008-06-10 A | 2008-06-25 A |  | 100% |  |  | finish no earlier than 2008-06-25 | DS; GP [10%] | 98h | 98h |
| 30 | 1.2.2 | Informe comparativo entregado | milestone | 1d | 2008-06-26 A | 2008-06-26 A | 29 | 100% |  |  |  |  |  |  |
| 31 | 1.3 | Gerencia de Proyectos |  | 67.5d | 2008-07-04 A | 2008-10-27 |  | 70% | 20.25d | 0.76d | start no earlier than 2008-07-04 | GP [10%] | 54h | 37.8h |
