# Cronograma Bucarello

Schedule from MS Project, 2008-09-29 to 2008-11-11.
gwt

## Calendars

- Estándar: Mon-Fri 09:00-13:00, 15:00-19:00; Sat-Sun off.

## Schedule

| ID | WBS | Task | Duration | Start | Finish | Predecessors | Total slack | Free slack | Work |
| --- | --- | --- | --- | --- | --- | --- | --- | --- | --- |
| 1 | 1 | **Grupo Taras** | 32d? | 2008-09-29 | 2008-11-11 |  | 0d |  | 450h |
| 2 | 1.1 | **Página Web** | 5d? | 2008-09-29 | 2008-10-03 |  | 0d |  | 63h |
| 3 | 1.1.1 | Diseño visual del sitio | 1d? | 2008-09-29 | 2008-09-29 |  | 0d |  | 12h |
| 4 | 1.1.2 | Diseño estructural del sitio | 1d? | 2008-09-30 | 2008-09-30 | 3 | 27d | 0d | 19h |
| 5 | 1.1.3 | Creación de contenido | 1d? | 2008-10-01 | 2008-10-01 | 4 | 27d | 0d | 16h |
| 6 | 1.1.4 | Sistema de Noticias | 1d? | 2008-10-02 | 2008-10-02 | 5 | 27d | 0d | 8h |
| 7 | 1.1.5 | Contáctenos | 1d? | 2008-10-03 | 2008-10-03 | 6 | 27d |  | 8h |
| 8 | 1.2 | **Web Propietarios** | 9d? | 2008-09-30 | 2008-10-10 |  | 22d |  | 107h |
| 9 | 1.2.1 | Creación de tablas | 1d? | 2008-09-30 | 2008-09-30 | 3 | 22d | 0d | 2h |
| 10 | 1.2.2 | Programas pre-post-formula | 1d? | 2008-10-01 | 2008-10-01 | 9 | 22d | 0d | 8h |
| 11 | 1.2.3 | Listas y Reportes Básicos | 1d? | 2008-10-02 | 2008-10-02 | 10 | 22d | 0d | 12h |
| 12 | 1.2.4 | Pantalla Principal (estado de cuenta) | 1d? | 2008-10-03 | 2008-10-03 | 11 | 22d | 0d | 12h |
| 13 | 1.2.5 | Mostrar recibo | 1d? | 2008-10-06 | 2008-10-06 | 12 | 22d | 0d | 16h |
| 14 | 1.2.6 | Permitir pago | 1d? | 2008-10-07 | 2008-10-07 | 13 | 22d | 0d | 12h |
| 15 | 1.2.7 | Recibir sugerencias | 1d? | 2008-10-08 | 2008-10-08 | 14 | 22d | 0d | 8h |
| 16 | 1.2.8 | Login Registro de entradas al sistema | 1d? | 2008-10-09 | 2008-10-09 | 15 | 22d | 0d | 8h |
| 17 | 1.2.9 | Vistas extendidas y otros reportes | 1d? | 2008-10-10 | 2008-10-10 | 16 | 22d |  | 29h |
| 18 | 1.3 | **Web Junta Condominio** | 13d? | 2008-09-30 | 2008-10-16 |  | 0d |  | 97h |
| 19 | 1.3.1 | Creación de tablas | 1d? | 2008-09-30 | 2008-09-30 | 3 | 0d |  | 2h |
| 20 | 1.3.2 | Programas pre-post-formula | 1d? | 2008-10-01 | 2008-10-01 | 19 | 0d |  | 6h |
| 21 | 1.3.3 | Listas y Reportes Básicos | 1d? | 2008-10-02 | 2008-10-02 | 20 | 0d |  | 6h |
| 22 | 1.3.4 | Listado de Morosos | 1d? | 2008-10-03 | 2008-10-03 | 21 | 0d |  | 8h |
| 23 | 1.3.5 | Consulta de Balances | 1d? | 2008-10-06 | 2008-10-06 | 22 | 0d |  | 8h |
| 24 | 1.3.6 | Asamblea y Minutas | 1d? | 2008-10-07 | 2008-10-07 | 23 | 0d |  | 8h |
| 25 | 1.3.7 | Validacion Pre-condominio | 1d? | 2008-10-08 | 2008-10-08 | 24 | 0d |  | 11h |
| 26 | 1.3.8 | Hoja de supervision | 1d? | 2008-10-09 | 2008-10-09 | 25 | 0d |  | 8h |
| 27 | 1.3.9 | Gestion de caja Chica | 1d? | 2008-10-10 | 2008-10-10 | 26 | 0d |  | 8h |
| 28 | 1.3.10 | Recibir sugerencias | 1d? | 2008-10-13 | 2008-10-13 | 27 | 0d |  | 8h |
| 29 | 1.3.11 | Login Registro de entradas al sistema | 1d? | 2008-10-14 | 2008-10-14 | 28 | 0d |  | 8h |
| 30 | 1.3.12 | Envio de Email propietarios | 1d? | 2008-10-15 | 2008-10-15 | 29 | 0d |  | 8h |
| 31 | 1.3.13 | Vistas extendidas y otros reportes | 1d? | 2008-10-16 | 2008-10-16 | 30 | 0d |  | 8h |

| ID | WBS | Task | Duration | Start | Finish | Predecessors | Total slack | Free slack | Work |
| --- | --- | --- | --- | --- | --- | --- | --- | --- | --- |
| 32 | 1.4 | **Web Alquileres** | 9d? | 2008-10-17 | 2008-10-29 |  | 0d |  | 36h |
| 33 | 1.4.1 | Creación de tablas | 1d? | 2008-10-17 | 2008-10-17 | 31 | 0d |  | 2h |
| 34 | 1.4.2 | Programas pre-post-formula | 1d? | 2008-10-20 | 2008-10-20 | 33 | 0d |  | 2h |
| 35 | 1.4.3 | Listas y Reportes Básicos | 1d? | 2008-10-21 | 2008-10-21 | 34 | 0d |  | 2h |
| 36 | 1.4.4 | Pantalla Principal (estado de cuenta) | 1d? | 2008-10-22 | 2008-10-22 | 35 | 0d |  | 4h |
| 37 | 1.4.5 | Mostrar recibo | 1d? | 2008-10-23 | 2008-10-23 | 36 | 0d |  | 4h |
| 38 | 1.4.6 | Permitir pago | 1d? | 2008-10-24 | 2008-10-24 | 37 | 0d |  | 8h |
| 39 | 1.4.7 | Recibir sugerencias | 1d? | 2008-10-27 | 2008-10-27 | 38 | 0d |  | 2h |
| 40 | 1.4.8 | Login Registro de entradas al sistema inquilinos y propietarios | 1d? | 2008-10-28 | 2008-10-28 | 39 | 0d |  | 4h |
| 41 | 1.4.9 | Vistas extendidas y otros reportes | 1d? | 2008-10-29 | 2008-10-29 | 40 | 0d |  | 8h |
| 42 | 1.5 | **Intranet** | 9d? | 2008-10-30 | 2008-11-11 |  | 0d |  | 147h |
| 43 | 1.5.1 | **Módulo de Envio de Informacion** | 5d? | 2008-10-30 | 2008-11-05 |  | 4d |  | 20h |
| 44 | 1.5.1.1 | Creación de tablas | 1d? | 2008-10-30 | 2008-10-30 | 41 | 4d | 0d | 2h |
| 45 | 1.5.1.2 | Programas pre-post-formula | 1d? | 2008-10-31 | 2008-10-31 | 44 | 4d | 0d | 2h |
| 46 | 1.5.1.3 | Listas y Reportes | 1d? | 2008-11-03 | 2008-11-03 | 45 | 4d | 0d | 2h |
| 47 | 1.5.1.4 | Vistas extendidas y otros reportes | 1d? | 2008-11-04 | 2008-11-04 | 46 | 4d | 0d | 6h |
| 48 | 1.5.1.5 | Envios automaticos Via e-mail/SMA | 1d? | 2008-11-05 | 2008-11-05 | 47 | 4d |  | 8h |
| 49 | 1.5.2 | **Módulo de Cobranzas** | 8d? | 2008-10-30 | 2008-11-10 |  | 1d |  | 30h |
| 50 | 1.5.2.1 | Creación de tablas | 1d? | 2008-10-30 | 2008-10-30 | 41 | 1d | 0d | 2h |
| 51 | 1.5.2.2 | Programas pre-post-formula | 1d? | 2008-10-31 | 2008-10-31 | 50 | 1d | 0d |  |
| 52 | 1.5.2.3 | Listas y Reportes | 1d? | 2008-11-03 | 2008-11-03 | 51 | 1d | 0d | 12h |
| 53 | 1.5.2.4 | Vistas extendidas y otros reportes | 1d? | 2008-11-04 | 2008-11-04 | 52 | 1d | 0d |  |
| 54 | 1.5.2.5 | Reportes de llamadas diarias | 1d? | 2008-11-05 | 2008-11-05 | 53 | 1d | 0d | 2h |
| 55 | 1.5.2.6 | Confirmacion cobro | 1d? | 2008-11-06 | 2008-11-06 | 54 | 1d | 0d | 4h |
| 56 | 1.5.2.7 | Interfaz con AS400 | 1d? | 2008-11-07 | 2008-11-07 | 55 | 1d | 0d | 8h |
| 57 | 1.5.2.8 | Pantalla principal para Analistas de cobranzas | 1d? | 2008-11-10 | 2008-11-10 | 56 | 1d |  | 2h |

| ID | WBS | Task | Duration | Start | Finish | Predecessors | Total slack | Work |
| --- | --- | --- | --- | --- | --- | --- | --- | --- |
| 58 | 1.5.3 | **Módulo Gestion Solicitudes y Sugerencias y tareas pendientes** | 7d? | 2008-10-30 | 2008-11-07 |  | 0d | 48h |
| 59 | 1.5.3.1 | Creación de tablas (Llamadas, Tickets) | 1d? | 2008-10-30 | 2008-10-30 | 41 | 0d | 2h |
| 60 | 1.5.3.2 | Programas pre-post-formula | 1d? | 2008-10-31 | 2008-10-31 | 59 | 0d | 2h |
| 61 | 1.5.3.3 | Listas y Reportes | 1d? | 2008-11-03 | 2008-11-03 | 60 | 0d | 8h |
| 62 | 1.5.3.4 | Vistas extendidas y otros reportes | 1d? | 2008-11-04 | 2008-11-04 | 61 | 0d | 14h |
| 63 | 1.5.3.5 | Pantalla principal para Solicitudes y Sugerencias | 1d? | 2008-11-05 | 2008-11-05 | 62 | 0d | 4h |
| 64 | 1.5.3.6 | Reporte- Alarmas tareas excedidas tiempo | 1d? | 2008-11-06 | 2008-11-06 | 63 | 0d | 4h |
| 65 | 1.5.3.7 | Reportes de casos por tipos, estadisticas | 1d? | 2008-11-07 | 2008-11-07 | 64 | 0d | 10h |
| 66 | 1.5.3.8 | **General - Diseño** | 1d? | 2008-10-31 | 2008-10-31 |  | 7d | 4h |
| 67 | 1.5.3.8.1 | Panel y Pantalla Principal | 1d? | 2008-10-31 | 2008-10-31 | 44 | 7d | 4h |
| 68 | 1.5.4 | **Carga de datos Interfaces** | 2d? | 2008-11-10 | 2008-11-11 |  | 0d | 19h |
| 69 | 1.5.4.1 | Programas de carga | 1d? | 2008-11-10 | 2008-11-10 | 65 | 0d | 11h |
| 70 | 1.5.4.2 | Carga y Revisión | 1d? | 2008-11-11 | 2008-11-11 | 69 | 0d | 8h |
| 71 | 1.5.5 | Pruebas | 1d? | 2008-11-10 | 2008-11-10 | 65 | 1d | 25h |
| 72 | 1.5.6 | Documentación | 1d? | 2008-11-10 | 2008-11-10 | 65 | 1d | 5h |
