# Cronograma

Schedule from MS Project, 2008-10-03 to 2009-03-10.
KATET

## Calendars

- Estándar: Mon-Fri 09:00-13:00, 15:00-19:00; Sat-Sun off. Exceptions (off unless hours are given): 2008-12-15 to 2009-01-16 (colectivas).

## Resources

| Resource |
| --- |
| DR |
| OP |
| GP |

## Schedule

| ID | WBS | Task | Duration | Start | Finish | Predecessors | Total slack | Free slack | Constraint | Resources | Work |
| --- | --- | --- | --- | --- | --- | --- | --- | --- | --- | --- | --- |
| 1 | 1 | **CRM Revensub** | 87.88d? | 2008-10-03 | 2009-03-10 |  | 0d |  |  |  | 333h |
| 2 | 1.1 | Análisis y modelaje de datos | 5d? | 2008-10-03 | 2008-10-09 |  | 82.88d |  | start no earlier than 2008-10-03 | DR [50%] | 20h |
| 3 | 1.2 | Documento de Especificaciones | 4d? | 2008-10-29 | 2008-11-03 |  | 65.88d |  | start no earlier than 2008-10-29 | DR [50%] | 16h |
| 4 | 1.3 | **Desarrollo** | 32.5d? | 2008-11-06 | 2009-01-26 |  | 0d |  |  |  | 136h |
| 5 | 1.3.1 | Validaciones Formularios | 5d? | 2008-11-06 | 2008-11-12 |  | 0d |  | start no earlier than 2008-11-06 | DR [50%] | 20h |
| 6 | 1.3.2 | Página Principal | 5d? | 2008-11-13 | 2008-11-19 | 5 | 0d |  |  | DR [50%] | 20h |
| 7 | 1.3.3 | Uso de plantillas | 6d? | 2008-11-20 | 2008-11-27 | 6 | 0d |  |  | DR [50%] | 24h |
| 8 | 1.3.4 | Asignación de Responsables | 3d? | 2008-11-28 | 2008-12-02 | 7 | 0d |  |  | DR [50%] | 12h |
| 9 | 1.3.5 | Mis Tareas | 2d? | 2008-12-03 | 2008-12-04 | 8 | 0d |  |  | DR [50%] | 8h |
| 10 | 1.3.6 | Vista extendida Empresas | 1.5d? | 2008-12-05 | 2008-12-08 | 9 | 0d |  |  | DR [50%] | 6h |
| 11 | 1.3.7 | Vista extendida Contactos | 1.5d? | 2008-12-08 | 2008-12-09 | 10 | 0d |  |  | DR [50%] | 6h |
| 12 | 1.3.8 | Vista extendida Eventos | 1.5d? | 2008-12-10 | 2008-12-11 | 11 | 0d |  |  | DR [50%] | 6h |
| 13 | 1.3.9 | Ingreso de Tareas a Interacicones, Eventos y Empresas | 3d? | 2008-12-11 | 2009-01-20 | 12 | 0d |  |  | DR [50%] | 12h |
| 14 | 1.3.10 | Historial de cambios en tablas | 1d? | 2009-01-20 | 2009-01-21 | 13 | 0d |  |  | DR [50%] | 4h |
| 15 | 1.3.11 | Perfiles de acceso | 2d? | 2009-01-21 | 2009-01-23 | 14 | 0d |  |  | DR [50%] | 8h |
| 16 | 1.3.12 | Manejo Multiempresa | 1d? | 2009-01-23 | 2009-01-26 | 15 | 0d |  |  |  | 10h |
| 17 | 1.4 | **Reportes** | 6d? | 2009-01-26 | 2009-02-03 |  | 0d |  |  |  | 24h |
| 18 | 1.4.1 | Gestión de usuarios | 4d? | 2009-01-26 | 2009-01-30 | 4 | 0d |  |  | DR [50%] | 16h |
| 19 | 1.4.2 | Prospectos | 2d? | 2009-01-30 | 2009-02-03 | 18 | 0d |  |  | DR [50%] | 8h |
| 20 | 1.5 | Carga de datos de Contactos | 2d? | 2009-02-03 | 2009-02-05 | 17 | 0.38d | 0d |  | DR [50%] | 8h |
| 21 | 1.6 | Guia de Usuario | 4d? | 2009-02-05 | 2009-02-11 | 20 | 0.38d | 0d |  | DR [50%] | 16h |
| 22 | 1.7 | Certificación Cliente | 10d | 2009-02-11 | 2009-02-25 | 21 | 0.38d | 0d |  |  | 40h |
| 23 | 1.8 | Ajustes | 4d? | 2009-02-25 | 2009-03-03 | 22 | 0.38d | 0d |  | DR [50%] | 16h |
| 24 | 1.9 | Documentación Técnica | 5d? | 2009-03-03 | 2009-03-10 | 23 | 0.38d |  |  | DR [40%] | 16h |
| 25 | 1.10 | Puesta en Producción | 5d? | 2009-03-03 | 2009-03-10 | 23 | 0.38d |  |  | DR [10%]; OP [50%] | 8h |

| ID | WBS | Task | Duration | Start | Finish | Predecessors | Total slack | Constraint | Resources | Work |
| --- | --- | --- | --- | --- | --- | --- | --- | --- | --- | --- |
| 26 | 1.11 | **Gerencia de Proyectos** | 25.38d? | 2009-02-03 | 2009-03-10 | 19 | 0d |  |  | 33h |
| 27 | 1.11.1 | Control y Seguimiento | 25d? | 2009-02-03 | 2009-03-10 |  | 0d | start no earlier than 2008-11-06 | GP [15%] | 30h |
| 28 | 1.11.2 | Cierre | 0.38d? | 2009-03-10 | 2009-03-10 | 27 | 0d |  | GP | 3h |
