# Plan EDELCA

Schedule from MS Project, 2005-03-28 to 2005-06-30.
Personal

## Calendars

- Estándar: Mon-Fri 09:00-13:00, 15:00-19:00; Sat-Sun off.

## Schedule

| ID | WBS | Task | Duration | Start | Finish | Predecessors | Total slack | Free slack | Constraint |
| --- | --- | --- | --- | --- | --- | --- | --- | --- | --- |
| 1 | 1 | Proyecto Implantación de la Solución de GEDI EDELCA | 69d? | 2005-03-28 | 2005-06-30 |  | 0d |  | finish no earlier than 2005-06-30 |
| 2 | 2 | **Inicio** | 4d | 2005-03-28 | 2005-03-31 |  | 65d |  |  |
| 3 | 2.1 | Conformación del Equipo de Trabajo | 2d | 2005-03-28 | 2005-03-29 |  | 66d | 1d | finish no earlier than 2005-03-29 |
| 4 | 2.2 | Preparación Kickoff Interno | 2d | 2005-03-29 | 2005-03-30 |  | 65d | 0d | finish no earlier than 2005-03-30 |
| 5 | 2.3 | Kickoff interno del Proyecto | 1d | 2005-03-31 | 2005-03-31 | 3, 4 | 65d |  |  |
| 6 | 3 | **Revisión y Abrobación Plan de Trabajo del Proyecto** | 7d | 2005-04-01 | 2005-04-11 |  | 58d |  |  |
| 7 | 3.1 | Revisión detallada del Plan de Trabajo | 2d | 2005-04-01 | 2005-04-04 |  | 58d | 0d | finish no earlier than 2005-04-04 |
| 8 | 3.2 | Presentación al Cliente | 1d | 2005-04-05 | 2005-04-05 | 7 | 58d | 0d |  |
| 9 | 3.3 | Aprobación por parte del Cliente | 1d | 2005-04-06 | 2005-04-06 | 8 | 58d | 0d |  |
| 10 | 3.4 | Iniciar gestiones para adquisición de HW (Servidor y Unidad Respaldo) | 3d | 2005-04-07 | 2005-04-11 | 9 | 58d |  |  |
| 11 | 4 | **Elaborar Diseño Detallado de la Solución** | 40d? | 2005-04-07 | 2005-06-01 |  | 7d |  |  |
| 12 | 4.1 | Análisis de requerimientos | 1d? | 2005-04-07 | 2005-04-07 | 9 | 60d |  |  |
| 13 | 4.2 | Elaboración Matriz de requerimientos | 1d? | 2005-04-08 | 2005-04-08 | 9 | 58d | 0d | finish no earlier than 2005-04-08 |
| 14 | 4.3 | Aprobación del Cliente | 1d | 2005-04-11 | 2005-04-11 | 13 | 58d |  |  |
| 15 | 4.4 | Definir #sesiones de trabajo y participantes | 1d | 2005-04-11 | 2005-04-11 |  | 58d |  | start no earlier than 2005-04-11 |
| 16 | 4.5 | Preparación material para sesiones de trabajo | 3d | 2005-04-11 | 2005-04-13 |  | 5d | 0d | finish no earlier than 2005-04-13 |
| 17 | 4.6 | Ejecutar Sesiones de Trabajo | 10d | 2005-04-14 | 2005-04-27 | 16 | 5d | 0d |  |
| 18 | 4.7 | Ensamblar resultados de las sesiones de trabajo | 2d | 2005-04-28 | 2005-04-29 | 17 | 5d | 0d |  |
| 19 | 4.8 | Elaborar Informe Modelo Integrado de la Solución | 3d | 2005-05-02 | 2005-05-04 | 18 | 5d | 0d |  |
| 20 | 4.9 | Configurar prototipo Inicial de GEDI en instalaciones GWT | 2d | 2005-05-05 | 2005-05-06 | 19 | 5d | 0d |  |
| 21 | 4.10 | Publicar y entregar resultados | 1d | 2005-05-09 | 2005-05-09 | 20 | 13d | 0d |  |
| 22 | 4.11 | Aprobación por parte del Cliente | 1d | 2005-05-10 | 2005-05-10 | 21 | 13d | 0d |  |
| 23 | 4.12 | Entrega de requerimientos definitivos de Hardware | 1d | 2005-05-11 | 2005-05-11 | 22 | 13d | 0d |  |
| 24 | 4.13 | Arrendamiento/Alquiler/Compra de HW definitivo por EDELCA | 15d | 2005-05-12 | 2005-06-01 | 23 | 13d | 0d |  |

| ID | WBS | Task | Duration | Start | Finish | Predecessors | Total slack | Free slack | Constraint |
| --- | --- | --- | --- | --- | --- | --- | --- | --- | --- |
| 25 | 5 | **Configurar la Solución** | 26d | 2005-05-09 | 2005-06-13 |  | 5d |  |  |
| 26 | 5.1 | Instalar Software básico Apache/Net2Client | 3d | 2005-06-02 | 2005-06-06 | 24 | 13d | 0d |  |
| 27 | 5.2 | Configuración detallada de GEDI | 8d | 2005-05-09 | 2005-05-18 | 20 | 5d | 0d |  |
| 28 | 5.3 | Definir mecanismos de Respaldo y Recuperación | 1d | 2005-06-07 | 2005-06-07 | 26 | 13d | 0d |  |
| 29 | 5.4 | Implantar mecanismos de respaldo y recuperación | 2d | 2005-06-08 | 2005-06-09 | 28 | 13d | 0d |  |
| 30 | 5.5 | Documentar Mecanismos de Respaldo y Recuperación | 2d | 2005-06-10 | 2005-06-13 | 29 | 13d |  |  |
| 31 | 5.6 | Ejecutar plan de pruebas | 2d | 2005-05-19 | 2005-05-20 | 27 | 5d | 0d |  |
| 32 | 5.7 | Presentar Solución GEDI Final | 1d | 2005-05-23 | 2005-05-23 | 31 | 5d | 0d |  |
| 33 | 5.8 | Aprobación por parte del Cliente | 1d | 2005-05-24 | 2005-05-24 | 32 | 27d |  |  |
| 34 | 6 | **Implantar la Solución GEDI** | 20d | 2005-05-24 | 2005-06-20 |  | 5d |  |  |
| 35 | 6.1 | Diseñar adiestramiento a usuarios | 2d | 2005-05-24 | 2005-05-25 | 32 | 5d | 0d |  |
| 36 | 6.2 | Definir usuarios a adiestrar | 1d | 2005-05-24 | 2005-05-24 | 32 | 6d | 1d |  |
| 37 | 6.3 | Adiestrar a usuarios | 1d | 2005-05-26 | 2005-05-26 | 36, 35 | 5d | 0d |  |
| 38 | 6.4 | Comunicar Inicio de uso de la Solución | 1d | 2005-05-27 | 2005-05-27 | 37 | 5d | 0d |  |
| 39 | 6.5 | Monitoreo y Estabilización de la Solución | 15d | 2005-05-30 | 2005-06-17 | 38 | 5d | 0d |  |
| 40 | 6.6 | Entrega formal de la Solución al Cliente | 1d | 2005-06-20 | 2005-06-20 | 39 | 5d | 0d |  |
| 41 | 7 | Cierre del Proyecto | 3d | 2005-06-21 | 2005-06-23 | 40 | 5d |  |  |
| 42 | 8 | Control y Seguimiento del Proyecto | 69d? | 2005-03-28 | 2005-06-30 |  | 0d |  | finish no earlier than 2005-06-30 |
| 43 | 9 | Gerencia del Proyecto | 69d? | 2005-03-28 | 2005-06-30 |  | 0d |  | finish no earlier than 2005-06-30 |
