# Plan BANCO CARONI V4

Schedule from MS Project, 2005-04-18 to 2005-07-12.
Personal

## Calendars

- Estándar: Mon-Fri 09:00-13:00, 15:00-19:00; Sat-Sun off. Exceptions (off unless hours are given): 2005-04-18 08:00-12:00, 13:00-17:00, 2005-04-19, 2005-05-09, 2005-05-30, 2005-06-24, 2005-06-27, 2005-07-05.

## Resources

| Resource |
| --- |
| Félix Alvarez |
| Oveja Negra |
| Maria Elisa Ramirez |
| Judith Olivares |
| Joaquín García |
| Maria Ignacia Moreno |
| Rep TI Dayanara Vivas |
| Pedro Barbeito |
| PRODUCTO 1 |
| PRODUCTO 1: Matriz de Requerimientos Aprobada |
| Analista de Infraestructura de GWT |
| PRODUCTO 2: Prototipo Inicial y Model Integrado de la Solución |

## Schedule

| ID | WBS | Task | Duration | Start | Finish | Predecessors | Total slack | Free slack | Constraint | Resources | Work |
| --- | --- | --- | --- | --- | --- | --- | --- | --- | --- | --- | --- |
| 1 | 1 | **1. Proyecto Implantación de la Solución Página Web Banco Caroní** | 55.75d? | 2005-04-18 | 2005-07-12 |  | 0d |  |  |  | 1072.36h |
| 2 | 1.1 | **1.1 Inicio** | 3.86d | 2005-04-18 | 2005-04-22 |  | 51.77d |  |  |  | 43.04h |
| 3 | 1.1.1 | 1.1.1 Conformación del Equipo de Trabajo | 3d | 2005-04-18 | 2005-04-22 |  | 51.77d | 0d | start no earlier than 2005-04-18 | Judith Olivares [3%]; Maria Elisa Ramirez [3%] | 1.44h |
| 4 | 1.1.2 | 1.1.2 Preparación Kickoff Interno | 2d | 2005-04-18 | 2005-04-21 |  | 52.77d | 1d | start no earlier than 2005-04-18 | Judith Olivares; Maria Elisa Ramirez [10%] | 17.6h |
| 5 | 1.1.3 | 1.1.3 Kickoff interno del Proyecto | 0.86d | 2005-04-22 | 2005-04-22 | 3, 4 | 51.77d |  |  | Maria Elisa Ramirez [50%]; Judith Olivares; Oveja Negra [50%]; Joaquín García [50%]; Maria Ignacia Moreno [50%]; Rep TI Dayanara Vivas [50%]; Pedro Barbeito [50%] | 24h |
| 6 | 1.2 | **1.2 Revisión y Abrobación Plan de Trabajo del Proyecto** | 2.67d | 2005-04-22 | 2005-04-26 |  | 3.08d |  |  |  | 36.8h |
| 7 | 1.2.1 | 1.2.1 Revisión detallada del Plan de Trabajo | 1d | 2005-04-22 | 2005-04-22 |  | 3.08d | 0d | start no earlier than 2005-04-22 | Félix Alvarez; Judith Olivares; Oveja Negra [50%]; Joaquín García [50%]; Maria Ignacia Moreno [50%]; Rep TI Dayanara Vivas [50%] | 32h |
| 8 | 1.2.2 | 1.2.2 Presentación al Cliente | 0.67d | 2005-04-25 | 2005-04-25 | 7 | 3.08d | 0d |  | Judith Olivares [25%]; Maria Elisa Ramirez [25%]; Pedro Barbeito [25%] | 4h |
| 9 | 1.2.3 | 1.2.3 Aprobación por parte del Cliente | 1d | 2005-04-25 | 2005-04-26 | 8 | 3.08d | 0d | finish no earlier than 2005-04-25 | Maria Elisa Ramirez [5%]; Judith Olivares [5%] | 0.8h |
| 10 | 1.3 | **1.3 Elaborar Diseño Detallado de la Solución** | 32.75d? | 2005-04-25 | 2005-06-10 |  | 4.25d |  |  |  | 519.08h |
| 11 | 1.3.1 | 1.3.1 Preparar Matriz Inicial de Requerimientos | 1d | 2005-04-26 | 2005-04-27 | 9 | 45.08d | 0d |  | Judith Olivares [50%] | 4h |
| 12 | 1.3.2 | 1.3.2 Levantamiento de requerimientos (Taller de Trabajo) | 1d? | 2005-04-27 | 2005-04-28 | 11 | 45.08d | 0d |  | Félix Alvarez; Maria Elisa Ramirez; Judith Olivares; Joaquín García; Maria Ignacia Moreno | 40h |
| 13 | 1.3.3 | 1.3.3 Elaboración Matriz de requerimientos | 1d? | 2005-04-28 | 2005-04-29 | 12 | 45.08d | 0d | finish no earlier than 2005-04-08 | Judith Olivares | 8h |
| 14 | 1.3.4 | 1.3.4 Aprobación Matriz de requerimientos por el Cliente | 1d | 2005-04-29 | 2005-05-02 | 13 | 45.08d | 0d |  | Maria Elisa Ramirez [50%]; Joaquín García [50%]; Maria Ignacia Moreno [50%]; Pedro Barbeito [50%] | 16h |
| 15 | 1.3.5 | 1.3.5 PRODUCTO 1: Matriz de Requerimientos Aprobada | 1d? | 2005-05-02 | 2005-05-03 | 14 | 45.08d |  |  |  |  |
| 16 | 1.3.6 | 1.3.6 Recabar contenido | 22d | 2005-04-26 | 2005-05-27 | 9 | 3.08d | 0d |  | Joaquín García [50%]; Maria Ignacia Moreno [30%]; Maria Elisa Ramirez [5%]; Judith Olivares [5%]; Félix Alvarez [5%]; Rep TI Dayanara Vivas [5%] | 176h |
| 17 | 1.3.7 | **1.3.7 Elaborar diseños del Look&Feel de la Pagina Web** | 9d? | 2005-04-26 | 2005-05-06 |  | 4.5d |  |  |  | 54.4h |
| 18 | 1.3.7.1 | 1.3.7.2 Recibir requerimientos de Imagen de Oveja Negra | 1d? | 2005-04-26 | 2005-04-26 |  | 4.5d | 0d | start no earlier than 2005-04-26 | Oveja Negra [25%]; Félix Alvarez [25%]; Judith Olivares [25%] | 6h |
| 19 | 1.3.7.2 | 1.3.7.3 Preparar bocetos de diseño Web de la Página | 4d | 2005-04-27 | 2005-05-02 | 18 | 4.5d | 0d |  | Félix Alvarez [50%] | 16h |
| 20 | 1.3.7.3 | 1.3.7.4 Revisar bocetos con Oveja Negra | 1d? | 2005-05-03 | 2005-05-03 | 19 | 4.5d | 0d |  | Félix Alvarez [25%]; Oveja Negra [25%]; Judith Olivares [25%] | 6h |
| 21 | 1.3.7.4 | 1.3.7.5 Ajustar Bocetos y/o Prototipo Preliminar | 1d? | 2005-05-04 | 2005-05-04 | 20 | 4.5d | 0d |  | Félix Alvarez [50%] | 4h |
| 22 | 1.3.7.5 | 1.3.7.6 Someter bocetos y/o Prototipo Inicial Aprobación del Cliente | 2d | 2005-05-05 | 2005-05-06 | 21 | 4.5d | 0d |  | Félix Alvarez [20%]; Oveja Negra [20%]; Maria Elisa Ramirez [20%]; Judith Olivares [20%]; Joaquín García [20%]; Maria Ignacia Moreno [20%]; Pedro Barbeito [20%] | 22.4h |
| 23 | 1.3.8 | **1.3.8 Definir y documentar Modelo Integrado de la Solución** | 32.75d? | 2005-04-25 | 2005-06-10 |  | 4.25d |  |  |  | 220.68h |
| 24 | 1.3.8.1 | 1.3.8.1 Definir #sesiones de trabajo y participantes | 1d | 2005-05-02 | 2005-05-02 |  | 45.75d |  | start no earlier than 2005-05-02 | Judith Olivares [20%]; Maria Elisa Ramirez [20%] | 3.2h |
| 25 | 1.3.8.2 | 1.3.8.2 Preparación material para sesiones de trabajo | 2d | 2005-05-02 | 2005-05-03 |  | 39.75d | 0d | start no earlier than 2005-05-02 | Judith Olivares [50%] | 8h |
| 26 | 1.3.8.3 | 1.3.8.3 Ejecutar Sesiones de Trabajo | 2d | 2005-05-04 | 2005-05-05 | 25 | 39.75d | 0d |  | Judith Olivares; Maria Elisa Ramirez; Joaquín García; Maria Ignacia Moreno; Pedro Barbeito | 80h |
| 27 | 1.3.8.4 | 1.3.8.4 Ensamblar resultados de las sesiones de trabajo | 1d | 2005-05-06 | 2005-05-06 | 26 | 39.75d | 0d |  | Judith Olivares [50%] | 4h |
| 28 | 1.3.8.5 | 1.3.8.5 Elaborar Informe Modelo Integrado de la Solución | 2d | 2005-05-10 | 2005-05-11 | 27 | 39.75d |  |  | Judith Olivares [50%] | 8h |
| 29 | 1.3.8.6 | 1.3.8.6 Configurar prototipo Inicial Página Web en instalaciones GWT | 6.25d | 2005-05-10 | 2005-05-18 | 22 | 4.5d | 0d |  | Félix Alvarez [80%]; Judith Olivares [20%] | 48h |
| 30 | 1.3.8.7 | 1.3.8.7 Publicar y entregar resultados | 1d | 2005-05-18 | 2005-05-19 | 29 | 4.5d | 0d |  | Judith Olivares [10%] | 0.8h |
| 31 | 1.3.8.8 | 1.3.8.8 PRODUCTO 2: Prototipo Inicial y Model Integrado de la Solución | 1d? | 2005-05-19 | 2005-05-20 | 30, 29 | 4.5d | 0d |  |  |  |
| 32 | 1.3.8.9 | 1.3.8.9 Aprobación del Producto 2 por el cliente | 1d? | 2005-05-20 | 2005-05-23 | 31 | 4.5d | 0d |  | Maria Elisa Ramirez [10%]; Judith Olivares [10%] | 1.6h |
| 33 | 1.3.8.10 | 1.3.8.10 Entrega de requerimientos definitivos de Hardware | 1d | 2005-05-23 | 2005-05-24 | 32 | 31.5d |  |  | Félix Alvarez [20%]; Analista de Infraestructura de GWT [20%]; Rep TI Dayanara Vivas [20%] | 4.8h |
| 34 | 1.3.8.11 | 1.3.8.11 Determinar requerimientos minimos de HW/SW | 4.75d? | 2005-04-25 | 2005-04-29 |  | 4.25d | 0.25d | finish no earlier than 2005-04-29 | Judith Olivares [3%]; Analista de Infraestructura de GWT [3%] | 2.28h |
| 35 | 1.3.8.12 | 1.3.8.12 Determinar requerimientos de acceso a servidor para instalación | 4.75d? | 2005-04-25 | 2005-04-29 |  | 31d | 0d | finish no earlier than 2005-04-29 | Judith Olivares [3%]; Analista de Infraestructura de GWT [3%] | 2.28h |
| 36 | 1.3.8.13 | 1.3.8.11 Arrendamiento/Alquiler/Compra de HW definitivo por Banco del Caroní | 27.75d | 2005-05-02 | 2005-06-10 | 34 | 4d | 0d | start no earlier than 2005-05-02 | Rep TI Dayanara Vivas [20%]; Maria Elisa Ramirez [3%]; Analista de Infraestructura de GWT [3%] | 57.72h |

Notes:
- 12: Se realizarían dos sesiones de 4 horas de duración cada una. Lo ideal serían dos mañanas.
- 15: PRODUCTO 1: Matriz de Requerimientos Aprobada
- 31: PRODUCTO 2: Prototipo Inicial y Model Integrado de la Solución

| ID | WBS | Task | Duration | Start | Finish | Predecessors | Total slack | Free slack | Constraint | Resources | Work |
| --- | --- | --- | --- | --- | --- | --- | --- | --- | --- | --- | --- |
| 37 | 1.4 | **1.4 Configurar la Solución** | 33d? | 2005-04-29 | 2005-06-17 |  | 14d |  |  |  | 216.8h |
| 38 | 1.4.1 | 1.4.2 Definir accesos | 1d? | 2005-04-29 | 2005-05-02 | 35 | 31d | 10.54d |  |  |  |
| 39 | 1.4.2 | 1.4.3 Instalar Software básico Apache/Net2Client | 1d | 2005-06-10 | 2005-06-13 | 36, 38 | 4d | 0d |  | Rep TI Dayanara Vivas; Analista de Infraestructura de GWT [50%] | 12h |
| 40 | 1.4.3 | 1.4.4 Configuración detallada de la Solución | 7d | 2005-05-27 | 2005-06-08 | 29, 16 | 3.08d | 0d |  | Félix Alvarez [70%]; Judith Olivares [10%] | 44.8h |
| 41 | 1.4.4 | 1.4.5 Definir mecanismos de Respaldo y Recuperación | 1d | 2005-06-13 | 2005-06-14 | 39 | 14d | 0d |  | Rep TI Dayanara Vivas; Analista de Infraestructura de GWT [30%] | 10.4h |
| 42 | 1.4.5 | 1.4.6 Implantar mecanismos de respaldo y recuperación | 2d | 2005-06-14 | 2005-06-16 | 41 | 14d | 0d |  | Rep TI Dayanara Vivas [50%] | 8h |
| 43 | 1.4.6 | 1.4.7 Documentar Mecanismos de Respaldo y Recuperación | 1d | 2005-06-16 | 2005-06-17 | 42 | 14d |  |  | Rep TI Dayanara Vivas; Analista de Infraestructura de GWT [10%] | 8.8h |
| 44 | 1.4.7 | 1.4.8 Documentar procesos internos de VP Sistemas | 15d | 2005-05-23 | 2005-06-14 | 32 | 4.5d | 1.42d | finish no earlier than 2005-06-03 | Rep TI Dayanara Vivas [50%] | 60h |
| 45 | 1.4.8 | 1.4.9 Ejecutar plan de pruebas | 2d | 2005-06-08 | 2005-06-10 | 40 | 3.08d | 0d |  | Félix Alvarez; Rep TI Dayanara Vivas [50%]; Analista de Infraestructura de GWT [30%] | 28.8h |
| 46 | 1.4.9 | 1.4.10 Presentar Solución Final | 1d | 2005-06-10 | 2005-06-13 | 45 | 3.08d | 0d |  | Félix Alvarez [50%]; Oveja Negra [50%]; Maria Elisa Ramirez [50%]; Judith Olivares [50%]; Joaquín García [50%]; Maria Ignacia Moreno [50%]; Rep TI Dayanara Vivas [50%]; Pedro Barbeito [50%] | 32h |
| 47 | 1.4.10 | 1.4.11 Migrar Solución a Servidor Web Definitivo | 1d? | 2005-06-13 | 2005-06-14 | 45, 39 | 4d | 0d |  | Félix Alvarez [50%] | 4h |
| 48 | 1.4.11 | 1.4.12 PRODUCTO 3: Solución Final | 1d | 2005-06-14 | 2005-06-15 | 47 | 4d | 0d |  |  |  |
| 49 | 1.4.12 | 1.4.13 Aprobación por parte del Cliente | 1d | 2005-06-15 | 2005-06-16 | 48 | 4d | 0.92d |  | Maria Elisa Ramirez | 8h |
| 50 | 1.5 | **1.5 Implantar la Solución** | 22.67d | 2005-05-25 | 2005-06-29 |  | 3.08d |  |  |  | 99.04h |
| 51 | 1.5.1 | 1.5.1 Programar Adiestramiento a Usuarios | 9d | 2005-05-25 | 2005-06-07 |  | 6.75d | 3.67d | start no earlier than 2005-05-25 | Maria Elisa Ramirez [10%]; Judith Olivares [2%] | 8.64h |
| 52 | 1.5.2 | 1.5.2 Diseñar adiestramiento a usuarios | 2d | 2005-06-13 | 2005-06-15 | 46, 51 | 3.08d | 0d |  | Judith Olivares; Félix Alvarez | 32h |
| 53 | 1.5.3 | 1.5.3 Definir usuarios a adiestrar | 2d | 2005-05-25 | 2005-05-26 |  | 15.75d | 12.67d | start no earlier than 2005-05-25 | Maria Elisa Ramirez [20%] | 3.2h |
| 54 | 1.5.4 | 1.5.4 Adiestrar a usuarios | 1d | 2005-06-15 | 2005-06-16 | 53, 52, 47, 44 | 3.08d | 0d |  | Félix Alvarez; Judith Olivares | 16h |
| 55 | 1.5.5 | 1.5.5 Comunicar Inicio de uso de la Solución | 1d | 2005-06-16 | 2005-06-17 | 54 | 3.08d | 0d |  | Maria Elisa Ramirez [10%] | 0.8h |
| 56 | 1.5.6 | 1.5.6 Monitoreo y Estabilización de la Solución | 5d | 2005-06-17 | 2005-06-28 | 55, 47, 49 | 3.08d | 0d |  | Félix Alvarez [20%]; Rep TI Dayanara Vivas [20%] | 16h |
| 57 | 1.5.7 | 1.5.7 Entrega formal de la Solución al Cliente | 1d | 2005-06-28 | 2005-06-29 | 56 | 3.08d | 0d |  | Félix Alvarez [40%]; Maria Elisa Ramirez [40%]; Judith Olivares [40%]; Joaquín García [40%]; Maria Ignacia Moreno [40%]; Rep TI Dayanara Vivas [40%]; Pedro Barbeito [40%] | 22.4h |
| 58 | 1.6 | **1.6 Cierre del Proyecto** | 5d? | 2005-06-29 | 2005-07-07 | 57 | 3.08d |  |  |  | 44h |
| 59 | 1.6.1 | 1.6.1 Cierre del Equipo | 1d? | 2005-06-29 | 2005-06-30 |  | 7.08d |  |  | Félix Alvarez [25%]; Oveja Negra [25%]; Maria Elisa Ramirez [25%]; Judith Olivares; Joaquín García [25%]; Maria Ignacia Moreno [25%]; Rep TI Dayanara Vivas; Pedro Barbeito [25%] | 28h |
| 60 | 1.6.2 | 1.6.2 Cierre Administrativo | 5d? | 2005-06-29 | 2005-07-07 |  | 3.08d |  |  | Maria Elisa Ramirez [20%]; Judith Olivares [20%] | 16h |

Notes:
- 48: PRODUCTO 3: Solución Final

| ID | WBS | Task | Duration | Start | Finish | Predecessors | Total slack | Free slack | Constraint | Resources | Work |
| --- | --- | --- | --- | --- | --- | --- | --- | --- | --- | --- | --- |
| 61 | 1.7 | **1.7 Revisión y Firma de Contrato** | 27.75d? | 2005-04-18 | 2005-05-27 |  | 28d |  |  |  | 24.4h |
| 62 | 1.7.1 | 1.7.1 Revisión de Contrato GWT-Legal | 8.75d? | 2005-04-18 | 2005-04-29 |  | 28.25d | 0.25d | finish no earlier than 2005-04-29 | Judith Olivares [2%] | 1.4h |
| 63 | 1.7.2 | 1.7.2 Revisión de Contrato por el Banco Caroní | 17.75d? | 2005-05-02 | 2005-05-26 | 62 | 28d | 0d | start no earlier than 2005-05-02 | Maria Elisa Ramirez [10%] | 14.2h |
| 64 | 1.7.3 | 1.7.3 Firma de Contrato | 1d? | 2005-05-26 | 2005-05-27 | 63 | 28d |  |  | Maria Elisa Ramirez; Judith Olivares [10%] | 8.8h |
| 65 | 1.8 | 1.8 Control y Seguimiento del Proyecto | 55.75d | 2005-04-18 | 2005-07-12 |  | 0d |  | start no earlier than 2005-04-18 | Judith Olivares [5%]; Maria Elisa Ramirez [5%] | 44.6h |
| 66 | 1.9 | 1.9 Gerencia del Proyecto | 55.75d | 2005-04-18 | 2005-07-12 |  | 0d |  | start no earlier than 2005-04-18 | Maria Elisa Ramirez [5%]; Judith Olivares [5%] | 44.6h |
