# planning fotoxs

Schedule from MS Project, 2005-07-15 to 2005-10-28, A marks actual dates.

## Calendars

- Standard: Mon-Fri 08:00-12:00, 13:00-17:00; Sat-Sun off.

## Resources

| Resource |
| --- |
| Veronica |
| Nelson |
| Jonathan |
| Eilyn |
| GWT1 |
| Claudia |
| Verónica |
| Gigliola |
| Meta |
| Aunb |

## Schedule

| ID | WBS | Task | Type | Duration | Start | Finish | Predecessors | Complete | Remaining | Total slack | Free slack | Constraint | Resources | Work | Actual work |
| --- | --- | --- | --- | --- | --- | --- | --- | --- | --- | --- | --- | --- | --- | --- | --- |
| 1 | 1 | **Modulo Comercial** |  | 74d? | 2005-07-19 A | 2005-10-28 |  | 40% | 44.4d? | 0d |  |  |  | 1120h | 448h |
| 2 | 1.1 | Ingreso Tarifa |  | 24d? | 2005-07-19 A | 2005-08-20 A |  | 100% |  |  |  | finish no earlier than 2005-08-20 | Veronica | 192h | 192h |
| 3 | 1.2 | Generacion Lista Precio |  | 29d? | 2005-07-19 A | 2005-08-27 A | 2 | 100% |  |  |  | start no earlier than 2005-07-19 | Verónica | 232h | 232h |
| 4 | 1.3 | Ingreso Natural |  | 3d? | 2005-08-29 | 2005-08-31 |  |  |  | 40d | 0d | finish no earlier than 2005-08-31 | Verónica | 24h |  |
| 5 | 1.4 | Ingreso Cliente Jurídico |  | 2d? | 2005-09-01 | 2005-09-02 | 4 |  |  | 40d |  | start no earlier than 2005-09-01 | Verónica | 16h |  |
| 6 | 1.5 | Reservacion |  | 54d? | 2005-07-19 | 2005-10-07 |  |  |  | 15d |  | finish no earlier than 2005-10-07 | Veronica | 432h |  |
| 7 | 1.6 | Modificar Ingreso Servicio para colocar el campo OBLIGATORIO |  | 3d? | 2005-08-16 A | 2005-08-18 A |  | 100% |  |  |  | finish no earlier than 2005-08-18 | Gigliola | 24h | 24h |
| 8 | 1.7 | Convenios |  | 3d? | 2005-09-06 | 2005-09-08 |  |  |  | 14d | 0d | finish no earlier than 2005-09-08 | Veronica | 24h |  |
| 9 | 1.8 | Programas Descuento |  | 3d? | 2005-09-09 | 2005-09-13 | 8 |  |  | 14d | 5d | start no earlier than 2005-09-09 | Veronica | 24h |  |
| 10 | 1.9 | CAPS |  | 4d | 2005-09-21 | 2005-09-26 | 9 |  |  | 9d |  | start no earlier than 2005-09-14 | Veronica | 32h |  |
| 11 | 1.10 | Búsquedas |  | 4d? | 2005-10-10 | 2005-10-13 | 10 |  |  | 0d |  | finish no earlier than 2005-10-13 | Veronica | 32h |  |
| 12 | 1.11 | Vistas Extendidas |  | 3d | 2005-10-14 | 2005-10-18 | 11 |  |  | 0d |  | finish no earlier than 2005-10-07 | Veronica | 24h |  |
| 13 | 1.12 | Tabla Equilibrio |  | 8d? | 2005-10-19 | 2005-10-28 | 12 |  |  | 0d |  | finish no earlier than 2005-10-11 | Veronica | 64h |  |
| 14 | 2 | **Módulo Operacional** |  | 76d? | 2005-07-15 A | 2005-10-28 |  | 4% | 72.58d? | 0d |  |  |  | 680h | 32h |
| 15 | 2.1 | Ingreso Estaciones |  | 1d? | 2005-09-22 | 2005-09-22 | 18 |  |  | 25.5d |  |  | Eilyn | 8h |  |
| 16 | 2.2 | Ingreso Orden 19 Ptos.(Falta validaciones en PRE y POST de la tabla) |  | 3d? | 2005-09-14 | 2005-09-16 | 23 |  |  | 17d | 0d | start no earlier than 2005-09-14 | Eilyn | 24h |  |
| 17 | 2.3 | Ingreso de Solicitud de Flota |  | 1d? | 2005-08-29 A | 2005-08-29 A |  | 100% |  |  |  | start no earlier than 2005-08-29 | Gigliola | 8h | 8h |
| 18 | 2.4 | Ingreso Orden Asignación (Falta act.htm por tipo de campo y validaciones en PRE y POST de la tabla) |  | 3d | 2005-09-19 | 2005-09-21 | 16 |  |  | 24.5d | 0d |  | Eilyn | 24h |  |
| 19 | 2.5 | Ingreso Solicitud de traslado |  | 1d? | 2005-08-22 A | 2005-08-22 A |  | 100% |  |  |  |  | Gigliola | 8h | 8h |
| 20 | 2.6 | Orden de Traslado | milestone | 0d? | 2005-08-29 A | 2005-09-02 A |  | 100% |  |  |  | finish no earlier than 2005-09-02 | Eilyn [50%] |  |  |
| 21 | 2.7 | Reporte Siniestro |  | 4d? | 2005-09-08 | 2005-09-13 |  |  |  | 33d |  | finish no earlier than 2005-09-13 | Jonathan | 32h |  |
| 22 | 2.8 | Ingreso Auditoría de Contrato.(Falta validaciones en PRE y POST de la tabla) |  | 2d? | 2005-09-07 A | 2005-09-08 A |  | 100% |  |  |  |  | Gigliola | 16h | 16h |
| 23 | 2.9 | Ingreso de Preingreso Unidad |  | 3d? | 2005-09-09 | 2005-09-13 |  |  |  | 17d | 0d | finish no earlier than 2005-09-13 |  |  |  |
| 24 | 2.10 | Ingreso Consignación Traslado (Falta act.htm por tipo de campo y validaciones en PRE y POST de la tabla) |  | 1d? | 2005-08-22 | 2005-08-22 |  |  |  | 49d |  |  |  |  |  |
| 25 | 2.11 | Apertura Contrato |  | 43d? | 2005-07-15 | 2005-09-15 |  |  |  | 1d |  | finish no earlier than 2005-09-15 | Nelson | 344h |  |
| 26 | 2.12 | Cierre Contrato |  | 11d? | 2005-09-21 | 2005-10-05 | 25 |  |  | 1d | 0d | start no earlier than 2005-09-16 | Nelson | 88h |  |
| 27 | 2.13 | Manejo de Contratos |  | 7d? | 2005-10-06 | 2005-10-14 | 26 |  |  | 1d |  | finish no earlier than 2005-10-11 | Nelson | 56h |  |
| 28 | 2.14 | Renovación automática de contratos |  | 6d? | 2005-10-18 | 2005-10-25 | 27 |  |  | 0d |  | finish no earlier than 2005-10-25 | Nelson | 48h |  |
| 29 | 2.15 | Facturas x venta vehículos |  | 3d? | 2005-10-26 | 2005-10-28 | 28 |  |  | 0d |  | start no earlier than 2005-10-26 | Nelson | 24h |  |

Notes:
- 20: Ingreso / Act.htm ocultando campos de cierre / Validaciones / Cierre de Orden / Busqueda / Vista Extendida
- 25: ·Apertura Contrato (Cliente, record conductor, Disponibilidad flota en estación y en la ciudad, listas de precio, tarifas, pagos(créditos, saldo), convenio (tarifas, grupo y subgrupo, vigencia del convenio))…Interfaz con digitalización..Apertura de Chequeo 19ptos / ·Impresión de contratos en apertura / ·
- 26: ·Cálculo del monto a pagar. Manejo de formas de pago / ·Facturas de Alquiler.(sin y con siniestros) .impresas en zonas de cobro del cliente / ·Facturas por Siniestro…impresas en zonas de cobro del cliente / ·Imprimir Facturas Pro forma y Precierre, ambas son iguales a excepción del título. Estas impresiones deben ser exactas a una factura sin Nro. Factura, ni Nro. de Control. Estas preformas se pueden imprimir en cualquier momento, sin importar que el contrato esté abierto. (en Inglés y Español) / ·Anular Facturas / ·Validación: No se puede facturar nuevamente un contrato a menos que exista una anulación de facturas
- 27: Manejo Tipo Contratos (extensión, upgrade, cambio por falla, cambio por gusto)

| ID | WBS | Task | Duration | Start | Finish | Total slack | Constraint | Resources | Work |
| --- | --- | --- | --- | --- | --- | --- | --- | --- | --- |
| 30 | 3 | **Módulo Mantenimiento** | 52d? | 2005-07-19 | 2005-09-28 | 22d |  |  | 304h |
| 31 | 3.1 | Ordenes de Trabajo | 34d? | 2005-07-19 | 2005-09-02 | 35d | finish no earlier than 2005-09-02 | Jonathan | 272h |
| 32 | 3.2 | Ordenes de lyC | 3d? | 2005-09-05 | 2005-09-07 | 37d | finish no earlier than 2005-09-07 | Jonathan | 24h |
| 33 | 3.3 | Solicitud Pedido | 1d? | 2005-09-01 | 2005-09-01 | 41d | start no earlier than 2005-09-01 | Gigliola | 8h |
| 34 | 3.4 | Pedidos | 4d? | 2005-09-05 | 2005-09-08 | 36d | start no earlier than 2005-09-05 |  |  |
| 35 | 3.5 | Producto | 1d | 2005-08-22 | 2005-08-22 | 49d |  |  |  |
| 36 | 3.6 | Ordenes de Salida de productos (asociadas o no a Ordenes de trabajo, manejo de devoluciones) | 4d? | 2005-09-22 | 2005-09-27 | 23d | finish no earlier than 2005-09-27 |  |  |
| 37 | 3.7 | Ordenes de Entrada de Productos (manejo de inventario, devoluciones) | 1d? | 2005-08-22 | 2005-08-22 | 49d |  |  |  |
| 38 | 3.8 | Facturación a Terceros | 4d? | 2005-09-23 | 2005-09-28 | 22d | finish no earlier than 2005-09-28 |  |  |
| 39 | 4 | Estadísticas | 7d? | 2005-10-20 | 2005-10-28 | 0d | finish no earlier than 2005-10-28 | Veronica | 56h |
| 40 | 5 | reportes | 12d? | 2005-10-13 | 2005-10-28 | 0d | finish no earlier than 2005-10-28 | Meta | 96h |
| 41 | 6 | Alarmas | 25d | 2005-09-01 | 2005-10-05 | 17d | start no earlier than 2005-09-01 | GWT1 | 200h |
| 42 | 7 | Interfaces | 8.5d? | 2005-09-29 | 2005-10-11 | 13.5d | start no earlier than 2005-09-29 | GWT1; Meta | 136h |
| 43 | 8 | Plan Contingencia | 1d? | 2005-08-22 | 2005-08-22 | 49d |  |  |  |

Notes:
- 31: Ingreso de OT / Cierre de OT / Busquedas / Vista Extendida / OT asociadas / Validaciones incluidas / Costos totalizados / O de Lavado y Comb asociadas / O Salida de Productos / ordenes de servicios asociadas
- 32: Falta act.htm por tipo de campo y validaciones en PRE y POST de la tabla / Ordenes de LyC asociadas a Vistas Extendida de O. Trabajo
- 35: Es posible que el producto no se ingrese por aqui, sino por great plane
