# PlanPreliminarHertz0604

Schedule from MS Project, 2005-04-08 to 2006-01-06, A marks actual dates.
gm

## Calendars

- Estándar: Mon-Fri 09:00-13:00, 15:00-19:00; Sat-Sun off.

## Resources

| Resource |
| --- |
| GM |
| usuario Funcional |
| Verónica |
| Todos |
| Nelson |
| Metadeveloper |
| Veronica |
| Meatdeveloper |
| Aron |
| recurso 1 |
| Recurso 2 …Claudia |
| Recurso 3 |

## Schedule

| ID | WBS | Task | Type | Duration | Start | Finish | Predecessors | Complete | Remaining | Baseline start | Baseline finish | Baseline duration | Total slack | Constraint | Resources | Work | Actual work |
| --- | --- | --- | --- | --- | --- | --- | --- | --- | --- | --- | --- | --- | --- | --- | --- | --- | --- |
| 1 | 1 | **Sistema Génesis - HERTZ Renta Motor** |  | 196d? | 2005-04-08 A | 2006-01-06 |  | 47% | 104.36d? | 2005-04-08 | 2005-12-30 | 191d? | 0d |  |  | 13365h | 6649.57h |
| 2 | 1.1 | Inicio |  | 3d? | 2005-04-08 | 2005-04-12 |  |  |  | 2005-04-19 | 2005-05-20 | 24d? | 193d | start no earlier than 2005-04-08 | GM | 24h |  |
| 3 | 1.2 | **Manejo Requerimientos** |  | 57d? | 2005-04-08 A | 2005-06-27 A |  | 100% |  | 2005-04-08 | 2005-05-31 | 38d? |  |  |  | 527h | 527h |
| 4 | 1.2.1 | Levantamiento de especificaciones |  | 21d | 2005-04-08 A | 2005-05-06 A |  | 100% |  | 2005-04-08 | 2005-05-06 | 21d |  | finish no earlier than 2005-05-06 | GM | 168h | 168h |
| 5 | 1.2.2 | **Análisis** |  | 53d? | 2005-04-14 A | 2005-06-27 A |  | 100% |  | 2005-04-14 | 2005-05-31 | 34d? |  |  |  | 335h | 335h |
| 6 | 1.2.2.1 | Plataforma |  | 3d? | 2005-04-14 A | 2005-04-18 A |  | 100% |  | 2005-04-14 | 2005-04-18 | 3d? |  | start no earlier than 2005-04-14 | GM | 24h | 24h |
| 7 | 1.2.2.2 | **Aplicación** |  | 27d? | 2005-05-20 A | 2005-06-27 A |  | 100% |  | 2005-05-09 | 2005-05-31 | 17d? |  |  | GM | 311h | 311h |
| 8 | 1.2.2.2.1 | Elaboracion Documento Especificaciones y Matríz Requerimiento |  | 3d? | 2005-05-20 A | 2005-05-24 A |  | 100% |  | 2005-05-12 | 2005-05-16 | 3d? |  | start no earlier than 2005-05-12 | GM | 24h | 24h |
| 9 | 1.2.2.2.2 | Entrega Especificaciones | milestone | 0d | 2005-05-25 A | 2005-05-25 A | 8 | 100% |  |  |  |  |  | start no earlier than 2005-05-25 |  |  |  |
| 10 | 1.2.2.2.3 | Aprobación de parte usuario |  | 3d? | 2005-05-25 A | 2005-05-27 A | 9 | 100% |  | 2005-05-17 | 2005-05-19 | 3d? |  |  | usuario Funcional | 24h | 24h |
| 11 | 1.2.2.2.4 | Elaboración Plan pruebas |  | 3d? | 2005-06-20 A | 2005-06-22 A |  | 100% |  | 2005-05-20 | 2005-05-24 | 3d? |  | start no earlier than 2005-06-20 | GM | 24h | 24h |
| 12 | 1.2.2.2.5 | Aprobacion Plan Pruebas |  | 3d? | 2005-06-23 A | 2005-06-27 A | 11 | 100% |  | 2005-05-25 | 2005-05-27 | 3d? |  |  | usuario Funcional | 24h | 24h |
| 13 | 1.2.2.2.6 | Documento con Plan de Pruebas | milestone | 0d? | 2005-06-27 A | 2005-06-27 A | 12 | 100% |  | 2005-05-27 | 2005-05-27 | 0d? |  | start no earlier than 2005-04-15 |  |  |  |
| 14 | 1.2.3 | Análisis y estrategia de trabajo conel grupo |  | 3d? | 2005-05-02 A | 2005-05-04 A |  | 100% |  | 2005-05-02 | 2005-05-04 | 3d? |  | finish no earlier than 2005-05-04 | Todos | 24h | 24h |
| 15 | 1.3 | **Diseño Aplicación** |  | 36d? | 2005-05-17 A | 2005-07-05 A |  | 100% |  | 2005-05-17 | 2005-07-01 | 34d? |  |  |  | 776h | 776h |
| 16 | 1.3.1 | Modelo Lógico BD |  | 7d? | 2005-05-17 A | 2005-05-31 A | 8 | 100% |  | 2005-05-17 | 2005-05-19 | 3d? |  | start no earlier than 2005-05-04 | GM | 56h | 56h |
| 17 | 1.3.2 | Modelo Lógico BD | milestone | 0d? | 2005-06-27 A | 2005-06-27 A | 16 | 100% |  |  |  |  |  | start no earlier than 2005-06-27 |  |  |  |
| 18 | 1.3.3 | Modelo Físico BD |  | 10d? | 2005-05-25 A | 2005-06-10 A | 17 | 100% |  | 2005-05-20 | 2005-05-26 | 4.93d? |  | finish no earlier than 2005-05-11 | Todos | 80h | 80h |
| 19 | 1.3.4 | Modelo de Integración |  | 5d? | 2005-05-17 A | 2005-05-26 A | 8 | 100% |  | 2005-05-17 | 2005-05-23 | 5d? |  |  | Nelson | 40h | 40h |
| 20 | 1.3.5 | Prediseño de Aplicación |  | 5d? | 2005-05-30 A | 2005-06-03 A |  | 100% |  | 2005-05-30 | 2005-06-03 | 5d? |  | start no earlier than 2005-05-04 | GM [60%]; Verónica [20%]; Nelson [20%]; Metadeveloper [20%] | 48h | 48h |
| 21 | 1.3.6 | Prototipo aplicación |  | 20d? | 2005-06-06 A | 2005-07-01 A | 20 | 100% |  | 2005-06-06 | 2005-07-01 | 20d? |  | finish no earlier than 2005-07-01 | Verónica; Nelson; Metadeveloper | 480h | 480h |
| 22 | 1.3.7 | Prototipo Aplicación | milestone | 0d | 2005-07-01 A | 2005-07-01 A |  | 100% |  | 2005-07-01 | 2005-07-01 | 0d |  | start no earlier than 2005-07-01 |  |  |  |
| 23 | 1.3.8 | Entonación Prototipo |  | 3d? | 2005-07-01 A | 2005-07-05 A | 22 | 100% |  | 2005-06-02 | 2005-06-06 | 3d? |  |  | Verónica; Nelson; Metadeveloper | 72h | 72h |
| 24 | 1.4 | **Carga Data Aplicación** |  | 127d? | 2005-06-15 A | 2005-12-08 |  | 30% | 88.89d? | 2005-05-30 | 2005-12-29 | 154d? | 21d |  |  | 344h | 192h |
| 25 | 1.4.1 | Análisis |  | 10d | 2005-06-15 A | 2005-06-28 A |  | 100% |  | 2005-05-30 | 2005-06-10 | 10d |  | start no earlier than 2005-06-15 | GM; usuario Funcional | 160h | 160h |

Notes:
- 19: Integracion con otros sistemas. Esquema de actualizacion de la información a nivel nacional. Integracion con Directorio Relacionados y Directorio de Trabajadores

| ID | WBS | Task | Type | Duration | Start | Finish | Predecessors | Complete | Remaining | Baseline start | Baseline finish | Baseline duration | Total slack | Free slack | Constraint | Resources | Work | Actual work |
| --- | --- | --- | --- | --- | --- | --- | --- | --- | --- | --- | --- | --- | --- | --- | --- | --- | --- | --- |
| 26 | 1.4.2 | **Preparación** |  | 7d? | 2005-06-29 A | 2005-07-07 | 25 | 29% | 5d? | 2005-06-13 | 2005-09-23 | 75d? | 131d |  |  |  | 112h | 32h |
| 27 | 1.4.2.1 | Estrategia |  | 7d? | 2005-06-29 A | 2005-07-07 |  | 29% | 5d? | 2005-06-13 | 2005-06-21 | 7d? | 131d |  | start no earlier than 2005-06-09 | GM; usuario Funcional | 112h | 32h |
| 28 | 1.4.2.2 | Documento con estrategia de Carga Datos | milestone | 0d? | 2005-07-07 | 2005-07-07 |  |  |  |  |  |  | 0d |  | start no earlier than 2005-07-07 |  |  |  |
| 29 | 1.4.3 | Data |  | 20d? | 2005-07-11 | 2005-08-05 |  |  |  | 2005-09-01 | 2005-09-23 | 17d? | 110d |  | start no earlier than 2005-07-11 |  |  |  |
| 30 | 1.4.4 | Carga adicional como baseline |  | 3d | 2005-12-06 | 2005-12-08 |  |  |  | 2005-12-06 | 2005-12-08 | 3d | 21d |  | start no earlier than 2005-12-06 | Meatdeveloper; GM; usuario Funcional | 72h |  |
| 31 | 1.5 | **Configuración Aplicación** |  | 3d? | 2005-05-02 A | 2005-05-04 A |  | 100% |  | 2005-05-02 | 2005-05-04 | 3d? |  |  |  |  | 24h | 24h |
| 32 | 1.5.1 | Ambiente N2C |  | 3d? | 2005-05-02 A | 2005-05-04 A |  | 100% |  | 2005-05-02 | 2005-05-04 | 3d? |  |  | start no earlier than 2005-05-02 | Veronica | 24h | 24h |
| 33 | 1.6 | **Desarrollo Aplicación** |  | 76d? | 2005-08-08 A | 2005-11-21 |  | 37% | 47.92d? | 2005-07-01 | 2005-08-19 | 36d? | 34d |  |  |  | 862h | 325.77h |
| 34 | 1.6.1 | **Módulo Comercial** |  | 60d? | 2005-08-08 A | 2005-10-28 |  | 34% | 39.4d? | 2005-07-01 | 2005-08-18 | 35d? | 50d |  |  | Verónica | 543h | 164.46h |
| 35 | 1.6.1.1 | Ingreso Tarifa |  | 10d? | 2005-08-17 A | 2005-08-30 | 38 | 90% | 1d? |  |  |  | 93d |  |  |  |  |  |
| 36 | 1.6.1.2 | Generacion Lista Precio |  | 10d? | 2005-09-01 | 2005-09-14 |  |  |  |  |  |  | 16.6d | 0d | start no earlier than 2005-09-01 |  |  |  |
| 37 | 1.6.1.3 | Ingreso Natural |  | 3d? | 2005-08-10 A | 2005-08-12 A |  | 100% |  |  |  |  |  |  | start no earlier than 2005-08-10 |  |  |  |
| 38 | 1.6.1.4 | Ingreso Cliente Jurídico |  | 2d? | 2005-08-15 A | 2005-08-16 A | 37 | 100% |  |  |  |  |  |  |  |  |  |  |
| 39 | 1.6.1.5 | Reservacion |  | 10d? | 2005-09-22 A | 2005-10-05 | 41 | 30% | 7d? |  |  |  | 13.6d | 0d |  |  |  |  |
| 40 | 1.6.1.6 | Ingreso Servicio |  | 3d? | 2005-08-08 A | 2005-08-10 A |  | 100% |  |  |  |  |  |  | start no earlier than 2005-08-08 |  |  |  |
| 41 | 1.6.1.7 | CAPS |  | 5d | 2005-09-15 | 2005-09-21 | 36 |  |  |  |  |  | 16.6d | 0d |  |  |  |  |
| 42 | 1.6.1.8 | Búsquedas |  | 4d? | 2005-10-06 A | 2005-10-11 | 39 | 15% | 3.4d? | 2005-07-01 | 2005-08-18 | 35d? | 13d | 0d |  |  |  |  |
| 43 | 1.6.1.9 | Vistas Extendidas |  | 5d | 2005-10-11 | 2005-10-17 |  |  |  | 2005-07-05 | 2005-08-18 | 33d? | 51d | 1d | start no earlier than 2005-10-11 |  |  |  |
| 44 | 1.6.1.10 | Tabla Equilibrio |  | 8d | 2005-10-19 | 2005-10-28 | 43 |  |  | 2005-07-04 | 2005-08-19 | 35d? | 50d |  | finish no earlier than 2005-10-28 | Nelson | 64h |  |
| 45 | 1.6.2 | **Módulo Operaciones** |  | 60d? | 2005-08-08 A | 2005-10-28 |  | 47% | 31.87d? |  |  |  | 50d |  |  |  | 64h |  |
| 46 | 1.6.2.1 | Ingreso Estaciones |  | 4d? | 2005-08-08 A | 2005-08-12 A |  | 100% |  |  |  |  |  |  | start no earlier than 2005-08-08 |  |  |  |
| 47 | 1.6.2.2 | Ingreso Orden 19 Ptos.(Falta validaciones en PRE y POST de la tabla) |  | 5d? | 2005-09-15 A | 2005-09-21 | 51 | 20% | 4d? |  |  |  | 77d |  |  |  |  |  |
| 48 | 1.6.2.3 | Ingreso de Solicitud de Flota |  | 2d | 2005-08-12 A | 2005-08-16 A | 46 | 100% |  |  |  |  |  |  |  |  |  |  |
| 49 | 1.6.2.4 | Ingreso Orden Asignación (Falta act.htm por tipo de campo y validaciones en PRE y POST de la tabla) |  | 10d? | 2005-08-16 A | 2005-08-29 | 48 | 90% | 1d? |  |  |  | 94d |  |  |  |  |  |
| 50 | 1.6.2.5 | Ingreso Solicitud de traslado |  | 1d? | 2005-08-30 A | 2005-08-30 A | 49 | 100% |  |  |  |  |  |  |  |  |  |  |
| 51 | 1.6.2.6 | Orden de Traslado |  | 10d? | 2005-09-01 A | 2005-09-14 |  | 90% | 1d? |  |  |  | 78d | 0d | start no earlier than 2005-09-01 |  |  |  |
| 52 | 1.6.2.7 | Ingreso Siniestro |  | 8d? | 2005-08-22 A | 2005-08-31 |  | 90% | 0.8d? |  |  |  | 92d |  | start no earlier than 2005-08-22 |  |  |  |
| 53 | 1.6.2.8 | Ingreso Auditoría de Contrato.(Falta validaciones en PRE y POST de la tabla) |  | 2d? | 2005-09-22 A | 2005-09-23 A | 47 | 100% |  |  |  |  |  |  |  |  |  |  |
| 54 | 1.6.2.9 | Ingreso de Preingreso Unidad |  | 1d? | 2005-09-27 A | 2005-09-27 A | 53 | 100% |  |  |  |  |  |  | finish no earlier than 2005-09-27 |  |  |  |
| 55 | 1.6.2.10 | Ingreso Consignación (Falta act.htm por tipo de campo y validaciones en PRE y POST de la tabla) |  | 3d? | 2005-09-28 | 2005-09-30 | 54 |  |  |  |  |  | 70d |  |  |  |  |  |
| 56 | 1.6.2.11 | Apertura Contrato |  | 15d? | 2005-08-08 A | 2005-08-26 |  | 90% | 1.5d? |  |  |  | 50d | 0d | start no earlier than 2005-08-08 |  |  |  |
| 57 | 1.6.2.12 | Cierre Contrato |  | 13d? | 2005-08-29 | 2005-09-14 | 56 |  |  |  |  |  | 50d | 0d |  |  |  |  |
| 58 | 1.6.2.13 | Manejo de Contratos |  | 10d? | 2005-09-15 | 2005-09-28 | 57 |  |  |  |  |  | 50d | 0d |  |  |  |  |
| 59 | 1.6.2.14 | Renovación automática de contratos |  | 8d? | 2005-09-29 | 2005-10-10 | 58 |  |  | 2005-07-04 | 2005-08-19 | 35d? | 50d | 0d |  | Metadeveloper | 64h |  |
| 60 | 1.6.2.15 | Facturas x venta vehículos |  | 8d | 2005-10-11 | 2005-10-20 | 59 |  |  | 2005-07-04 | 2005-08-19 | 35d | 50d | 0d |  |  |  |  |
| 61 | 1.6.2.16 | Busquedas |  | 6d | 2005-10-21 | 2005-10-28 | 60 |  |  | 2005-07-05 | 2005-08-15 | 30d? | 50d |  | start no earlier than 2005-08-08 |  |  |  |

Notes:
- 30: Es el base line antes de comenzar con el de producci'on
- 32: Se crea la aplicacion en N2c, se crean las tablas de las bases de datos y se configura el ambiente necesario para los desarrolladores

| ID | WBS | Task | Type | Duration | Start | Finish | Predecessors | Complete | Remaining | Baseline start | Baseline finish | Baseline duration | Total slack | Free slack | Constraint | Resources | Work | Actual work |
| --- | --- | --- | --- | --- | --- | --- | --- | --- | --- | --- | --- | --- | --- | --- | --- | --- | --- | --- |
| 62 | 1.6.3 | **Módulo Mantenimiento Flota** |  | 60d? | 2005-08-08 A | 2005-10-28 |  | 33% | 40.25d? |  |  |  | 50d |  |  |  |  |  |
| 63 | 1.6.3.1 | Ordenes de Trabajo |  | 15d? | 2005-08-08 A | 2005-08-26 A |  | 100% |  |  |  |  |  |  | start no earlier than 2005-08-08 |  |  |  |
| 64 | 1.6.3.2 | Ordenes de lyC |  | 5d? | 2005-08-29 A | 2005-09-02 | 63 | 95% | 0.25d? |  |  |  | 50d | 0d |  |  |  |  |
| 65 | 1.6.3.3 | Pedidos |  | 10d? | 2005-10-07 | 2005-10-20 | 68 |  |  |  |  |  | 50d | 0d |  |  |  |  |
| 66 | 1.6.3.4 | Orden de Servicios |  | 8d? | 2005-09-05 | 2005-09-14 | 64 |  |  |  |  |  | 50d | 0d |  |  |  |  |
| 67 | 1.6.3.5 | Ordenes de Salida de productos (asociadas o no a Ordenes de trabajo, manejo de devoluciones) |  | 8d? | 2005-09-15 | 2005-09-26 | 66 |  |  |  |  |  | 50d | 0d |  |  |  |  |
| 68 | 1.6.3.6 | Ordenes de Entrada de Productos (manejo de inventario, devoluciones) |  | 8d? | 2005-09-27 | 2005-10-06 | 67 |  |  |  |  |  | 50d | 0d |  |  |  |  |
| 69 | 1.6.3.7 | Facturación a Terceros |  | 6d | 2005-10-21 | 2005-10-28 | 65 |  |  |  |  |  | 50d |  |  |  |  |  |
| 70 | 1.6.4 | **Integración con otros sistemas** |  | 29d? | 2005-10-12 A | 2005-11-21 | 42 | 26% | 21.39d? | 2005-08-19 | 2005-11-10 | 60d? | 34d |  |  | Veronica | 255h | 161.31h |
| 71 | 1.6.4.1 | Sistema Digitilización |  | 20d? | 2005-10-12 | 2005-11-08 |  |  |  |  |  |  | 43d |  | start no earlier than 2005-09-26 |  |  |  |
| 72 | 1.6.4.2 | Sistema Satelital |  | 10d? | 2005-10-12 | 2005-10-25 |  |  |  |  |  |  | 53d |  | start no earlier than 2005-09-26 |  |  |  |
| 73 | 1.6.4.3 | Página WEB Hertz Renta Motor |  | 15d? | 2005-10-12 | 2005-11-01 |  |  |  |  |  |  | 48d |  | start no earlier than 2005-10-10 |  |  |  |
| 74 | 1.6.4.4 | Directorio Relacionado |  | 16d? | 2005-10-31 A | 2005-11-21 A |  | 100% |  |  |  |  |  |  | start no earlier than 2005-07-25 | GM | 128h | 128h |
| 75 | 1.7 | Reportes |  | 20d? | 2005-09-01 A | 2005-09-28 |  | 5% | 19d? |  |  |  | 72d |  | start no earlier than 2005-09-01 | recurso 1 | 160h | 8h |
| 76 | 1.8 | Estadísticas |  | 20d? | 2005-09-01 A | 2005-09-28 |  | 5% | 19d? |  |  |  | 72d |  | start no earlier than 2005-09-01 | Recurso 2 …Claudia | 160h | 8h |
| 77 | 1.9 | Alarmas |  | 20d | 2005-09-01 | 2005-09-28 |  |  |  |  |  |  | 72d |  | start no earlier than 2005-09-01 | Recurso 3 | 160h |  |
| 78 | 1.10 | **Pruebas** |  | 15d? | 2005-11-21 | 2005-12-09 |  |  |  | 2005-08-22 | 2005-09-28 | 28d? | 20d |  |  |  | 120h |  |
| 79 | 1.10.1 | Funcionalidad |  | 15d? | 2005-11-21 | 2005-12-09 |  |  |  | 2005-08-22 | 2005-09-02 | 10d? | 20d |  | start no earlier than 2005-11-21 | usuario Funcional | 120h |  |
| 80 | 1.11 | **Implantación** |  | 45d? | 2005-10-31 | 2005-12-30 |  |  |  | 2005-08-16 | 2005-12-29 | 98d? | 5d |  |  | Verónica; Nelson; Aron | 1720h |  |
| 81 | 1.11.1 | **Ambiente Desarrollo** |  | 30d? | 2005-10-31 | 2005-12-09 |  |  |  |  |  |  | 20d |  |  |  |  |  |
| 82 | 1.11.1.1 | Crear Aplicaciones y tablas de N2C en desarrollo |  | 5d? | 2005-10-31 | 2005-11-04 |  |  |  |  |  |  | 25d | 0d | start no earlier than 2005-10-31 |  |  |  |
| 83 | 1.11.1.2 | Carga de data historica |  | 10d? | 2005-11-07 | 2005-11-18 | 82 |  |  |  |  |  | 25d | 5d | start no earlier than 2005-09-12 |  |  |  |
| 84 | 1.11.1.3 | Pruebas Estación Piloto |  | 10d? | 2005-11-28 | 2005-12-09 | 83 |  |  | 2005-08-16 | 2005-08-19 | 4d? | 20d | 0d | finish no earlier than 2005-12-09 |  |  |  |
| 85 | 1.11.1.4 | Certificación de pruebas | milestone | 0d? | 2005-12-09 | 2005-12-09 | 84 |  |  |  |  |  | 20d |  | finish no earlier than 2005-12-09 |  |  |  |

Notes:
- 70: Interfaz
- 79: Pruebas con el usuario. Incluye pruebas en la estación piloto, más las de Caracas, más la de los otros sistemas

| ID | WBS | Task | Duration | Start | Finish | Predecessors | Complete | Remaining | Baseline start | Baseline finish | Baseline duration | Total slack | Free slack | Constraint | Resources | Work | Actual work |
| --- | --- | --- | --- | --- | --- | --- | --- | --- | --- | --- | --- | --- | --- | --- | --- | --- | --- |
| 86 | 1.11.2 | **Operacionalización** | 20d? | 2005-12-05 | 2005-12-30 |  |  |  | 2005-12-07 | 2005-12-29 | 17d? | 5d |  |  | Verónica; Nelson; Aron; Meatdeveloper | 640h |  |
| 87 | 1.11.2.1 | Crear Aplicaciones y tablas de N2C en porduccion | 3d? | 2005-12-05 | 2005-12-07 |  |  |  |  |  |  | 12d | 0d | start no earlier than 2005-12-05 |  |  |  |
| 88 | 1.11.2.2 | Carga Data Historica | 10d | 2005-12-08 | 2005-12-21 | 87 |  |  |  |  |  | 12d |  |  |  |  |  |
| 89 | 1.11.2.3 | Pase de programas a Producción | 1d? | 2005-12-09 | 2005-12-09 | 87 |  |  |  |  |  | 20d |  | start no earlier than 2005-12-09 |  |  |  |
| 90 | 1.11.2.4 | Estaciones | 15d | 2005-12-12 | 2005-12-30 |  |  |  | 2005-12-09 | 2005-12-29 | 15d | 5d |  | start no earlier than 2005-12-12 |  |  |  |
| 91 | 1.11.2.5 | Prueba Corporacion | 7d? | 2005-12-21 | 2005-12-29 | 93 |  |  | 2005-12-07 | 2005-12-08 | 2d? | 6d |  | start no earlier than 2005-12-13 |  |  |  |
| 92 | 1.12 | Documentación | 162d? | 2005-04-11 A | 2005-11-22 |  | 60% | 64.8d? | 2005-04-11 | 2005-11-22 | 162d? | 33d |  | start no earlier than 2005-04-11 | Verónica; Nelson; Meatdeveloper; GM | 5184h | 3110.4h |
| 93 | 1.13 | Adiestramiento | 7d? | 2005-12-12 | 2005-12-20 |  |  |  | 2005-11-14 | 2005-11-18 | 5d? | 6d | 0d | start no earlier than 2005-12-12 | GM; usuario Funcional | 112h |  |
| 94 | 1.14 | Manejo Cambio | 110d? | 2005-08-01 A | 2005-12-30 |  | 40% | 66d? | 2005-08-01 | 2005-12-30 | 110d? | 5d |  | finish no earlier than 2005-12-30 | GM; usuario Funcional | 1760h | 704h |
| 95 | 1.15 | Control y Seguimiento | 174d? | 2005-05-03 A | 2005-12-30 |  | 70% | 52.2d? | 2005-05-03 | 2005-12-30 | 174d? | 5d |  | finish no earlier than 2005-12-30 | GM | 1392h | 974.4h |
| 96 | 1.16 | **PostImplantación** | 5d? | 2006-01-02 | 2006-01-06 |  |  |  | 2005-12-08 | 2005-12-30 | 17d? | 0d |  |  |  | 40h |  |
| 97 | 1.16.1 | Monitoreo y soporte | 5d? | 2006-01-02 | 2006-01-06 |  |  |  | 2005-12-08 | 2005-12-30 | 17d? | 0d |  | start no earlier than 2006-01-02 | usuario Funcional | 40h |  |

Notes:
- 90: Validar fecha critica para puesta en produccion en las agencias..Esto puede implicar viajes a las áreas
- 91: Pruebas en mabiente de producción
- 93: Incluye adiestrar al Help Desk
