# Proyect1

Schedule from MS Project, 2005-11-28 to 2006-03-30, A marks actual dates.
VENESOFT

## Calendars

- Estándar: Mon-Fri 09:00-13:00, 15:00-19:00; Sat-Sun off.

## Schedule

| ID | WBS | Task | Duration | Start | Finish | Predecessors | Complete | Remaining | Total slack | Constraint |
| --- | --- | --- | --- | --- | --- | --- | --- | --- | --- | --- |
| 1 | 1 | **Proyecto "e-orchestra"** | 89d | 2005-11-28 A | 2006-03-30 |  | 9% | 81.35d | 0d |  |
| 2 | 1.1 | **Fase de Análisis** | 23d | 2005-11-28 A | 2005-12-28 |  | 24% | 17.47d | 66d |  |
| 3 | 1.1.1 | **Levantamiento de la información** | 23d | 2005-11-28 A | 2005-12-28 |  | 24% | 17.47d | 66d |  |
| 4 | 1.1.1.1 | Conocer la plataforma, herramientas computacionales y/o sistemas utilizados para los procesos internos. | 5d | 2005-11-28 A | 2005-12-02 A |  | 100% |  |  | finish no earlier than 2005-12-02 |
| 5 | 1.1.1.2 | **Entrevista por grupos responsables de las diferentes áreas de negocio de la empresa y de los subproyectos de e-orchestra** | 18d | 2005-12-05 A | 2005-12-28 | 4 | 13% | 15.65d | 66d |  |
| 6 | 1.1.1.2.1 | Estructurar Cuestionario de las Entrevistas | 2d | 2005-12-05 A | 2005-12-06 A |  | 100% |  |  |  |
| 7 | 1.1.1.2.2 | Estructurar un Calendario de Entrevistas | 0.5d | 2005-12-05 A | 2005-12-05 A |  | 100% |  |  |  |
| 8 | 1.1.1.2.3 | Determinar las necesidades del usuario para realizar su trabajo de manera óptima | 16d | 2005-12-07 A | 2005-12-28 | 7, 6 | 6% | 15d | 66d | finish no earlier than 2005-12-16 |
| 9 | 1.1.1.2.4 | Reconocer los procesos empresariales | 16d | 2005-12-07 A | 2005-12-28 | 7, 6 | 6% | 15d | 0d | finish no earlier than 2005-12-16 |
| 10 | 1.2 | **Fase de Diseño** | 26d | 2005-12-29 | 2006-02-02 | 9 |  |  | 0d |  |
| 11 | 1.2.1 | Diseñar el sistema a implementar aplicando la metodología de desarrollo propuesta para la gerencia de proyectos de informática lo cual permitirá optimizar el seguimiento y desarrollo de los mismos | 25d | 2005-12-29 | 2006-02-01 |  |  |  | 0d | finish no earlier than 2006-01-06 |
| 12 | 1.2.2 | Diseñar la estructura de los documentos que en línea mostrarán los procedimientos asociados con el sistema. | 5d | 2006-01-19 | 2006-01-25 | 11SS+15d |  |  | 5d |  |
| 13 | 1.2.3 | Entregable: Interfaz del sistema y diseño de la estructura de la documentación de procedimientos | 1d | 2006-02-02 | 2006-02-02 | 11, 12 |  |  | 0d | start no earlier than 2006-01-06 |
| 14 | 1.3 | **Fase de Desarrollo** | 40d | 2006-02-03 | 2006-03-30 | 13 |  |  | 0d |  |
| 15 | 1.3.1 | Elaboración de un documento en línea de procedimientos que permita optimizar el desarrollo y seguimiento de proyectos de informática, a la empresa GWT | 39d | 2006-02-03 | 2006-03-29 |  |  |  | 0d | finish no earlier than 2006-03-02 |
| 16 | 1.3.2 | Entregable: Sistema, herramienta de software, que de soporte a la metodología de desarrollo propuesta | 1d | 2006-03-30 | 2006-03-30 | 15 |  |  | 0d |  |

Notes:
- 12: Debe contemplar entre otras: que sea multiidioma, facilmente actualizable al cambiar el procedimiento o ajustar el sistema, debe ser ayuda en línea en el sistema.
