# ttgoportunidades

Schedule from MS Project, 2005-11-23 to 2006-01-10, A marks actual dates.
GWT

## Calendars

- Estándar: Mon-Fri 09:00-13:00, 15:00-19:00; Sat-Sun off.

## Resources

| Resource |
| --- |
| V Riera |
| V R |
| H Rosas V Riera |
| O Lorenzo |
| O Lorenzo V Riera |

## Schedule

| ID | WBS | Task | Duration | Start | Finish | Predecessors | Complete | Remaining | Baseline start | Baseline finish | Baseline duration | Total slack | Constraint | Resources | Work |
| --- | --- | --- | --- | --- | --- | --- | --- | --- | --- | --- | --- | --- | --- | --- | --- |
| 1 | 1 | **Gerencia oportunidades** | 34.5d? | 2005-11-23 A | 2006-01-10 |  | 4% | 33.27d? | 2005-11-23 | 2006-02-08 | 56d? | 0d |  |  | 336h |
| 3 | 1.1 | Inicio | 1d? | 2005-11-23 A | 2005-11-23 A |  | 100% |  | 2005-11-23 | 2005-11-23 | 1d? |  | start no earlier than 2005-11-23 |  |  |
| 4 | 1.2 | **Definición del proceso** | 17.5d | 2005-11-29 | 2005-12-22 |  |  |  | 2005-11-23 | 2005-12-01 | 7d | 0d |  | V Riera | 224h |
| 5 | 1.2.1 | Definición de métricas | 7d | 2005-11-29 | 2005-12-13 |  |  |  | 2005-12-02 | 2005-12-12 | 7d | 0d |  | V Riera | 56h |
| 6 | 1.2.2 | Establecimiento de procedimientos | 7d | 2005-12-13 | 2005-12-22 | 5 |  |  | 2005-12-13 | 2005-12-21 | 7d | 0d |  | V Riera | 56h |
| 7 | 1.3 | **Incorporación a 701** | 2d? | 2005-12-22 | 2005-12-26 | 6 |  |  | 2006-01-16 | 2006-01-24 | 7d | 0d |  | H Rosas V Riera | 32h |
| 8 | 1.3.1 | Definición de tablas | 1d? | 2005-12-22 | 2005-12-23 |  |  |  |  |  |  | 0d |  | H Rosas V Riera | 8h |
| 9 | 1.3.2 | Definición de Campos | 1d? | 2005-12-23 | 2005-12-26 | 8 |  |  |  |  |  | 0d |  | H Rosas V Riera | 8h |
| 10 | 1.4 | Prueba de Sistema | 10d | 2005-12-26 | 2006-01-09 | 9 |  |  | 2006-01-25 | 2006-02-07 | 10d | 0d |  | O Lorenzo V Riera | 80h |
| 11 | 1.5 | Cierre | 1d | 2006-01-09 | 2006-01-10 | 10 |  |  | 2006-02-08 | 2006-02-08 | 1d | 0d |  |  |  |
