# Plan TN-GWT TakeOff2006

Schedule from MS Project, 2005-12-19 to 2006-04-07.
GSM

## Calendars

- Standard: Mon-Fri 08:00-12:00, 13:00-17:00; Sat-Sun off.

## Schedule

| ID | WBS | Task | Type | Duration | Start | Finish | Predecessors | Total slack | Free slack | Constraint |
| --- | --- | --- | --- | --- | --- | --- | --- | --- | --- | --- |
| 1 | 1 | **TN-GWT TakeOff** |  | 80d? | 2005-12-19 | 2006-04-07 |  | 0d |  |  |
| 2 | 1.1 | Starting Milestone |  | 1d? | 2006-01-16 | 2006-01-16 |  | 2d | 0d | start no earlier than 2006-01-16 |
| 3 | 1.2 | **Marketing Plan** |  | 39d? | 2005-12-19 | 2006-02-09 |  | 41d |  |  |
| 4 | 1.2.1 | Building the screens for HSCG |  | 1d? | 2005-12-19 | 2005-12-19 |  | 79d |  |  |
| 5 | 1.2.2 | **Corporate Image** |  | 18d | 2006-01-17 | 2006-02-09 | 2 | 41d |  |  |
| 6 | 1.2.2.1 | Define Image |  | 3d | 2006-01-17 | 2006-01-19 |  | 41d | 0d |  |
| 7 | 1.2.2.2 | Build the Concept |  | 15d | 2006-01-20 | 2006-02-09 | 6 | 59d |  |  |
| 8 | 1.2.2.3 | Definition of Corporate Image Folders, WebSite, P/R (aligned w/Products) |  | 1d | 2006-01-20 | 2006-01-20 | 6 | 42d | 0d |  |
| 9 | 1.2.2.4 | Budget for Corporate Image |  | 1d | 2006-01-23 | 2006-01-23 | 8 | 42d | 0d |  |
| 10 | 1.2.3 | **Product** |  | 6d | 2006-01-24 | 2006-01-31 |  | 42d |  |  |
| 11 | 1.2.3.1 | Establish Portafolio of Products |  | 1d | 2006-01-24 | 2006-01-24 | 9 | 42d | 0d |  |
| 12 | 1.2.3.2 | **Establish Product Strategy for each Portafolio Product** |  | 5d | 2006-01-25 | 2006-01-31 |  | 42d |  |  |
| 13 | 1.2.3.2.1 | Distribution\ |  | 1d | 2006-01-25 | 2006-01-25 | 11 | 42d | 0d |  |
| 14 | 1.2.3.2.2 | Communication |  | 1d | 2006-01-26 | 2006-01-26 | 13 | 42d | 0d |  |
| 15 | 1.2.3.2.3 | Definition Product Folders, WebSite, P/R aligned w/Corporate image |  | 1d | 2006-01-27 | 2006-01-27 | 14 | 42d | 0d |  |
| 16 | 1.2.3.2.4 | Price |  | 1d | 2006-01-30 | 2006-01-30 | 15 | 42d | 0d |  |
| 17 | 1.2.3.2.5 | Budget for each Product |  | 1d | 2006-01-31 | 2006-01-31 | 16 | 42d | 0d |  |
| 18 | 1.2.4 | Plan the Implementation of the deliverables of the Marketing Plan Activities |  | 3d | 2006-02-01 | 2006-02-03 | 17 | 42d | 0d |  |
| 19 | 1.3 | **Product Development Plan** |  | 80d | 2005-12-19 | 2006-04-07 |  | 0d |  |  |
| 20 | 1.3.1 | **HSCG Requirements:** |  | 20d | 2005-12-19 | 2006-01-13 |  | 0d |  |  |
| 21 | 1.3.1.1 | Build the designs |  | 5d | 2005-12-19 | 2005-12-23 |  | 15d |  |  |
| 22 | 1.3.1.2 | Net2Client |  | 20d | 2005-12-19 | 2006-01-13 | 21FF | 0d |  |  |
| 23 | 1.3.2 | **TN-GWT Requirements:** |  | 60d | 2006-01-13 | 2006-04-07 | 20, 22 | 0d |  |  |
| 24 | 1.3.2.1 | Product Roadmap | milestone | 0d | 2006-01-13 | 2006-01-13 |  | 57d | 15d |  |
| 25 | 1.3.2.2 | Revise the requirements on V 4.2, 4.3 |  | 2d | 2006-02-06 | 2006-02-07 | 24, 18 | 42d | 0d |  |
| 26 | 1.3.2.3 | Revised Product Roadmap |  | 1d | 2006-02-08 | 2006-02-08 | 25 | 42d |  |  |
| 27 | 1.3.2.4 | Net2Client |  | 60d | 2006-01-16 | 2006-04-07 |  | 0d |  |  |
| 28 | 1.3.2.5 | WiB |  | 40d | 2006-01-16 | 2006-03-10 |  | 20d |  |  |
| 29 | 1.3.2.6 | Prioritize Requirements |  | 1d | 2006-01-16 | 2006-01-16 |  | 59d |  |  |
| 30 | 1.3.2.7 | Revised Product Roadmap |  | 1d | 2006-01-16 | 2006-01-16 |  | 59d |  |  |

| ID | WBS | Task | Duration | Start | Finish | Predecessors | Total slack | Free slack |
| --- | --- | --- | --- | --- | --- | --- | --- | --- |
| 31 | 1.4 | **Expansion Production Capacity** | 57d | 2006-01-17 | 2006-04-05 | 2 | 2d |  |
| 32 | 1.4.1 | **TN** | 10d | 2006-01-17 | 2006-01-30 |  | 49d |  |
| 33 | 1.4.1.1 | Hiring Project Manager (English Spoken) | 10d | 2006-01-17 | 2006-01-30 |  | 67d |  |
| 34 | 1.4.2 | **GWT** | 57d | 2006-01-17 | 2006-04-05 |  | 2d |  |
| 35 | 1.4.2.1 | Find/reassign Project Manager (English Spoken) | 15d | 2006-01-17 | 2006-02-06 |  | 62d |  |
| 36 | 1.4.2.2 | Get 3 additional programmers | 30d | 2006-01-17 | 2006-02-27 |  | 47d |  |
| 37 | 1.4.2.3 | Train additional programmers | 10d | 2006-01-17 | 2006-01-30 |  | 67d |  |
| 38 | 1.4.2.4 | Get 2 temporary programmers for January 2006 (MD/reassign) | 5d | 2006-01-17 | 2006-01-23 |  | 72d |  |
| 39 | 1.4.2.5 | **Infrastructure** | 57d | 2006-01-17 | 2006-04-05 |  | 2d |  |
| 40 | 1.4.2.5.1 | Get office space | 40d | 2006-01-17 | 2006-03-13 |  | 20d | 0d |
| 41 | 1.4.2.5.2 | Get Furniture | 10d | 2006-03-10 | 2006-03-23 | 40FS-2d | 24d | 0d |
| 42 | 1.4.2.5.3 | Get PC's | 5d | 2006-03-24 | 2006-03-30 | 41 | 24d |  |
| 43 | 1.4.2.5.4 | Get connected (ABA, LAN) | 15d | 2006-03-14 | 2006-04-03 | 40 | 20d | 0d |
| 44 | 1.4.2.5.5 | Get VoIP-PBX | 2d | 2006-04-04 | 2006-04-05 | 43 | 20d |  |
