# ttpropuestas

Schedule from MS Project, 2005-11-23 to 2006-02-20, A marks actual dates.
GWT

## Calendars

- Estándar: Mon-Fri 09:00-13:00, 15:00-19:00; Sat-Sun off.

## Resources

| Resource |
| --- |
| V Riera |
| H Rosas V Riera |
| O Lorenzo |
| O Lorenzo V Riera |

## Schedule

| ID | WBS | Task | Duration | Start | Finish | Predecessors | Complete | Remaining | Baseline start | Baseline finish | Baseline duration | Total slack | Free slack | Constraint | Resources | Work | Actual work |
| --- | --- | --- | --- | --- | --- | --- | --- | --- | --- | --- | --- | --- | --- | --- | --- | --- | --- |
| 1 | 1 | **Manejo de Propuestas** | 64d? | 2005-11-23 A | 2006-02-20 |  | 23% | 49.55d? | 2005-11-23 | 2006-02-08 | 56d? | 0d |  |  |  | 184h | 48h |
| 3 | 1.1 | Inicio | 1d? | 2005-11-23 A | 2005-11-23 A |  | 100% |  | 2005-11-23 | 2005-11-23 | 1d? |  |  | start no earlier than 2005-11-23 |  |  |  |
| 4 | 1.2 | Definición de los elementos que conforma la propuesta | 5d | 2005-11-23 A | 2005-11-29 A |  | 100% |  | 2005-11-23 | 2005-11-29 | 5d |  |  | start no earlier than 2005-11-23 | V Riera | 40h | 40h |
| 5 | 1.3 | Establecimiento del modelo de propuestas | 1d | 2005-11-30 A | 2005-11-30 A | 4 | 100% |  | 2005-11-30 | 2005-12-06 | 5d |  |  |  | V Riera | 8h | 8h |
| 6 | 1.4 | **Establecimiento de procesos de la elaboración de la propuesta y los procedimientos** | 22d? | 2005-12-14 | 2006-01-12 |  |  |  | 2005-12-14 | 2006-01-12 | 0d? | 27d |  |  |  |  |  |
| 7 | 1.4.1 | Definición de Procesos | 1d? | 2005-12-14 | 2005-12-14 |  |  |  | 2005-12-14 | 2005-12-14 | 0d? | 48d |  | finish no earlier than 2005-12-14 |  |  |  |
| 8 | 1.4.2 | Definición de Procedimientos | 1d? | 2005-12-14 | 2005-12-14 |  |  |  | 2005-12-14 | 2005-12-14 | 0d? | 48d |  | finish no earlier than 2005-12-14 |  |  |  |
| 9 | 1.4.3 | Establecer componentes a proponer en el sistema | 1d? | 2006-01-12 | 2006-01-12 |  |  |  | 2006-01-12 | 2006-01-18 | 0d? | 27d |  | start no earlier than 2006-01-12 |  |  |  |
| 10 | 1.5 | **Incorporación a 701** | 17d? | 2006-01-20 | 2006-02-13 |  |  |  | 2006-01-20 | 2006-01-27 | 10d | 5d |  |  | H Rosas V Riera | 136h |  |
| 11 | 1.5.1 | Establecer componentes definitivos del sistema | 6d? | 2006-01-20 | 2006-01-27 |  |  |  | 2006-01-20 | 2006-01-27 | 0d? | 16d |  | finish no earlier than 2006-01-27 |  |  |  |
| 12 | 1.5.2 | Incorporar los componentes en la 701 | 4d? | 2006-01-26 | 2006-01-31 |  |  |  |  |  |  | 14d |  | finish no earlier than 2006-01-31 |  |  |  |
| 13 | 1.5.3 | Probar sistema | 9d? | 2006-01-31 | 2006-02-10 |  |  |  |  |  |  | 5d | 0d | finish no earlier than 2006-02-10 |  |  |  |
| 14 | 1.5.4 | Aprobar sistema | 1d? | 2006-02-13 | 2006-02-13 | 13 |  |  |  |  |  | 5d |  |  |  |  |  |
| 15 | 1.6 | Cierre | 1d | 2006-02-20 | 2006-02-20 |  |  |  | 2006-02-08 | 2006-02-08 | 1d | 0d |  | start no earlier than 2006-02-20 |  |  |  |
