# Proyect1

Schedule from MS Project, 2005-11-28 to 2006-03-03, A marks actual dates.
VENESOFT

## Calendars

- Estándar: Mon-Fri 09:00-13:00, 15:00-19:00; Sat-Sun off.

## Schedule

| ID | WBS | Task | Duration | Start | Finish | Predecessors | Complete | Remaining | Total slack | Constraint |
| --- | --- | --- | --- | --- | --- | --- | --- | --- | --- | --- |
| 1 | 1 | **Proyecto "e-orchestra"** | 70d? | 2005-11-28 A | 2006-03-03 |  | 41% | 41.42d? | 0d |  |
| 2 | 1.1 | **Fase de Análisis** | 28d? | 2005-11-28 A | 2006-01-04 |  | 95% | 1.53d? | 0d |  |
| 3 | 1.1.1 | **Levantamiento de la información** | 28d? | 2005-11-28 A | 2006-01-04 |  | 95% | 1.53d? | 0d |  |
| 4 | 1.1.1.1 | Conocer la plataforma, herramientas computacionales y/o sistemas utilizados para los procesos internos. | 5d | 2005-11-28 A | 2005-12-02 A |  | 100% |  |  | finish no earlier than 2005-12-02 |
| 5 | 1.1.1.2 | **Entrevista por grupos responsables de las diferentes áreas de negocio de la empresa y de los subproyectos de e-orchestra** | 23d? | 2005-12-05 A | 2006-01-04 | 4 | 94% | 1.46d? | 0d |  |
| 6 | 1.1.1.2.1 | Estructurar Cuestionario de las Entrevistas | 2d | 2005-12-05 A | 2005-12-06 A |  | 100% |  |  |  |
| 7 | 1.1.1.2.2 | Estructurar un Calendario de Entrevistas | 0.5d | 2005-12-05 A | 2005-12-05 A |  | 100% |  |  |  |
| 8 | 1.1.1.2.3 | **Determinar las necesidades del usuario para realizar su trabajo de manera óptima** | 21d? | 2005-12-07 A | 2006-01-04 | 7, 6 | 93% | 1.45d? | 0d |  |
| 9 | 1.1.1.2.3.1 | Entrevistar a los responsables de áreas de negocio de GWT | 6d? | 2005-12-07 A | 2005-12-14 A |  | 100% |  |  | start no earlier than 2005-12-07 |
| 10 | 1.1.1.2.3.2 | Analizar resultados de encuestas | 2d? | 2005-12-15 A | 2005-12-16 A | 9 | 100% |  |  | start no earlier than 2005-12-15 |
| 11 | 1.1.1.2.3.3 | **Documentar los procesos empresariales** | 13d? | 2005-12-19 A | 2006-01-04 | 7, 6 | 90% | 1.24d? | 0d |  |
| 12 | 1.1.1.2.3.3.1 | Documentar procesos en un primer nivel (nivel 0) sin interconexión | 8d? | 2005-12-19 A | 2005-12-28 A |  | 100% |  |  | start no earlier than 2005-12-19 |
| 13 | 1.1.1.2.3.3.2 | Documentar procesos de GWT en un nivel 1 interconextándose las diferentes áreas de negocio | 13d? | 2005-12-19 A | 2006-01-04 |  | 85% | 2d? | 0d | finish no earlier than 2006-01-04 |
| 14 | 1.2 | **Fase de Diseño** | 26d | 2006-01-05 | 2006-02-09 | 11 |  |  | 0d |  |
| 15 | 1.2.1 | Diseñar el sistema a implementar aplicando la metodología de desarrollo propuesta para la gerencia de proyectos de informática lo cual permitirá optimizar el seguimiento y desarrollo de los mismos | 25d | 2006-01-05 | 2006-02-08 |  |  |  | 0d | finish no earlier than 2006-01-06 |
| 16 | 1.2.2 | Diseñar la estructura de los documentos que en línea mostrarán los procedimientos asociados con el sistema. | 5d | 2006-01-26 | 2006-02-01 | 15SS+15d |  |  | 5d |  |
| 17 | 1.2.3 | Entregable: Interfaz del sistema y diseño de la estructura de la documentación de procedimientos | 1d | 2006-02-09 | 2006-02-09 | 15, 16 |  |  | 0d | start no earlier than 2006-01-06 |
| 18 | 1.3 | **Fase de Desarrollo** | 16d | 2006-02-10 | 2006-03-03 | 17 |  |  | 0d |  |
| 19 | 1.3.1 | Elaboración de un documento en línea de procedimientos que permita optimizar el desarrollo y seguimiento de proyectos de informática, a la empresa GWT | 16d | 2006-02-10 | 2006-03-03 |  |  |  | 0d | finish no earlier than 2006-03-02 |
| 20 | 1.3.2 | Entregable: Sistema, herramienta de software, que de soporte a la metodología de desarrollo propuesta | 1d | 2006-03-03 | 2006-03-03 |  |  |  | 0d | start no earlier than 2006-03-03 |

Notes:
- 16: Debe contemplar entre otras: que sea multiidioma, facilmente actualizable al cambiar el procedimiento o ajustar el sistema, debe ser ayuda en línea en el sistema.
