# ttgoportunidades

Schedule from MS Project, 2005-11-23 to 2006-03-02, A marks actual dates.
GWT

## Calendars

- Estándar: Mon-Fri 09:00-13:00, 15:00-19:00; Sat-Sun off.

## Resources

| Resource |
| --- |
| V Riera |
| V R |
| H Rosas V Riera |
| O Lorenzo |
| O Lorenzo V Riera |
| Vriera |

## Schedule

| ID | WBS | Task | Duration | Start | Finish | Predecessors | Complete | Remaining | Baseline start | Baseline finish | Baseline duration | Total slack | Free slack | Constraint | Resources | Work | Actual work |
| --- | --- | --- | --- | --- | --- | --- | --- | --- | --- | --- | --- | --- | --- | --- | --- | --- | --- |
| 1 | 1 | **Gerencia oportunidades** | 72d? | 2005-11-23 A | 2006-03-02 |  | 54% | 33.24d? | 2005-11-23 | 2006-02-08 | 56d? | 0d |  |  |  | 1272h | 547.33h |
| 3 | 1.1 | Inicio | 1d? | 2005-11-23 A | 2005-11-23 A |  | 100% |  | 2005-11-23 | 2005-11-23 | 1d? |  |  | start no earlier than 2005-11-23 |  |  |  |
| 4 | 1.2 | **Definición del proceso** | 41d? | 2005-11-29 A | 2006-01-24 |  | 74% | 10.78d? | 2005-11-23 | 2005-12-01 | 7d | 0d |  |  | V Riera | 784h | 517.92h |
| 5 | 1.2.1 | Establecimiento de procesos | 35.5d | 2005-11-29 A | 2006-01-20 A |  | 100% |  | 2005-12-02 | 2005-12-12 | 7d |  |  |  | V Riera | 284h | 284h |
| 6 | 1.2.2 | Establecimiento de procedimientos | 28.5d? | 2005-12-13 A | 2006-01-20 A | 5 | 100% |  |  |  |  |  |  |  |  |  |  |
| 7 | 1.2.3 | Propuesta de Métricas | 25d | 2005-12-21 A | 2006-01-24 |  | 6% | 23.4d | 2005-12-13 | 2005-12-21 | 7d | 0d |  | finish no earlier than 2006-01-24 | V Riera | 200h | 12.8h |
| 8 | 1.3 | **Incorporación a 701** | 35d | 2006-01-12 A | 2006-03-01 | 7 | 6% | 32.82d | 2006-01-16 | 2006-01-24 | 7d | 1d |  |  | H Rosas V Riera | 488h | 29.41h |
| 9 | 1.3.1 | Definición de Métricas | 1d | 2006-01-12 A | 2006-01-25 |  | 80% | 0.2d |  |  |  | 18.3d | 0d | finish no earlier than 2006-01-24 |  |  |  |
| 10 | 1.3.2 | Definición de tablas | 5d | 2006-01-16 A | 2006-01-31 | 9 | 14% | 4.3d |  |  |  | 18.3d | 0d | start no earlier than 2006-01-16 | H Rosas V Riera | 40h | 5.6h |
| 11 | 1.3.3 | Definición de Campos | 5d | 2006-01-17 A | 2006-02-06 | 10 | 16% | 4.2d |  |  |  | 18.3d |  |  | H Rosas V Riera | 40h | 6.4h |
| 12 | 1.3.4 | Puesta en producción del sistema | 10d | 2006-01-25 | 2006-02-07 |  |  |  |  |  |  | 0d |  |  |  |  |  |
| 13 | 1.3.5 | Prueba de Sistema | 11d | 2006-02-08 | 2006-02-22 | 12 |  |  | 2006-01-25 | 2006-02-07 | 10d | 0d |  |  | O Lorenzo V Riera | 88h |  |
| 14 | 1.3.6 | Aprobación del sistema | 5d | 2006-02-23 | 2006-03-01 | 13 |  |  |  |  |  | 0d |  |  | V Riera | 40h |  |
| 15 | 1.4 | Cierre | 1d | 2006-03-02 | 2006-03-02 | 14 |  |  | 2006-02-08 | 2006-02-08 | 1d | 0d |  |  |  |  |  |
