# ttmercadeo

Schedule from MS Project, 2006-01-12 to 2006-03-23, A marks actual dates.
GWT

## Calendars

- Estándar: Mon-Fri 09:00-13:00, 15:00-19:00; Sat-Sun off.

## Resources

| Resource |
| --- |
| V Riera |
| H Rosas V Riera |
| O Lorenzo |
| O Lorenzo V Riera |

## Schedule

| ID | WBS | Task | Duration | Start | Finish | Predecessors | Complete | Remaining | Baseline start | Baseline finish | Baseline duration | Total slack | Free slack | Constraint | Resources | Work | Actual work |
| --- | --- | --- | --- | --- | --- | --- | --- | --- | --- | --- | --- | --- | --- | --- | --- | --- | --- |
| 1 | 1 | **Mercadeo** | 51d? | 2006-01-12 A | 2006-03-23 |  | 17% | 42.54d? | 2005-11-23 | 2006-02-08 | 56d? | 0d |  |  |  | 280h | 28h |
| 3 | 1.1 | Inicio | 1d? | 2006-01-20 A | 2006-01-20 A |  | 100% |  | 2005-11-23 | 2005-11-23 | 1d? |  |  | start no earlier than 2005-11-23 |  |  |  |
| 4 | 1.2 | Definición de los elementos que conforman el Plan de Mercadeo | 5d | 2006-01-24 A | 2006-01-30 |  | 60% | 2d | 2005-11-23 | 2005-11-29 | 5d | 37.5d | 3d | start no earlier than 2005-11-23 | V Riera | 40h | 24h |
| 5 | 1.3 | Establecimiento del modelo de Plan de Mercadeo | 1d | 2006-02-03 A | 2006-02-03 | 4 | 50% | 0.5d | 2005-11-30 | 2005-12-06 | 5d | 34d |  |  | V Riera | 8h | 4h |
| 6 | 1.4 | **Establecimiento de procesos de la elaboración del plan de mercadeo** | 13d? | 2006-01-12 A | 2006-01-30 |  | 12% | 11.44d? | 2005-12-14 | 2006-01-12 | 0d? | 38d |  |  |  |  |  |
| 7 | 1.4.1 | Definición de Procesos | 1d? | 2006-01-24 A | 2006-01-24 |  | 90% | 0.1d? | 2005-12-14 | 2005-12-14 | 0d? | 42d |  | finish no earlier than 2005-12-14 |  |  |  |
| 8 | 1.4.2 | Definición de Procedimientos | 1d? | 2006-01-24 A | 2006-01-24 |  | 90% | 0.1d? | 2005-12-14 | 2005-12-14 | 0d? | 42d |  | finish no earlier than 2005-12-14 |  |  |  |
| 9 | 1.4.3 | Establecer componentes a proponer en el sistema | 13d? | 2006-01-12 | 2006-01-30 |  |  |  | 2006-01-12 | 2006-01-18 | 0d? | 38d |  | finish no earlier than 2006-01-30 |  |  |  |
| 10 | 1.5 | **Incorporación a 701?** | 29d? | 2006-02-13 | 2006-03-23 |  |  |  | 2006-01-20 | 2006-01-27 | 10d | 0d |  |  | H Rosas V Riera | 232h |  |
| 11 | 1.5.1 | Establecer componentes definitivos del sistema? | 6d? | 2006-02-13 | 2006-02-20 |  |  |  | 2006-01-20 | 2006-01-27 | 0d? | 23d |  | start no earlier than 2006-02-13 |  |  |  |
| 12 | 1.5.2 | Incorporar los componentes en la 701? | 4d? | 2006-03-20 | 2006-03-23 |  |  |  |  |  |  | 0d |  | start no earlier than 2006-03-20 |  |  |  |
| 13 | 1.5.3 | Probar sistema | 4d? | 2006-02-24 | 2006-03-01 |  |  |  |  |  |  | 15d | 0d | finish no earlier than 2006-03-01 |  |  |  |
| 14 | 1.5.4 | Aprobar sistema | 1d? | 2006-03-02 | 2006-03-02 | 13 |  |  |  |  |  | 15d |  |  |  |  |  |
| 15 | 1.6 | Cierre | 1d | 2006-03-03 | 2006-03-03 |  |  |  | 2006-02-08 | 2006-02-08 | 1d | 14d |  | start no earlier than 2006-03-03 |  |  |  |
