# ttgoportunidades

Schedule from MS Project, 2005-11-23 to 2006-03-02, A marks actual dates.
GWT

## Calendars

- Estándar: Mon-Fri 09:00-13:00, 15:00-19:00; Sat-Sun off.

## Resources

| Resource |
| --- |
| V Riera |
| V R |
| H Rosas V Riera |
| O Lorenzo |
| O Lorenzo V Riera |
| Vriera |

## Schedule

| ID | WBS | Task | Duration | Start | Finish | Predecessors | Complete | Remaining | Baseline start | Baseline finish | Baseline duration | Total slack | Constraint | Resources | Work | Actual work |
| --- | --- | --- | --- | --- | --- | --- | --- | --- | --- | --- | --- | --- | --- | --- | --- | --- |
| 1 | 1 | **Gerencia oportunidades** | 72d? | 2005-11-23 A | 2006-03-02 |  | 99% | 0.21d? | 2005-11-23 | 2006-02-08 | 56d? | 0d |  |  | 1088h | 1088h |
| 3 | 1.1 | Inicio | 1d? | 2005-11-23 A | 2005-11-23 A |  | 100% |  | 2005-11-23 | 2005-11-23 | 1d? |  | start no earlier than 2005-11-23 |  |  |  |
| 4 | 1.2 | **Definición del proceso** | 41d? | 2005-11-29 A | 2006-01-24 A |  | 100% |  | 2005-11-23 | 2005-12-01 | 7d |  |  | V Riera | 784h | 784h |
| 5 | 1.2.1 | Establecimiento de procesos | 35.5d | 2005-11-29 A | 2006-01-20 A |  | 100% |  | 2005-12-02 | 2005-12-12 | 7d |  |  | V Riera | 284h | 284h |
| 6 | 1.2.2 | Establecimiento de procedimientos | 28.5d? | 2005-12-13 A | 2006-01-20 A | 5 | 100% |  |  |  |  |  |  |  |  |  |
| 7 | 1.2.3 | Propuesta de Métricas | 25d | 2005-12-21 A | 2006-01-24 A |  | 100% |  | 2005-12-13 | 2005-12-21 | 7d |  | finish no earlier than 2006-01-24 | V Riera | 200h | 200h |
| 8 | 1.3 | **Incorporación a 701** | 31d | 2006-01-12 A | 2006-02-23 A | 7 | 100% |  | 2006-01-16 | 2006-01-24 | 7d |  |  | H Rosas V Riera | 304h | 304h |
| 9 | 1.3.1 | Definición de Métricas | 1d | 2006-01-12 A | 2006-01-25 A |  | 100% |  |  |  |  |  | finish no earlier than 2006-01-24 |  |  |  |
| 10 | 1.3.2 | Definición de tablas | 3d | 2006-01-16 A | 2006-01-27 A | 9 | 100% |  |  |  |  |  | start no earlier than 2006-01-16 | H Rosas V Riera | 24h | 24h |
| 11 | 1.3.3 | Definición de Campos | 1d | 2006-01-17 A | 2006-01-31 A | 10 | 100% |  |  |  |  |  |  | H Rosas V Riera | 8h | 8h |
| 12 | 1.3.4 | Puesta en producción del sistema | 3d | 2006-01-25 A | 2006-01-27 A |  | 100% |  |  |  |  |  |  |  |  |  |
| 13 | 1.3.5 | Prueba de Sistema | 2d | 2006-02-08 A | 2006-02-22 A | 12 | 100% |  | 2006-01-25 | 2006-02-07 | 10d |  |  | V Riera | 16h | 16h |
| 14 | 1.3.6 | Aprobación del sistema | 1d | 2006-02-23 A | 2006-02-23 A | 13 | 100% |  |  |  |  |  |  | V Riera | 8h | 8h |
| 15 | 1.4 | Cierre | 1d | 2006-03-02 A | 2006-03-02 | 14 | 70% | 0.3d | 2006-02-08 | 2006-02-08 | 1d | 0d |  |  |  |  |
