# Plan Implantación Fase I-Carao Records

Schedule from MS Project, 2007-03-05 to 2007-04-24.
Globalwebtek Venezuela C.A.

## Calendars

- Estándar: Mon-Fri 09:00-13:00, 15:00-19:00; Sat-Sun off.

## Resources

| Resource |
| --- |
| GP |
| R1 |
| AV |
| OP |
| CR |
| D1 |

## Schedule

| ID | WBS | Task | Type | Duration | Start | Finish | Predecessors | Total slack | Free slack | Constraint | Resources | Work |
| --- | --- | --- | --- | --- | --- | --- | --- | --- | --- | --- | --- | --- |
| 1 | 1 | **Cacao Records** |  | 36.75d? | 2007-03-05 09:00 | 2007-04-24 17:00 |  | 0d |  |  |  | 167h |
| 2 | 1.1 | Reunión de Arranque |  | 0.06d? | 2007-03-05 09:00 | 2007-03-05 09:30 |  | 34.94d |  |  | GP; CR | 1h |
| 3 | 1.2 | Análsis y preparación material para definición requerimientos |  | 0.25d? | 2007-03-06 09:00 | 2007-03-06 11:00 |  | 33.75d |  | start no earlier than 2007-03-06 09:00 | GP | 2h |
| 4 | 1.3 | **Especificación de Requerimientos** |  | 7d? | 2007-03-08 09:00 | 2007-03-19 09:00 |  | 26.75d |  |  |  | 15h |
| 5 | 1.3.1 | **Levantamiento de Información** |  | 2.12d? | 2007-03-08 09:00 | 2007-03-12 10:00 |  | 27.88d |  |  |  | 4h |
| 6 | 1.3.1.1 | Mesa de Trabajo #1 |  | 0.12d? | 2007-03-08 09:00 | 2007-03-08 10:00 |  | 31.88d |  | start no earlier than 2007-03-08 09:00 | GP; CR | 2h |
| 7 | 1.3.1.2 | Mesa de Trabajo #2 |  | 0.12d? | 2007-03-12 09:00 | 2007-03-12 10:00 |  | 29.62d | 0d | start no earlier than 2007-03-12 09:00 | GP; CR | 2h |
| 8 | 1.3.2 | Elaboración del Informe Especificación de Req. |  | 0.25d? | 2007-03-12 10:00 | 2007-03-12 12:00 | 7 | 29.62d |  |  | GP | 2h |
| 9 | 1.3.3 | Entrega a Cacao Records para su revisión | milestone | 0d? | 2007-03-13 09:00 | 2007-03-13 09:00 |  | 27.88d | 2d | start no earlier than 2007-03-13 09:00 | GP |  |
| 10 | 1.3.4 | Revisión por parte de Cacao Records | milestone | 0d? | 2007-03-14 19:00 | 2007-03-14 19:00 | 9 | 27.62d | 0d | finish no earlier than 2007-03-14 19:00 | CR |  |
| 11 | 1.3.5 | Recepción de ajustes recomendados al Informe |  | 1d? | 2007-03-15 09:00 | 2007-03-15 19:00 | 10 | 25.88d | 0d | finish no earlier than 2007-03-15 19:00 | GP | 8h |
| 12 | 1.3.6 | Ajustes al Informe Especificación de Requerimientos |  | 0.12d? | 2007-03-16 09:00 | 2007-03-16 10:00 | 11 | 25.88d | 0d |  | GP | 1h |
| 13 | 1.3.7 | Entrega de Especificación de Req. para aprobación | milestone | 0d? | 2007-03-16 10:00 | 2007-03-16 10:00 | 12 | 25.88d |  |  | GP |  |
| 14 | 1.3.8 | Aprobación del Informe Especificación de Requerimientos | milestone | 0d? | 2007-03-19 09:00 | 2007-03-19 09:00 |  | 25d |  | start no earlier than 2007-03-19 09:00 | CR |  |
| 15 | 1.4 | Informe Especificación de Requerimientos Aprobado |  | 1d? | 2007-03-20 09:00 | 2007-03-20 19:00 |  | 9.5d | 0d | start no earlier than 2007-03-20 09:00 |  |  |
| 16 | 1.5 | **Configuracion y Desarrollo** |  | 34.17d? | 2007-03-05 09:00 | 2007-04-20 10:20 |  | 2.58d |  |  |  | 127h |
| 17 | 1.5.1 | **Diseño Gráfico** |  | 8.38d? | 2007-03-12 12:00 | 2007-03-22 17:00 |  | 23d |  |  |  | 30h |
| 18 | 1.5.1.1 | Elaboración propuesta de diseño |  | 5d? | 2007-03-12 12:00 | 2007-03-19 12:00 | 8 | 24.12d | 0d | start no earlier than 2007-03-12 09:00 | D1 [30%] | 12h |
| 19 | 1.5.1.2 | Presentación al Cliente | milestone | 0d? | 2007-03-19 12:00 | 2007-03-19 12:00 | 18 | 24.12d | 0d | start no earlier than 2007-03-16 09:00 | GP |  |
| 20 | 1.5.1.3 | Aprobación por parte del Cliente | milestone | 0d? | 2007-03-19 12:00 | 2007-03-19 12:00 | 19 | 24.12d | 0d |  | CR |  |
| 21 | 1.5.1.4 | Elaboración de css y preparación de plantillas |  | 0.5d? | 2007-03-19 12:00 | 2007-03-19 18:00 | 20 | 24.12d |  |  | D1 | 4h |
| 22 | 1.5.1.5 | Preparación y Entrega de Contenido | milestone | 0d? | 2007-03-20 19:00 | 2007-03-20 19:00 |  | 21.25d | 0d | finish no earlier than 2007-03-20 19:00 | CR |  |
| 23 | 1.5.1.6 | Carga de contenido en WIB3 |  | 1.75d? | 2007-03-21 09:00 | 2007-03-22 17:00 | 22 | 21.25d |  |  | R1 | 14h |
| 24 | 1.5.2 | **Desarrollo de Aplicaciones** |  | 9d? | 2007-03-21 09:00 | 2007-04-02 19:00 |  | 11.25d |  |  |  | 72h |
| 25 | 1.5.2.1 | Blog |  | 4d? | 2007-03-21 09:00 | 2007-03-26 19:00 | 15, 13 | 9.5d | 0d | start no earlier than 2007-02-21 09:00 | R1 | 32h |
| 26 | 1.5.2.2 | Catalogo de Productos |  | 5d? | 2007-03-27 09:00 | 2007-04-02 19:00 | 25 | 9.5d | 0d | start no earlier than 2007-02-21 09:00 | R1 | 40h |
| 27 | 1.5.3 | Pruebas internas |  | 0.5d? | 2007-04-03 09:00 | 2007-04-03 13:00 | 26 | 9.5d | 0d |  | R1 | 4h |

| ID | WBS | Task | Type | Duration | Start | Finish | Predecessors | Total slack | Free slack | Constraint | Resources | Work |
| --- | --- | --- | --- | --- | --- | --- | --- | --- | --- | --- | --- | --- |
| 28 | 1.5.4 | **Plan de Pruebas** |  | 1d? | 2007-04-03 15:00 | 2007-04-04 13:00 |  | 14.25d |  |  |  | 1h |
| 29 | 1.5.4.1 | Elaboración Plan de Pruebas |  | 1d? | 2007-04-03 15:00 | 2007-04-04 13:00 | 27 | 12.5d |  |  | GP [12.5%] | 1h |
| 30 | 1.5.5 | Plan de Pruebas elaborado | milestone | 0d? | 2007-03-05 09:00 | 2007-03-05 09:00 |  | 35d |  |  | GP |  |
| 31 | 1.5.6 | Documentación |  | 11d? | 2007-03-21 09:00 | 2007-04-04 19:00 |  | 12d |  | finish no earlier than 2007-04-04 19:00 | R1 [4.5%]; GP [4.5%] | 8h |
| 32 | 1.5.7 | Adiestramiento |  | 4d? | 2007-04-03 15:00 | 2007-04-09 13:00 | 27 | 9.5d |  | finish no earlier than 2007-04-04 19:00 | GP [12.5%] | 4h |
| 33 | 1.5.8 | **Pruebas de Certificación** |  | 0.5d? | 2007-04-18 19:00 | 2007-04-19 13:00 |  | 2.36d |  |  |  | 4h |
| 34 | 1.5.8.1 | Realización de Pruebas de Funcionalidad (Certificación) | milestone | 0d? | 2007-04-18 19:00 | 2007-04-18 19:00 |  | 0.72d | 0d | finish no earlier than 2007-04-18 19:00 | AV |  |
| 35 | 1.5.8.2 | Realización de Ajustes recomendados |  | 0.5d? | 2007-04-19 09:00 | 2007-04-19 13:00 | 34 | 0.72d | 0d |  | R1 | 4h |
| 36 | 1.5.9 | Pruebas Certificadas | milestone | 0d? | 2007-04-19 13:00 | 2007-04-19 13:00 | 35 | 0.72d | 0d |  | AV |  |
| 37 | 1.5.10 | Puesta en Producción |  | 0.67d? | 2007-04-19 15:00 | 2007-04-20 10:20 | 36 | 0.72d | 0d |  | OP [75%]; GP [25%] | 4h |
| 38 | 1.6 | Gerencia de Proyecto |  | 36.75d? | 2007-03-05 09:00 | 2007-04-24 17:00 |  | 0d |  | start no earlier than 2007-03-05 09:00 | GP [6.8%] | 20h |
| 39 | 1.7 | Cierre |  | 0.22d? | 2007-04-20 10:20 | 2007-04-20 12:06 | 37 | 2.36d |  |  | GP; AV | 2h |
