# Cronograma Alcance Reestructurado Cines Unidos

Schedule from MS Project, 2007-03-15 to 2007-12-28.
Globalwebtek Venezuela C.A.

## Calendars

- Estándar: Mon-Fri 09:00-13:00, 15:00-19:00; Sat-Sun off. Exceptions (off unless hours are given): 2007-04-05 to 2007-04-06, 2007-04-19, 2007-05-01, 2007-07-05, 2007-07-24, 2007-10-12, 2007-12-25.

## Schedule

| ID | WBS | Task | Type | Duration | Start | Finish | Predecessors | Total slack | Free slack | Constraint | Work |
| --- | --- | --- | --- | --- | --- | --- | --- | --- | --- | --- | --- |
| 1 | 1 | **Cines Unidos** |  | 199d | 2007-03-15 | 2007-12-28 |  | 0d |  |  | 4644h |
| 2 | 1.1 | Reunión de Arranque |  | 0.31d | 2007-03-15 | 2007-03-15 |  | 198.69d |  | start no earlier than 2007-03-15 | 8h |
| 3 | 1.2 | **Etapa I - Preparandonos para la Independencia** |  | 76d | 2007-03-15 | 2007-07-04 |  | 86d |  |  | 2606h |
| 4 | 1.2.1 | **Fase I - Levantamiento de Información** |  | 20d | 2007-03-15 | 2007-04-13 |  | 86d |  |  | 468h |
| 5 | 1.2.1.1 | **Modelo de Procesos** |  | 7d | 2007-03-19 | 2007-03-27 |  | 190d |  |  | 120h |
| 6 | 1.2.1.1.1 | Mesa de Trabajo # 1 |  | 2d | 2007-03-19 | 2007-03-20 |  | 195d |  | start no earlier than 2007-03-19 | 40h |
| 7 | 1.2.1.1.2 | Mesa de Trabajo # 2 |  | 2d | 2007-03-22 | 2007-03-23 |  | 190d | 0d | start no earlier than 2007-03-22 | 40h |
| 8 | 1.2.1.1.3 | Mesa de Trabajo # 3 |  | 2d | 2007-03-26 | 2007-03-27 | 7 | 190d |  |  | 40h |
| 9 | 1.2.1.2 | **Modelo de Datos** |  | 8d | 2007-03-29 | 2007-04-11 |  | 179d |  |  | 64h |
| 10 | 1.2.1.2.1 | Mesa de Trabajo # 3 |  | 3d | 2007-03-29 | 2007-04-02 |  | 181d | 2d | start no earlier than 2007-03-29 | 32h |
| 11 | 1.2.1.2.2 | Mesa de Trabajo # 4 |  | 3d | 2007-04-09 | 2007-04-11 | 10 | 179d | 0d | start no earlier than 2007-04-09 | 32h |
| 12 | 1.2.1.3 | **Configuración Ambiente de Desarrollo** |  | 10d | 2007-03-19 | 2007-03-30 |  | 187d |  |  | 160h |
| 13 | 1.2.1.3.1 | Adiestramiento en configuración e instalación de Vista, Merchant e Infoworks |  | 5d | 2007-03-19 | 2007-03-23 |  | 187d | 0d | start no earlier than 2007-03-19 | 80h |
| 14 | 1.2.1.3.2 | Instalación y configuración de ambiente a imágen y semejanza de ambiente de producción de Cines Unidos |  | 5d | 2007-03-26 | 2007-03-30 | 13 | 187d |  |  | 40h |
| 15 | 1.2.1.3.3 | Configuración de VPN para acceso remoto |  | 5d | 2007-03-19 | 2007-03-23 |  | 192d |  | start no earlier than 2007-03-19 | 40h |
| 16 | 1.2.1.4 | **Infraestructura a Futuro** |  | 12d | 2007-03-15 | 2007-03-30 |  | 187d |  |  | 96h |
| 17 | 1.2.1.4.1 | Investigación de requerimientos de infraestructura |  | 10d | 2007-03-15 | 2007-03-28 |  | 187d | 0d |  | 80h |
| 18 | 1.2.1.4.2 | Elaborar informe de recmendaciones |  | 2d | 2007-03-29 | 2007-03-30 | 17 | 187d |  |  | 16h |
| 19 | 1.2.1.5 | **Informe de Especificación de Requerimientos** |  | 9d | 2007-03-30 | 2007-04-13 |  | 75d |  |  | 28h |
| 20 | 1.2.1.5.1 | Elaboración del Informe de Especificación de Requerimientos |  | 2d | 2007-04-12 | 2007-04-13 | 11 | 179d | 0d |  | 20h |
| 21 | 1.2.1.5.2 | Entrega al Equipo de Proyecto CU para su revisión | milestone | 0d | 2007-04-13 | 2007-04-13 | 20 | 179d | 0d | start no earlier than 2006-12-01 |  |
| 22 | 1.2.1.5.3 | Revisión por parte del Equipo de Proyecto CU | milestone | 0d | 2007-04-13 | 2007-04-13 | 21 | 179d |  |  |  |
| 23 | 1.2.1.5.4 | Ajustes al Informe Especificación de Requerimientos |  | 2d | 2007-03-30 | 2007-04-02 |  | 75d | 0d | start no earlier than 2007-03-30 | 8h |
| 24 | 1.2.1.5.5 | Entrega de Especificación de Req. para aprobación | milestone | 0d | 2007-04-02 | 2007-04-02 | 23 | 75d | 2d | start no earlier than 2006-12-07 |  |
| 25 | 1.2.1.5.6 | Aprobación del Informe Especificación de Requerimientos | milestone | 0d | 2007-04-05 | 2007-04-05 | 24 | 73d | 0d | start no earlier than 2007-04-05 |  |
| 26 | 1.2.2 | Informe Especificación de Requerimientos Aprobado | milestone | 0d | 2007-04-05 | 2007-04-05 | 25 | 184d |  |  |  |
| 27 | 1.2.3 | Modelo de Procesos Definido | milestone | 0d | 2007-04-05 | 2007-04-05 | 25 | 184d |  |  |  |
| 28 | 1.2.4 | Modelo de Datos Definido | milestone | 0d | 2007-04-05 | 2007-04-05 | 25 | 73d | 0d |  |  |

| ID | WBS | Task | Type | Duration | Start | Finish | Predecessors | Total slack | Free slack | Work |
| --- | --- | --- | --- | --- | --- | --- | --- | --- | --- | --- |
| 29 | 1.2.5 | **Fase II - Conformación de las bases** |  | 58d | 2007-04-09 | 2007-06-29 |  | 73d |  | 1954h |
| 30 | 1.2.5.1 | **Directorio de Clientes** |  | 10d | 2007-04-09 | 2007-04-23 | 28 | 73d | 0d | 176h |
| 31 | 1.2.5.1.1 | Análisis del Modelo de Datos de Clientes y Transacciones del proveedor actual (BD) |  | 2d | 2007-04-09 | 2007-04-10 | 28 | 73d | 0d | 24h |
| 32 | 1.2.5.1.2 | Equivalencia entre la base de datos del Proveedor Actual vs. lo levantado |  | 2d | 2007-04-11 | 2007-04-12 | 31 | 73d | 0d | 16h |
| 33 | 1.2.5.1.3 | Crear en N2C la nueva estructura de la B.D de Clientes y Transacciones |  | 2d | 2007-04-13 | 2007-04-16 | 32 | 73d | 0d | 24h |
| 34 | 1.2.5.1.4 | Carga inicial de datos de Clientes y Transacciones en N2C |  | 3d | 2007-04-17 | 2007-04-20 | 33 | 73d | 0d | 40h |
| 35 | 1.2.5.1.5 | Implementar mecanismo de carga diaria de datos provenientes del Proveedor Actual a Cines Unidos |  | 1d | 2007-04-23 | 2007-04-23 | 34 | 73d |  | 16h |
| 36 | 1.2.5.1.6 | Implementar facilidad de monitoreo quincenal de los datos para su depuración |  | 2d | 2007-04-09 | 2007-04-10 | 28 | 81d |  | 24h |
| 37 | 1.2.5.1.7 | Envio de correos masivos con políticas de colas y administración de mensajes devueltos |  | 3d | 2007-04-09 | 2007-04-11 | 28 | 80d |  | 32h |
| 38 | 1.2.5.2 | **Reportes de Clientes** |  | 6d | 2007-04-11 | 2007-04-18 | 31 | 176d |  | 98h |
| 39 | 1.2.5.2.1 | Implementación de 10 reportes básicos |  | 3d | 2007-04-11 | 2007-04-13 |  | 179d |  | 32h |
| 40 | 1.2.5.2.2 | Implementación de 3 reportes estadísticos |  | 5d | 2007-04-11 | 2007-04-17 |  | 176d | 0d | 50h |
| 41 | 1.2.5.2.3 | Adiestramiento al personal de Cines Unidos |  | 1d | 2007-04-18 | 2007-04-18 | 40 | 176d |  | 16h |
| 42 | 1.2.5.3 | CRM |  | 10d | 2007-04-24 | 2007-05-08 | 30 | 164d |  | 160h |
| 43 | 1.2.5.4 | Vista |  | 40d | 2007-04-24 | 2007-06-19 | 30 | 134d |  | 600h |
| 44 | 1.2.5.5 | Merchant |  | 40d | 2007-04-24 | 2007-06-19 | 30 | 73d | 0d | 600h |
| 45 | 1.2.5.6 | Pagina Web |  | 15d | 2007-04-24 | 2007-05-15 | 30 | 159d |  | 200h |
| 46 | 1.2.5.7 | **Implantación** |  | 8d | 2007-06-20 | 2007-06-29 |  | 73d |  | 120h |
| 47 | 1.2.5.7.1 | Pruebas internas |  | 2d | 2007-06-20 | 2007-06-21 | 44 | 73d | 0d | 32h |
| 48 | 1.2.5.7.2 | Documentación |  | 3d | 2007-06-22 | 2007-06-26 | 47 | 73d | 0d | 40h |
| 49 | 1.2.5.7.3 | Adiestramiento |  | 2d | 2007-06-27 | 2007-06-28 | 48 | 73d | 0d | 24h |
| 50 | 1.2.5.7.4 | Pruebas de Certificación |  | 1d | 2007-06-29 | 2007-06-29 | 49 | 73d | 0d | 24h |
| 51 | 1.2.6 | Directorios de Clientes implantado | milestone | 0d | 2007-06-29 | 2007-06-29 | 50 | 126d |  |  |
| 52 | 1.2.7 | Reportes de Clientes implantado | milestone | 0d | 2007-06-29 | 2007-06-29 | 50 | 126d |  |  |
| 53 | 1.2.8 | CRM implantado | milestone | 0d | 2007-06-29 | 2007-06-29 | 50 | 126d |  |  |
| 54 | 1.2.9 | N2C y Vista Integrados | milestone | 0d | 2007-06-29 | 2007-06-29 | 50 | 126d |  |  |
| 55 | 1.2.10 | N2C y Merchant integrados | milestone | 0d | 2007-06-29 | 2007-06-29 | 50 | 126d |  |  |
| 56 | 1.2.11 | N2C y Página web integrados | milestone | 0d | 2007-06-29 | 2007-06-29 | 50 | 73d | 0d |  |

| ID | WBS | Task | Type | Duration | Start | Finish | Predecessors | Total slack | Free slack | Constraint | Work |
| --- | --- | --- | --- | --- | --- | --- | --- | --- | --- | --- | --- |
| 57 | 1.2.12 | **Fase III - Independencia** |  | 3d | 2007-07-02 | 2007-07-04 |  | 73d |  |  | 184h |
| 58 | 1.2.12.1 | Pruebas Independencia |  | 2d | 2007-07-02 | 2007-07-03 | 56 | 73d | 0d |  | 160h |
| 59 | 1.2.12.2 | Independizarse del proveedor actual |  | 1d | 2007-07-04 | 2007-07-04 | 58 | 73d | 0d |  | 24h |
| 60 | 1.2.13 | Cines Unidos independizado de Proveedor Actual | milestone | 0d | 2007-07-04 | 2007-07-04 | 59 | 73d | 0d |  |  |
| 61 | 1.3 | **Etapa II - Hacia al e_Business** |  | 50d | 2007-07-06 | 2007-09-14 |  | 73d |  |  | 672h |
| 62 | 1.3.1 | Cartelera Cinematográfica |  | 30d | 2007-07-06 | 2007-08-17 | 60 | 93d |  |  | 120h |
| 63 | 1.3.2 | Integración Call Center |  | 30d | 2007-07-06 | 2007-08-17 | 60 | 73d | 0d |  | 200h |
| 64 | 1.3.3 | Integración Tienda Cines Unidos |  | 20d | 2007-08-20 | 2007-09-14 | 63 | 73d |  |  | 200h |
| 65 | 1.3.4 | Pruebas internas |  | 5d | 2007-08-20 | 2007-08-24 | 63 | 76d | 0d |  | 40h |
| 66 | 1.3.5 | Documentación |  | 5d | 2007-08-27 | 2007-08-31 | 65 | 76d | 0d |  | 40h |
| 67 | 1.3.6 | Adiestramiento |  | 2d | 2007-09-03 | 2007-09-04 | 66 | 76d | 0d |  | 32h |
| 68 | 1.3.7 | Pruebas de Certificación |  | 5d | 2007-09-05 | 2007-09-11 | 67 | 76d | 0d |  | 40h |
| 69 | 1.3.8 | Cartelera Cinematográfica implantada | milestone | 0d | 2007-09-11 | 2007-09-11 | 68 | 76d |  |  |  |
| 70 | 1.3.9 | Integración Call Center implantado | milestone | 0d | 2007-09-11 | 2007-09-11 | 68 | 76d |  |  |  |
| 71 | 1.3.10 | Integración Tienda Cines Unidos implantado | milestone | 0d | 2007-09-11 | 2007-09-11 | 68 | 76d |  |  |  |
| 72 | 1.4 | **Etapa III - Inteligencia de Negocio** |  | 199d | 2007-03-15 | 2007-12-28 |  | 0d |  |  | 1358h |
| 73 | 1.4.1 | Integración con InfoWorks y/o Pentaho |  | 40d | 2007-11-01 | 2007-12-27 |  | 1d |  | start no earlier than 2007-11-01 | 500h |
| 74 | 1.4.2 | Gerencia de Proyectos |  | 198d | 2007-03-15 | 2007-12-27 |  | 0d |  | start no earlier than 2007-03-15 | 850h |
| 75 | 1.4.3 | Cierre |  | 1d | 2007-12-28 | 2007-12-28 | 74 | 0d |  |  | 8h |
