# Centro de Convenciones

Schedule from MS Project, 2007-05-02 to 2007-08-30.
GlobalWebTek

## Calendars

- Standard: Mon-Fri 08:00-12:00, 13:00-17:00; Sat-Sun off. Exceptions (off unless hours are given): 2007-07-05, 2007-07-24.

## Resources

| Resource |
| --- |
| GP |
| OP |
| DS1 |
| DS2 |
| D |
| PMO |
| AP |
| LT |

## Schedule

| ID | WBS | Task | Duration | Start | Finish | Predecessors | Total slack | Free slack | Constraint | Resources | Work |
| --- | --- | --- | --- | --- | --- | --- | --- | --- | --- | --- | --- |
| 1 | 1 | **Centro de Convenciones - Fase I** | 84.66d? | 2007-05-02 | 2007-08-30 |  | 0d |  |  |  | 979.6h |
| 2 | 1.1 | **Inicio** | 18d? | 2007-05-02 | 2007-05-25 |  | 0d |  |  |  | 79h |
| 3 | 1.1.1 | Preparación de Kickoff | 0.38d? | 2007-05-02 | 2007-05-02 |  | 1.96d | 0d | start no earlier than 2007-05-02 | GP | 3h |
| 4 | 1.1.2 | Reunión de Kickoff | 8h | 2007-05-02 | 2007-05-03 | 3 | 1.96d | 0d |  | GP | 8h |
| 5 | 1.1.3 | Preparación de Ambiente de Desarrollo de aplicación | 6d? | 2007-05-03 | 2007-05-11 | 4 | 10.62d |  |  | OP [25%] | 12h |
| 6 | 1.1.4 | Levantamiento de Información | 2.67d? | 2007-05-03 | 2007-05-08 | 4 | 1.96d | 0d |  | GP [50%]; DS1 [50%]; DS2 [50%] | 32h |
| 7 | 1.1.5 | Documento de Especificación de Requerimientos | 12d? | 2007-05-08 | 2007-05-24 | 6 | 1.96d |  |  | GP [25%] | 24h |
| 8 | 1.1.6 | Documento Aprobado por Cliente | 1d? | 2007-05-25 | 2007-05-25 |  | 0d |  | start no earlier than 2007-05-25 |  |  |
| 9 | 1.2 | **Intranet** | 20.13d? | 2007-05-28 | 2007-06-25 |  | 0d |  |  |  | 229.6h |
| 10 | 1.2.1 | Análisis y Diseño del Sistema Fase I | 6d? | 2007-05-28 | 2007-06-04 | 8 | 6.01d | 0d |  | GP [10%]; LT [35%] | 21.6h |
| 11 | 1.2.2 | **General** | 8.12d? | 2007-06-05 | 2007-06-15 |  | 6.01d | 0d |  |  | 52h |
| 12 | 1.2.2.1 | Parámetros del Sistema | 0.62d? | 2007-06-05 | 2007-06-05 | 10 | 6.01d | 0d |  | DS1 [80%] | 4h |
| 13 | 1.2.2.2 | Manejo de Perfiles | 2.5d? | 2007-06-05 | 2007-06-08 | 12 | 6.01d | 0d |  | DS1 [80%] | 16h |
| 14 | 1.2.2.3 | Registro y Actualización de Cliente | 1.25d? | 2007-06-08 | 2007-06-11 | 13 | 6.01d | 0d |  | DS1 [80%] | 8h |
| 15 | 1.2.2.4 | Registro y Actualización de Secciones | 1.25d? | 2007-06-11 | 2007-06-12 | 14 | 6.01d | 0d |  | DS1 [80%] | 8h |
| 16 | 1.2.2.5 | Registro y actualización de Asientos | 1.25d? | 2007-06-12 | 2007-06-13 | 15 | 6.01d | 0d |  | DS1 [80%] | 8h |
| 17 | 1.2.2.6 | Registro de Eventos y costo de asientos por sección | 1.25d? | 2007-06-13 | 2007-06-15 | 16 | 6.01d |  |  | DS1 [80%] | 8h |
| 18 | 1.2.3 | **Tramitación de Boletos** | 11.88d? | 2007-05-28 | 2007-06-12 |  | 0d |  |  |  | 76h |
| 19 | 1.2.3.1 | Reservación de Boletos | 3.75d? | 2007-05-28 | 2007-05-31 | 2 | 0d |  |  | DS2 [80%] | 24h |
| 20 | 1.2.3.2 | Compra de Boletos | 3.75d? | 2007-05-31 | 2007-06-06 | 19 | 0d |  |  | DS2 [80%] | 24h |
| 21 | 1.2.3.3 | Registro de Pago | 2.5d? | 2007-06-06 | 2007-06-08 | 20 | 0d |  |  | DS2 [80%] | 16h |
| 22 | 1.2.3.4 | Generación de Datos de Boletos vendidos | 1.88d? | 2007-06-11 | 2007-06-12 | 21 | 0d |  |  | DS2 [80%] | 12h |
| 23 | 1.2.4 | **Interfaz con Sistema de Torniquetes** | 2.31d? | 2007-06-12 | 2007-06-15 |  | 0d |  |  |  | 20h |
| 24 | 1.2.4.1 | Comunicación Aplicación a Sistema Torniquetes | 1.39d? | 2007-06-12 | 2007-06-14 | 18 | 0d |  |  | DS2 [80%]; LT [35%] | 12h |
| 25 | 1.2.4.2 | Recepción de solicitudes desde Torniquetes | 0.93d? | 2007-06-14 | 2007-06-15 | 24 | 0d |  |  | DS2 [80%]; LT [35%] | 8h |

Notes:
- 1: Este proyecto asume la participación en un 100% de los dos recursos de Desarrollo

| ID | WBS | Task | Duration | Start | Finish | Predecessors | Total slack | Free slack | Constraint | Resources | Work |
| --- | --- | --- | --- | --- | --- | --- | --- | --- | --- | --- | --- |
| 26 | 1.2.5 | **Reposición de Data** | 4.44d? | 2007-06-15 | 2007-06-21 |  | 0d |  |  |  | 48h |
| 27 | 1.2.5.1 | Para Reservación | 1.11d? | 2007-06-15 | 2007-06-18 | 23 | 0d |  |  | DS1 [50%]; DS2 [50%]; LT [35%] | 12h |
| 28 | 1.2.5.2 | Para Compra | 1.11d? | 2007-06-18 | 2007-06-19 | 27 | 0d |  |  | DS1 [50%]; DS2 [50%]; LT [35%] | 12h |
| 29 | 1.2.5.3 | Para Registro de Pago | 1.11d? | 2007-06-19 | 2007-06-20 | 28 | 0d |  |  | DS1 [50%]; DS2 [50%]; LT [35%] | 12h |
| 30 | 1.2.5.4 | Para Comunicación con Torniquetes | 1.11d? | 2007-06-20 | 2007-06-21 | 29 | 0d |  |  | DS1 [50%]; DS2 [50%]; LT [35%] | 12h |
| 31 | 1.2.6 | **Reportes** | 1.5d? | 2007-06-21 | 2007-06-25 |  | 0d |  |  |  | 12h |
| 32 | 1.2.6.1 | Clientes Registrados | 0.38d? | 2007-06-21 | 2007-06-22 | 26 | 0d |  |  | DS1 | 3h |
| 33 | 1.2.6.2 | Boletos Reservados | 0.38d? | 2007-06-22 | 2007-06-22 | 32 | 0d |  |  | DS2 | 3h |
| 34 | 1.2.6.3 | Boletos Vendidos | 0.38d? | 2007-06-22 | 2007-06-22 | 33 | 0d |  |  | DS2 | 3h |
| 35 | 1.2.6.4 | Disponibilidad de asientos por sección | 0.38d? | 2007-06-22 | 2007-06-25 | 34 | 0d |  |  | DS2 | 3h |
| 36 | 1.3 | **Certificado SSL** | 23.62d? | 2007-06-25 | 2007-07-30 |  | 22.91d |  |  |  | 51h |
| 37 | 1.3.1 | Tramitación de Certificado SSL | 10d? | 2007-06-25 | 2007-07-10 | 9 | 22.91d | 0d |  | OP [10%] | 8h |
| 38 | 1.3.2 | Instalación de Certificado | 1.88d? | 2007-07-10 | 2007-07-12 | 37 | 22.91d | 0d |  | OP [20%] | 3h |
| 39 | 1.3.3 | Uso de https en Autenticación y Pagos | 1.74d? | 2007-07-12 | 2007-07-13 | 38 | 22.91d |  | start no earlier than 2007-03-06 | DS1 [80%]; DS2 [80%]; LT [35%] | 24h |
| 40 | 1.3.4 | Implantación en ambiente Producción | 10d? | 2007-07-13 | 2007-07-30 | 39 | 22.91d |  |  | OP [20%] | 16h |
| 41 | 1.4 | Integración | 20d? | 2007-06-25 | 2007-07-25 | 9 | 0d |  |  | AP; LT [35%]; DS1 [20%]; DS2 [20%]; GP [10%]; OP [20%] | 328h |
| 42 | 1.5 | **Pruebas** | 50.13d? | 2007-05-28 | 2007-08-08 |  | 0d |  |  |  | 128h |
| 43 | 1.5.1 | Pruebas Internas y Ajustes | 16.67d? | 2007-06-25 | 2007-07-18 | 9 | 7.33d | 0d |  | DS1 [80%]; DS2 [80%]; GP [10%] | 40h |
| 44 | 1.5.2 | Pruebas Integrales | 10d? | 2007-07-25 | 2007-08-08 | 41 | 0d |  |  | GP [10%]; LT [20%]; DS1 [20%]; DS2 [20%]; AP [20%] | 40h |
| 45 | 1.5.3 | Plan de Pruebas | 8d? | 2007-05-28 | 2007-06-06 | 2 | 42.13d |  |  | GP [25%] | 16h |
| 46 | 1.5.4 | Pruebas Certificación | 1d? | 2007-07-18 | 2007-07-19 | 43 | 7.33d | 0d |  |  |  |
| 47 | 1.5.5 | Ajustes | 4d? | 2007-07-19 | 2007-07-26 | 46 | 7.33d | 0d |  | DS1 [50%]; DS2 [50%] | 32h |
| 48 | 1.5.6 | Certificación del Sistema | 1d? | 2007-07-26 | 2007-07-27 | 47 | 7.33d |  |  |  |  |
| 49 | 1.6 | **Adiestramiento** | 9.77d? | 2007-08-08 | 2007-08-21 |  | 0d |  |  |  | 31h |
| 50 | 1.6.1 | Guia de Usuario | 9.27d? | 2007-08-08 | 2007-08-21 | 42 | 0d |  |  | GP [10%]; DS1 [60%]; DS2 [60%]; LT [15%] | 23h |
| 51 | 1.6.2 | Adiestramiento a Usuarios | 0.5d? | 2007-08-21 | 2007-08-21 | 50 | 0d |  |  | GP; LT | 8h |

Notes:
- 26: Esto implica el manejo de transacciones que quedan sin terminar
- 41: Tareas de Arturo Puente respecto a la implementación general de hardware y plan de contingencia. Incluye pruebas de integración

| ID | WBS | Task | Duration | Start | Finish | Predecessors | Total slack | Resources | Work |
| --- | --- | --- | --- | --- | --- | --- | --- | --- | --- |
| 52 | 1.7 | **Puesta en Marcha** | 16.52d? | 2007-08-08 | 2007-08-30 |  | 0d |  | 27h |
| 53 | 1.7.1 | Implantación en Producción Integrada | 2d | 2007-08-08 | 2007-08-10 | 42 | 14.52d | OP | 16h |
| 54 | 1.7.2 | **Cierre de Proyecto** | 5.75d? | 2007-08-21 | 2007-08-29 |  | 0d |  | 11h |
| 55 | 1.7.2.1 | Preparación Acta de Cierre | 1.25d? | 2007-08-21 | 2007-08-23 | 49 | 0d | GP [10%] | 1h |
| 56 | 1.7.2.2 | Preparación Presentación | 2.5d? | 2007-08-23 | 2007-08-27 | 55 | 0d | GP [10%] | 2h |
| 57 | 1.7.2.3 | Reunión de Cierre | 2d? | 2007-08-27 | 2007-08-29 | 56 | 0d | GP [25%]; LT [25%] | 8h |
| 58 | 1.7.3 | Sistema en Producción | 1d? | 2007-08-29 | 2007-08-30 | 54 | 0d |  |  |
| 59 | 1.8 | **Gerencia de Proyecto** | 36.62d? | 2007-05-28 | 2007-07-18 |  | 30.03d |  | 106h |
| 60 | 1.8.1 | Planificación, Control, Seguimiento | 11.25d | 2007-05-28 | 2007-06-12 | 8 | 55.41d | GP [30%] | 27h |
| 61 | 1.8.2 | Reuniones de Seguimiento Fase I | 180h | 2007-06-15 | 2007-07-18 | 11 | 30.03d | GP [35%] | 63h |
| 62 | 1.8.3 | PMO | 33.33d? | 2007-05-28 | 2007-07-13 | 8 | 33.32d | PMO [6%] | 16h |
