# Proyect Diseño_2003

Schedule from MS Project, 2007-05-07 to 2007-06-22.
AMB Mercanet

## Calendars

- Estándar: Mon-Fri 09:00-13:00, 15:00-19:00; Sat-Sun off.

## Resources

| Resource | Rate |
| --- | --- |
| Gerente de Proyecto | 50 |
| Diseñador | 40 |
| Desarrollador | 35 |
| Programador | 40 |
| GP |  |
| Cl |  |
| DE |  |
| C |  |
| DI |  |
| OP |  |

## Schedule

| ID | WBS | Task | Type | Duration | Start | Finish | Predecessors | Total slack | Free slack | Constraint | Resources | Work |
| --- | --- | --- | --- | --- | --- | --- | --- | --- | --- | --- | --- | --- |
| 1 | 1 | **Proyecto Sitio Web Alco** |  | 34.62d? | 2007-05-07 09:00 | 2007-06-22 16:00 |  | 0d |  |  |  | 210h |
| 2 | 1.1 | Reunión de Arranque |  | 0.12d? | 2007-05-07 09:00 | 2007-05-07 10:00 |  | 39.5d | 0.88d |  | GP; Cl | 2h |
| 3 | 1.2 | **Especificación de Requerimientos** |  | 11d? | 2007-05-08 09:00 | 2007-05-22 19:00 |  | 10.29d |  |  |  | 10h |
| 4 | 1.2.1 | **Levantamiento de Información** |  | 0.46d? | 2007-05-08 09:00 | 2007-05-08 12:40 |  | 33.17d |  |  |  | 4h |
| 5 | 1.2.1.1 | Mesa de Trabajo #1 |  | 0.38d? | 2007-05-08 09:00 | 2007-05-08 12:40 | 2 | 15.92d |  | start no earlier than 2007-05-08 08:00 | GP; Cl; DE | 4h |
| 6 | 1.2.2 | Elaboración del Informe Especificación de Req. |  | 0.5d? | 2007-05-11 09:00 | 2007-05-11 13:00 |  | 12.62d | 0.5d | start no earlier than 2007-05-11 08:00 | GP | 4h |
| 7 | 1.2.3 | Entrega del Informe para su revisión | milestone | 0d? | 2007-05-14 08:00 | 2007-05-14 08:00 | 6 | 12.12d | 1d | start no earlier than 2007-05-14 08:00 | GP |  |
| 8 | 1.2.4 | Revisión por parte del Cliente | milestone | 0d? | 2007-05-15 08:00 | 2007-05-15 08:00 | 7 | 11.12d | 1d | start no earlier than 2007-05-15 08:00 | Cl |  |
| 9 | 1.2.5 | Recepción de ajustes recomendados al Informe | milestone | 0d? | 2007-05-17 08:00 | 2007-05-17 08:00 | 8 | 26.38d | 1d | start no earlier than 2007-05-17 08:00 | GP |  |
| 10 | 1.2.6 | Ajustes al Informe Especificación de Requerimientos |  | 0.25d? | 2007-05-18 09:00 | 2007-05-18 11:00 | 9 | 8.12d | 0.75d | start no earlier than 2007-05-18 08:00 | GP | 2h |
| 11 | 1.2.7 | Entrega de Especificación de Req. para aprobación | milestone | 0d? | 2007-05-21 08:00 | 2007-05-21 08:00 | 10 | 7.38d | 0d | start no earlier than 2007-05-21 08:00 | GP |  |
| 12 | 1.2.8 | Aprobación del Informe Especificación de Requerimientos | milestone | 0d? | 2007-05-21 08:00 | 2007-05-21 08:00 | 11 | 7.38d |  |  | Cl |  |
| 13 | 1.2.9 | Informe Especificación de Requerimientos Aprobado |  | 1d? | 2007-05-22 09:00 | 2007-05-22 19:00 |  | 0.29d | 0d | start no earlier than 2007-05-22 08:00 |  |  |
| 14 | 1.3 | **Correcciones y Ajustes de Diseño propuestos por el Cliente** |  | 1.75d? | 2007-05-22 19:00 | 2007-05-24 17:00 |  | 0.29d |  |  |  | 14h |
| 15 | 1.3.1 | Recepcion de Ajustes propuestos por el Cliente | milestone | 0d? | 2007-05-22 19:00 | 2007-05-22 19:00 | 13 | 0.29d | 0d |  | DI |  |
| 16 | 1.3.2 | Ajustes Graficos propuestos por el Cliente |  | 0.25d? | 2007-05-23 09:00 | 2007-05-23 11:00 | 15 | 0.29d | 0d |  | DI | 2h |
| 17 | 1.3.3 | Homologacion y Ajustes Finales de las 3 propuestas |  | 0.25d? | 2007-05-23 11:00 | 2007-05-23 13:00 | 16 | 0.29d | 0d |  | DI | 2h |
| 18 | 1.3.4 | Conversion a Formatos Graficos para paquetizacion y envio |  | 0.12d? | 2007-05-23 15:00 | 2007-05-23 16:00 | 17 | 0.29d | 0d |  | DI | 1h |
| 19 | 1.3.5 | Conversion a Formato Web para paquetizacion y envio |  | 0.12d? | 2007-05-23 16:00 | 2007-05-23 17:00 | 18 | 0.29d | 0d |  | DI | 1h |
| 20 | 1.3.6 | Entrega de la Propuesta al Cliente | milestone | 0d? | 2007-05-23 17:00 | 2007-05-23 17:00 | 19 | 0.29d | 0d |  | DI |  |
| 21 | 1.3.7 | Aprobacion de la Propuesta por parte del Cliente |  | 1d? | 2007-05-23 17:00 | 2007-05-24 17:00 | 20 | 20.88d |  |  | DI | 8h |
| 22 | 1.4 | **Diseño del Sitio Web** |  | 16.62d? | 2007-05-23 17:00 | 2007-06-15 12:00 |  | 0.29d |  |  |  | 127h |
| 23 | 1.4.1 | Recepcion de Material Grafico | milestone | 0d? | 2007-05-23 17:00 | 2007-05-23 17:00 | 20 | 0.29d | 0d |  | DI |  |
| 24 | 1.4.2 | Procesado de Material Grafico |  | 0.5d? | 2007-05-23 17:00 | 2007-05-24 11:00 | 23 | 0.29d | 0d |  | DI | 4h |
| 25 | 1.4.3 | Adaptacion multiformato de Material Grafico |  | 0.38d? | 2007-05-24 11:00 | 2007-05-24 16:00 | 24 | 0.29d | 0d |  | DI | 3h |
| 26 | 1.4.4 | Extraccion y Adaptacion de texturas y fondos |  | 0.38d? | 2007-05-24 16:00 | 2007-05-24 19:00 | 25 | 0.29d | 0d |  | DI | 3h |
| 27 | 1.4.5 | Extraccion y Adaptacion de Manchas y Elementos de Apoyo |  | 0.25d? | 2007-05-25 09:00 | 2007-05-25 11:00 | 26 | 0.29d | 0d |  | DI | 2h |

| ID | WBS | Task | Duration | Start | Finish | Predecessors | Total slack | Free slack | Resources | Work |
| --- | --- | --- | --- | --- | --- | --- | --- | --- | --- | --- |
| 28 | 1.4.6 | **Desarrollo del Sitio Web** | 15.12d? | 2007-05-25 11:00 | 2007-06-15 12:00 |  | 0.29d |  |  | 115h |
| 29 | 1.4.6.1 | Configuracion del Sitio | 0.25d? | 2007-05-25 11:00 | 2007-05-25 13:00 | 27 | 0.29d | 0d | DI | 2h |
| 30 | 1.4.6.2 | **Diseño de Elementos de Diseño** | 0.88d? | 2007-05-25 15:00 | 2007-05-28 12:00 |  | 0.29d |  |  | 7h |
| 31 | 1.4.6.2.1 | Diseño y Adaptacion de Elementos Comunes (Bullets, Tramas y Texturas) | 0.25d? | 2007-05-25 15:00 | 2007-05-25 17:00 | 29 | 0.29d | 0d | DI | 2h |
| 32 | 1.4.6.2.2 | Diseño y Adaptacion de Elementos del Encabezado | 0.12d? | 2007-05-25 17:00 | 2007-05-25 18:00 | 31 | 0.29d | 0d | DI | 1h |
| 33 | 1.4.6.2.3 | Diseño y Adaptacion de Elementos de Navegacion | 0.12d? | 2007-05-25 18:00 | 2007-05-25 19:00 | 32 | 0.29d | 0d | DI | 1h |
| 34 | 1.4.6.2.4 | Diseño y Adaptacion de Elementos de apoyo a Contenidos | 0.25d? | 2007-05-28 09:00 | 2007-05-28 11:00 | 33 | 0.29d | 0d | DI | 2h |
| 35 | 1.4.6.2.5 | Diseño y Adaptacion de Elementos de Pie de Pagina y Marcas de Registro | 0.12d? | 2007-05-28 11:00 | 2007-05-28 12:00 | 34 | 0.29d | 0d | DI | 1h |
| 36 | 1.4.6.3 | **Creacion de Hoja de Estilos** | 0.88d? | 2007-05-28 12:00 | 2007-05-29 11:00 |  | 0.29d |  |  | 7h |
| 37 | 1.4.6.3.1 | Diseño de Estilos HTML | 0.12d? | 2007-05-28 12:00 | 2007-05-28 13:00 | 35 | 0.29d | 0d | DI | 1h |
| 38 | 1.4.6.3.2 | Diseño de Etiquetas Class | 0.12d? | 2007-05-28 15:00 | 2007-05-28 16:00 | 37 | 0.29d | 0d | DI | 1h |
| 39 | 1.4.6.3.3 | Diseño de Etiquetas Div | 0.12d? | 2007-05-28 16:00 | 2007-05-28 17:00 | 38 | 0.29d | 0d | DI | 1h |
| 40 | 1.4.6.3.4 | Diseño de PseudoClases | 0.12d? | 2007-05-28 17:00 | 2007-05-28 18:00 | 39 | 0.29d | 0d | DI | 1h |
| 41 | 1.4.6.3.5 | Diseño de Navegacion | 0.12d? | 2007-05-28 18:00 | 2007-05-28 19:00 | 40 | 0.29d | 0d | DI | 1h |
| 42 | 1.4.6.3.6 | Parametrizacion y Homologacion | 0.25d? | 2007-05-29 09:00 | 2007-05-29 11:00 | 41 | 18.38d |  | DI | 2h |
| 43 | 1.4.6.4 | **Creacion de Layout (3 Templates)** | 0.5d? | 2007-05-29 09:00 | 2007-05-29 13:00 |  | 0.29d |  |  | 4h |
| 44 | 1.4.6.4.1 | Diseño de Layout 1 | 0.25d? | 2007-05-29 09:00 | 2007-05-29 11:00 | 41 | 0.29d | 0d | DI | 2h |
| 45 | 1.4.6.4.2 | Diseño de Layout 2 | 0.12d? | 2007-05-29 11:00 | 2007-05-29 12:00 | 44 | 0.29d | 0d | DI | 1h |
| 46 | 1.4.6.4.3 | Diseño de Layout Generico | 0.12d? | 2007-05-29 12:00 | 2007-05-29 13:00 | 45 | 0.29d | 0d | DI | 1h |
| 47 | 1.4.6.5 | **Creacion de Elementos Comunes** | 0.5d? | 2007-05-29 15:00 | 2007-05-29 19:00 |  | 0.29d |  |  | 4h |
| 48 | 1.4.6.5.1 | Diseño de Barra de Navegacion Principal (archivo externo) | 0.25d? | 2007-05-29 15:00 | 2007-05-29 17:00 | 46 | 0.29d | 0d | DI | 2h |
| 49 | 1.4.6.5.2 | Diseño de Head | 0.12d? | 2007-05-29 17:00 | 2007-05-29 18:00 | 48 | 0.29d | 0d | DI | 1h |
| 50 | 1.4.6.5.3 | Diseño de Pie | 0.12d? | 2007-05-29 18:00 | 2007-05-29 19:00 | 49 | 0.29d | 0d | DI | 1h |
| 51 | 1.4.6.6 | **Ajustes de Diseño** | 0.38d? | 2007-05-30 09:00 | 2007-05-30 12:00 |  | 0.29d |  |  | 3h |
| 52 | 1.4.6.6.1 | Homologacion de estilos CSS | 0.12d? | 2007-05-30 09:00 | 2007-05-30 10:00 | 50 | 0.29d | 0d | DI | 1h |
| 53 | 1.4.6.6.2 | Homologacion de Contenidos Estaticos | 0.12d? | 2007-05-30 10:00 | 2007-05-30 11:00 | 52 | 0.29d | 0d | DI | 1h |
| 54 | 1.4.6.6.3 | Homologacion de Contenidos Dinamicos | 0.12d? | 2007-05-30 11:00 | 2007-05-30 12:00 | 53 | 0.29d | 0d | DI | 1h |

| ID | WBS | Task | Type | Duration | Start | Finish | Predecessors | Total slack | Free slack | Constraint | Resources | Work |
| --- | --- | --- | --- | --- | --- | --- | --- | --- | --- | --- | --- | --- |
| 55 | 1.4.6.7 | **Módulos y Aplicaciones** |  | 11d? | 2007-05-30 12:00 | 2007-06-14 12:00 |  | 0.29d |  |  |  | 88h |
| 56 | 1.4.6.7.1 | Banners en el Home |  | 1d? | 2007-05-30 12:00 | 2007-05-31 12:00 | 54 | 0.29d | 0d |  | DE | 8h |
| 57 | 1.4.6.7.2 | Buscador |  | 1d? | 2007-05-31 12:00 | 2007-06-01 12:00 | 56 | 0.29d | 0d |  | DE | 8h |
| 58 | 1.4.6.7.3 | Productos |  | 4d? | 2007-06-01 12:00 | 2007-06-07 12:00 | 57 | 0.29d | 0d |  | DE | 32h |
| 59 | 1.4.6.7.4 | Promociones |  | 3d? | 2007-06-07 12:00 | 2007-06-12 12:00 | 58 | 0.29d | 0d |  | DE | 24h |
| 60 | 1.4.6.7.5 | Contactos |  | 1d? | 2007-06-12 12:00 | 2007-06-13 12:00 | 59 | 0.29d | 0d |  | DE | 8h |
| 61 | 1.4.6.7.6 | Pruebas y Ajustes |  | 1d? | 2007-06-13 12:00 | 2007-06-14 12:00 | 60 | 0.29d | 0d |  | DE | 8h |
| 62 | 1.4.6.8 | Solucion Desarrollada y Entrega al Cliente |  | 1d? | 2007-06-14 12:00 | 2007-06-15 12:00 | 61 | 5.25d |  |  |  |  |
| 63 | 1.5 | **Plan de Pruebas** |  | 0.5d? | 2007-06-14 12:00 | 2007-06-14 18:00 |  | 0.29d |  |  |  | 4h |
| 64 | 1.5.1 | Elaboración Plan de Pruebas |  | 0.5d? | 2007-06-14 12:00 | 2007-06-14 18:00 | 61 | 0.29d | 0d |  | GP | 4h |
| 65 | 1.6 | Plan de Pruebas elaborado |  | 1d? | 2007-06-14 18:00 | 2007-06-15 18:00 | 64 | 0.29d | 0d |  |  |  |
| 66 | 1.7 | Adiestramiento |  | 1.5d? | 2007-06-15 18:00 | 2007-06-19 12:00 | 65 | 0.29d | 0d |  | GP | 12h |
| 67 | 1.8 | **Pruebas de Certificación** |  | 0.62d? | 2007-06-19 12:00 | 2007-06-19 19:00 |  | 0.29d |  |  |  | 5h |
| 68 | 1.8.1 | Preparación para las pruebas en ambiente de desarrollo |  | 0.12d? | 2007-06-19 12:00 | 2007-06-19 13:00 | 66 | 0.29d | 0d |  | GP | 1h |
| 69 | 1.8.2 | Realización de Pruebas de Funcionalidad (Cliente) | milestone | 0d? | 2007-06-19 13:00 | 2007-06-19 13:00 | 68 | 0.29d | 0d |  | Cl |  |
| 70 | 1.8.3 | Realización de Ajustes recomendados |  | 0.5d? | 2007-06-19 15:00 | 2007-06-19 19:00 | 69 | 0.29d | 0d |  | DE | 4h |
| 71 | 1.9 | Pruebas Certificadas |  | 1d? | 2007-06-20 09:00 | 2007-06-20 19:00 | 70 | 0.29d | 0d |  |  |  |
| 72 | 1.10 | **Puesta en Producción** |  | 1.33d? | 2007-06-21 09:00 | 2007-06-22 11:40 |  | 0.29d |  |  |  | 16h |
| 73 | 1.10.1 | Migración de aplicaciones |  | 1d? | 2007-06-21 09:00 | 2007-06-21 19:00 | 71 | 0.29d | 0d |  | OP | 8h |
| 74 | 1.10.2 | Pruebas integrales |  | 0.33d? | 2007-06-22 09:00 | 2007-06-22 11:40 | 73 | 0.29d |  |  | OP; GP; DE | 8h |
| 75 | 1.11 | **Gerencia de Proyecto** |  | 34.62d? | 2007-05-07 09:00 | 2007-06-22 16:00 |  | 0d |  |  |  | 18h |
| 76 | 1.11.1 | Planificación |  | 34.62d? | 2007-05-07 09:00 | 2007-06-22 16:00 |  | 0d |  | start no earlier than 2007-05-07 08:00 | GP [2.2%] | 6h |
| 77 | 1.11.2 | Control y Seguimiento |  | 34.62d? | 2007-05-07 09:00 | 2007-06-22 16:00 |  | 0d |  | start no earlier than 2007-05-07 08:00 | GP [4.3%] | 12h |
| 78 | 1.12 | Cierre |  | 34.62d? | 2007-05-07 09:00 | 2007-06-22 16:00 |  | 0d |  | start no earlier than 2007-05-07 08:00 | GP [0.4%]; Cl [0.4%] | 2h |
