# Proyecto CRM - Corporacion Union

Schedule from MS Project, 2007-08-23 to 2008-01-04.

## Calendars

- Estándar: Mon-Fri 08:00-12:00, 13:00-17:00; Sat-Sun off. Exceptions (off unless hours are given): 2007-10-12, 2007-12-24.

## Resources

| Resource |
| --- |
| R1 |
| Gerente |
| Usuario |
| Rvelasquez |
| Operaciones |
| Consultor |
| R2 |

## Schedule

| ID | WBS | Task | Type | Duration | Start | Finish | Predecessors | Total slack | Free slack | Constraint | Resources | Work |
| --- | --- | --- | --- | --- | --- | --- | --- | --- | --- | --- | --- | --- |
| 1 | 1 | **Conversión Monetaria Génesis** |  | 94.28d | 2007-08-23 | 2008-01-04 |  | 0d |  |  |  | 332h |
| 2 | 1.1 | **Inicio** |  | 0.38d | 2007-08-23 | 2007-08-23 |  | 2.03d |  |  |  | 3h |
| 3 | 1.1.1 | Reunión de Arranque (Kickoff) |  | 0.38d | 2007-08-23 | 2007-08-23 |  | 2.41d | 0d | start no earlier than 2007-08-23 | Gerente | 3h |
| 4 | 1.2 | **Especificación de Requerimientos** |  | 7d | 2007-08-23 | 2007-09-03 |  | 76.34d | 0d |  |  | 12h |
| 5 | 1.2.1 | Elaboración del Informe Esp. de Req. |  | 4d | 2007-08-23 | 2007-08-29 | 3 | 33.47d | 0d |  | Gerente [25%] | 8h |
| 6 | 1.2.2 | Revisión por parte del Equipo de Proyecto |  | 0.5d | 2007-08-29 | 2007-08-29 | 5 | 33.47d | 0d |  | Gerente [50%] | 2h |
| 7 | 1.2.3 | Ajustes al Informe Especificación de Requerimientos |  | 0.5d | 2007-08-29 | 2007-08-30 | 6 | 33.47d | 0d |  | Gerente [50%] | 2h |
| 8 | 1.2.4 | Entrega de Especificación de Requerimientos para aprobación | milestone | 0d | 2007-08-30 | 2007-08-30 | 7 | 33.47d | 0d |  |  |  |
| 9 | 1.2.5 | Revisión por parte del Cliente |  | 2d | 2007-08-30 | 2007-09-03 | 8 | 33.47d | 0d |  |  |  |
| 10 | 1.2.6 | Aprobación del Informe Especificación de Requerimientos | milestone | 0d | 2007-09-03 | 2007-09-03 | 9 | 33.47d | 0d |  |  |  |
| 11 | 1.3 | Informe Especificación de Requerimientos Aprobado | milestone | 0d | 2007-09-03 | 2007-09-03 | 10 | 91d |  |  |  |  |
| 12 | 1.4 | **Configuración y Desarrollo** |  | 74.97d | 2007-09-03 | 2007-12-18 |  | 11.94d |  |  |  | 135h |
| 13 | 1.4.1 | **Fase 1 - 1ro Octubre** |  | 10.57d | 2007-09-03 | 2007-09-17 |  | 76.34d |  |  |  | 32h |
| 14 | 1.4.1.1 | Impreso Total Cotiz, Reserv en pantalla e email |  | 4d | 2007-09-03 | 2007-09-07 | 4 | 43.44d |  |  | R1 [25%] | 8h |
| 15 | 1.4.1.2 | Impresión Total en BsF Reporte Siniestro |  | 1d | 2007-09-03 | 2007-09-04 | 4 | 76.43d | 0d |  | R1 [25%] | 2h |
| 16 | 1.4.1.3 | Pruebas Internas y Ajustes |  | 3.64d | 2007-09-04 | 2007-09-10 | 15 | 76.34d | 0d |  | R1 [25%]; R2 [25%] | 8h |
| 17 | 1.4.1.4 | **Pruebas de Certificación** |  | 5.2d | 2007-09-10 | 2007-09-17 |  | 76.34d | 0d |  |  | 8h |
| 18 | 1.4.1.4.1 | Pruebas del Cliente |  | 2d | 2007-09-10 | 2007-09-12 | 16 | 76.34d | 0d |  |  |  |
| 19 | 1.4.1.4.2 | Ajustes |  | 3.2d | 2007-09-12 | 2007-09-17 | 18 | 76.34d | 0d |  | R1 [25%]; R2 [25%] | 8h |
| 20 | 1.4.1.4.3 | Certificación por parte del Cliente | milestone | 0d | 2007-09-17 | 2007-09-17 | 19 | 76.34d |  |  |  |  |
| 21 | 1.4.1.5 | Pase a producción |  | 0.73d | 2007-09-17 | 2007-09-17 | 17 | 76.34d | 0d |  | R1 [50%]; Operaciones | 6h |
| 22 | 1.4.1.6 | Sistema con Conversión Monetaria Req. 01/10 | milestone | 0d | 2007-09-17 | 2007-09-17 | 21 | 76.34d |  |  |  |  |
| 23 | 1.4.2 | **Fase 2 - Enero 2007** |  | 50.34d | 2007-10-08 | 2007-12-18 |  | 11.39d |  |  |  | 103h |
| 24 | 1.4.2.1 | Modificación de Impresión-Devolver cambios |  | 8d | 2007-10-08 | 2007-10-18 |  | 11.39d | 0d | start no earlier than 2007-10-08 | R1 [25%]; R2 [25%] | 20h |
| 25 | 1.4.2.2 | Pruebas Internas y Ajustes |  | 3.2d | 2007-10-19 | 2007-10-24 | 24 | 11.39d | 0d |  | R1 [25%]; R2 [25%] | 8h |
| 26 | 1.4.2.3 | Preparación de scripts para cambiar valores a BsF |  | 20d | 2007-10-24 | 2007-11-21 | 25 | 11.39d | 0d |  | R1 [25%] | 40h |
| 27 | 1.4.2.4 | Scripts para limpieza de datos que quedarán en Producción |  | 2.5d | 2007-11-21 | 2007-11-23 | 26 | 11.39d | 0d |  | R2 [25%] | 5h |
| 28 | 1.4.2.5 | Prueba y ajustes de los scripts |  | 4.44d | 2007-11-23 | 2007-11-30 | 27 | 11.39d | 0d |  | R1 [25%]; Gerente [10%]; R2 [25%] | 12h |

| ID | WBS | Task | Type | Duration | Start | Finish | Predecessors | Total slack | Free slack | Constraint | Resources | Work |
| --- | --- | --- | --- | --- | --- | --- | --- | --- | --- | --- | --- | --- |
| 29 | 1.4.2.6 | **Pruebas de Certificación** |  | 9d | 2007-11-30 | 2007-12-13 |  | 11.39d | 0d |  |  | 10h |
| 30 | 1.4.2.6.1 | Pruebas del Cliente |  | 5d | 2007-11-30 | 2007-12-07 | 28 | 11.39d | 0d |  |  |  |
| 31 | 1.4.2.6.2 | Ajustes |  | 4d | 2007-12-07 | 2007-12-13 | 30 | 11.39d |  |  | R1 [25%]; R2 [25%] | 10h |
| 32 | 1.4.2.7 | **Documentación** |  | 3.2d | 2007-12-13 | 2007-12-18 |  | 11.94d |  |  |  | 8h |
| 33 | 1.4.2.7.1 | Instructivo para Implantación en Producción |  | 3.2d | 2007-12-13 | 2007-12-18 | 29 | 11.94d |  |  | R1 [25%]; R2 [25%] | 8h |
| 34 | 1.5 | **Replicación Génesis** |  | 33.89d | 2007-11-01 | 2007-12-18 |  | 11.39d |  |  |  | 36h |
| 35 | 1.5.1 | Definición de perfiles |  | 2d | 2007-11-01 | 2007-11-02 |  | 34.68d |  | start no earlier than 2007-11-01 |  |  |
| 36 | 1.5.2 | Replicación de Génesis a ambiente prod |  | 3.75d | 2007-12-13 | 2007-12-18 | 29 | 11.39d |  |  | Rvelasquez; R1 [20%]; Operaciones [50%] | 12h |
| 37 | 1.5.3 | Ajuste Usuarios y Perfiles |  | 1.6d | 2007-11-05 | 2007-11-06 | 35 | 34.68d | 0d |  | Gerente [25%]; R2 | 16h |
| 38 | 1.5.4 | Prueba de Perfiles |  | 3d | 2007-11-06 | 2007-11-09 | 37 | 34.68d | 0d |  |  |  |
| 39 | 1.5.5 | Ajustes perfiles |  | 1d | 2007-11-09 | 2007-11-12 | 38 | 34.68d | 0d |  | R2 | 8h |
| 40 | 1.5.6 | Certificación Réplica |  | 2d | 2007-11-12 | 2007-11-14 | 39 | 34.68d | 0d |  |  |  |
| 41 | 1.5.7 | Réplica Sistema en producción |  | 1d | 2007-11-14 | 2007-11-15 | 40 | 34.68d |  |  |  |  |
| 42 | 1.6 | **Puesta Producción 31/12** |  | 1d | 2007-12-31 | 2007-12-31 |  | 0d |  |  |  | 16h |
| 43 | 1.6.1 | Actualización BD en réplica | milestone | 0d | 2007-12-31 | 2007-12-31 |  | 6.91d | 0d | start no earlier than 2007-12-31 | Rvelasquez |  |
| 44 | 1.6.2 | Implantación Impresiones en Producción | milestone | 0d | 2007-12-31 | 2007-12-31 | 43 | 6.91d | 0d |  | Rvelasquez |  |
| 45 | 1.6.3 | Ejecución scripts | milestone | 0d | 2007-12-31 | 2007-12-31 | 44 | 6.91d | 0d |  | Rvelasquez |  |
| 46 | 1.6.4 | Revisión de muestra para comprobar correctitud | milestone | 0d | 2007-12-31 | 2007-12-31 | 45 | 6.91d |  |  | Rvelasquez |  |
| 47 | 1.6.5 | Guardia de Recurso de GWT |  | 1d | 2007-12-31 | 2007-12-31 |  | 0d |  | start no earlier than 2007-12-31 | R2 [200%] | 16h |
| 48 | 1.6.6 | Sistema en Producción | milestone | 0d | 2007-12-31 | 2007-12-31 | 47 | 0d |  |  |  |  |
| 49 | 1.7 | Soporte Post implantación |  | 3.28d | 2008-01-01 | 2008-01-04 | 42 | 0d |  |  | R1; Gerente [10%]; Consultor [30%] | 14h |
| 50 | 1.8 | Consultoría |  | 3.75d | 2007-09-03 | 2007-09-07 | 4 | 87.25d |  |  | Consultor | 30h |
| 51 | 1.9 | **Cierre** |  | 0.38d | 2008-01-02 | 2008-01-02 |  | 1.91d |  |  |  | 3h |
| 52 | 1.9.1 | Preparación presentación de Cierre y Acta de Cierre |  | 0.12d | 2008-01-02 | 2008-01-02 |  | 1.91d | 0d | start no earlier than 2008-01-02 | Gerente | 1h |
| 53 | 1.9.2 | Reunión Cierre de Proyecto |  | 0.25d | 2008-01-02 | 2008-01-02 | 52 | 1.91d |  |  | Gerente | 2h |

| ID | WBS | Task | Duration | Start | Finish | Predecessors | Total slack | Resources | Work |
| --- | --- | --- | --- | --- | --- | --- | --- | --- | --- |
| 54 | 1.10 | **Gerencia de Proyecto** | 91.88d | 2007-08-23 | 2008-01-02 |  | 2.03d |  | 83h |
| 55 | 1.10.1 | Planificación | 2.22d | 2007-09-03 | 2007-09-05 | 4 | 88.78d | Gerente [45%] | 8h |
| 56 | 1.10.2 | Control y Seguimiento | 91.88d | 2007-08-23 | 2008-01-02 | 3 | 2.41d | Gerente [10.2%] | 75h |
