# Seventec Propuesta

Schedule from MS Project, 2007-10-15 to 2007-11-20, costs in Bs.
GlobalWebTek

## Calendars

- Standard: Mon-Fri 08:00-12:00, 13:00-17:00; Sat-Sun off.

## Resources

| Resource | Rate |
| --- | --- |
| MR | 15000 |
| EC | 6250 |
| DS | 6250 |
| LR |  |
| AL | 15000 |
| GP |  |
| OP |  |

## Schedule

| ID | WBS | Task | Duration | Start | Finish | Predecessors | Total slack | Free slack | Constraint | Resources | Work | Cost |
| --- | --- | --- | --- | --- | --- | --- | --- | --- | --- | --- | --- | --- |
| 1 | 1 | **Control de Servicios de Infraestructura** | 26.93d? | 2007-10-15 08:00 | 2007-11-20 16:24 |  | 0d |  |  |  | 215h | 693,750 |
| 2 | 1.1 | **Inicio** | 0.12d | 2007-10-15 08:00 | 2007-10-15 09:00 |  | 8.75d |  |  |  | 1h |  |
| 3 | 1.1.1 | Reunión de Kickoff | 1h | 2007-10-15 08:00 | 2007-10-15 09:00 |  | 8.75d | 0d | start no earlier than 2007-10-15 08:00 | GP | 1h |  |
| 4 | 1.2 | **FASE I** | 26.8d? | 2007-10-15 09:00 | 2007-11-20 16:24 |  | 0d |  |  |  | 190h | 693,750 |
| 5 | 1.2.1 | **Levantamiento de Información** | 2.12d | 2007-10-16 08:00 | 2007-10-18 09:00 |  | 0d |  |  |  | 2h |  |
| 6 | 1.2.1.1 | Sesión de Trabajo 1 | 1h | 2007-10-16 08:00 | 2007-10-16 09:00 |  | 2d |  | start no earlier than 2007-10-16 08:00 | GP | 1h |  |
| 7 | 1.2.1.2 | Sesión de Trabajo 2 | 1h | 2007-10-18 08:00 | 2007-10-18 09:00 |  | 0d |  | start no earlier than 2007-10-18 08:00 | GP | 1h |  |
| 8 | 1.2.2 | **Requerimientos, Análisis y Diseño** | 9.25d | 2007-10-15 09:00 | 2007-10-26 11:00 |  | 0d |  |  |  | 38h |  |
| 9 | 1.2.2.1 | Creación de Aplicación en N2C Desarrollo | 4h | 2007-10-15 09:00 | 2007-10-15 14:00 | 3 | 8.75d |  | start no earlier than 2006-10-31 08:00 | OP | 4h |  |
| 10 | 1.2.2.2 | Documento de Especificación de Requerimientos | 2d | 2007-10-18 09:00 | 2007-10-22 09:00 | 5 | 0d |  | finish no earlier than 2006-11-03 17:00 | GP | 16h |  |
| 11 | 1.2.2.3 | Revisión por parte del Cliente | 2d | 2007-10-22 09:00 | 2007-10-24 09:00 | 10 | 0d |  |  |  |  |  |
| 12 | 1.2.2.4 | Ajustes Documento de Especificaciones | 2h | 2007-10-24 09:00 | 2007-10-24 11:00 | 11 | 0d |  | start no earlier than 2006-11-10 08:00 | GP | 2h |  |
| 13 | 1.2.2.5 | Análisis y Diseño | 2d | 2007-10-24 11:00 | 2007-10-26 11:00 | 12 | 0d |  |  | GP | 16h |  |
| 14 | 1.2.3 | **Desarrollo** | 17.25d? | 2007-10-26 11:00 | 2007-11-20 14:00 |  | 0d |  |  |  | 138h | 693,750 |
| 15 | 1.2.3.1 | Modelo de Datos | 0.75d? | 2007-10-26 11:00 | 2007-10-29 09:00 | 8 | 0d |  |  | DS; GP [50%] | 6h | 18,750 |
| 16 | 1.2.3.2 | **Construcción Funcionalidades** | 16.5d? | 2007-10-29 09:00 | 2007-11-20 14:00 |  | 0d |  |  |  | 132h | 675,000 |
| 17 | 1.2.3.2.1 | **Usuarios/Perfiles** | 0.75d? | 2007-10-29 09:00 | 2007-10-29 16:00 |  | 0d |  |  |  | 6h | 37,500 |
| 18 | 1.2.3.2.1.1 | Definición y Creación de Perfiles | 0.5d? | 2007-10-29 09:00 | 2007-10-29 14:00 | 15 | 0d |  |  | DS | 4h | 25,000 |
| 19 | 1.2.3.2.1.2 | Asociación de Tienda a Usuario | 0.25d? | 2007-10-29 14:00 | 2007-10-29 16:00 | 18 | 0d |  |  | DS | 2h | 12,500 |
| 20 | 1.2.3.2.2 | **Clientes** | 1d? | 2007-10-29 16:00 | 2007-10-30 16:00 |  | 0d |  |  |  | 8h |  |
| 21 | 1.2.3.2.2.1 | Registro | 1d? | 2007-10-29 16:00 | 2007-10-30 16:00 | 17 | 0d |  |  |  | 8h |  |
| 22 | 1.2.3.2.3 | **Servicios** | 6d? | 2007-10-30 16:00 | 2007-11-07 16:00 |  | 0d |  |  |  | 48h | 300,000 |
| 23 | 1.2.3.2.3.1 | Registro/Actualización | 0.5d | 2007-10-30 16:00 | 2007-10-31 11:00 | 20 | 0d |  |  | DS | 4h | 25,000 |
| 24 | 1.2.3.2.3.2 | Impreso de Orden de Servicio | 2d? | 2007-10-31 11:00 | 2007-11-02 11:00 | 23 | 0d |  |  | DS | 16h | 100,000 |
| 25 | 1.2.3.2.3.3 | Manejo de Status | 0.5d? | 2007-11-02 11:00 | 2007-11-02 16:00 | 24 | 0d |  |  | DS | 4h | 25,000 |
| 26 | 1.2.3.2.3.4 | Reporte Técnico | 1d? | 2007-11-02 16:00 | 2007-11-05 16:00 | 25 | 0d |  |  | DS | 8h | 50,000 |
| 27 | 1.2.3.2.3.5 | Impreso de Garantía | 1d? | 2007-11-05 16:00 | 2007-11-06 16:00 | 26 | 0d |  |  | DS | 8h | 50,000 |
| 28 | 1.2.3.2.3.6 | Registro de Costos | 0.5d? | 2007-11-06 16:00 | 2007-11-07 11:00 | 27 | 0d |  |  | DS | 4h | 25,000 |
| 29 | 1.2.3.2.3.7 | Email con Cotización a Cliente | 0.5d? | 2007-11-07 11:00 | 2007-11-07 16:00 | 28 | 0d |  |  | DS | 4h | 25,000 |

| ID | WBS | Task | Duration | Start | Finish | Predecessors | Total slack | Constraint | Resources | Work | Cost |
| --- | --- | --- | --- | --- | --- | --- | --- | --- | --- | --- | --- |
| 30 | 1.2.3.2.4 | **Traslado de Equipos** | 3d? | 2007-11-07 16:00 | 2007-11-12 16:00 |  | 0d |  |  | 24h | 150,000 |
| 31 | 1.2.3.2.4.1 | Registro de Traslado | 0.5d? | 2007-11-07 16:00 | 2007-11-08 11:00 | 22 | 0d |  | DS | 4h | 25,000 |
| 32 | 1.2.3.2.4.2 | Impreso de Traslado | 1d? | 2007-11-08 11:00 | 2007-11-09 11:00 | 31 | 0d |  | DS | 8h | 50,000 |
| 33 | 1.2.3.2.4.3 | Tracking de Traslado | 1d? | 2007-11-09 11:00 | 2007-11-12 11:00 | 32 | 0d |  | DS | 8h | 50,000 |
| 34 | 1.2.3.2.4.4 | Cierre de Traslado | 0.5d? | 2007-11-12 11:00 | 2007-11-12 16:00 | 33 | 0d |  | DS | 4h | 25,000 |
| 35 | 1.2.3.2.5 | **Consultas** | 2.25d? | 2007-11-12 16:00 | 2007-11-15 09:00 |  | 0d |  |  | 18h | 112,500 |
| 36 | 1.2.3.2.5.1 | Clientes | 0.25d? | 2007-11-12 16:00 | 2007-11-13 09:00 | 30 | 0d |  | DS | 2h | 12,500 |
| 37 | 1.2.3.2.5.2 | Servicios | 1d? | 2007-11-13 09:00 | 2007-11-14 09:00 | 36 | 0d |  | DS | 8h | 50,000 |
| 38 | 1.2.3.2.5.3 | Traslados | 1d? | 2007-11-14 09:00 | 2007-11-15 09:00 | 37 | 0d |  | DS | 8h | 50,000 |
| 39 | 1.2.3.2.6 | Pruebas Internas y Ajustes | 1.5d | 2007-11-15 09:00 | 2007-11-16 14:00 | 35 | 0d |  | DS | 12h | 75,000 |
| 40 | 1.2.3.2.7 | Guías de Usuario | 2d | 2007-11-16 14:00 | 2007-11-20 14:00 | 39 | 0.3d |  | GP | 16h |  |
| 41 | 1.2.4 | Pruebas de Certificación | 0.5d | 2007-11-16 14:00 | 2007-11-19 09:00 | 39 | 0d |  | GP | 4h |  |
| 42 | 1.2.5 | **Puesta en Marcha** | 1.8d | 2007-11-19 09:00 | 2007-11-20 16:24 |  | 0d |  |  | 8h |  |
| 43 | 1.2.5.1 | Adiestramiento | 4h | 2007-11-19 09:00 | 2007-11-19 15:00 | 41 | 0d | start no earlier than 2007-02-01 08:00 | GP | 4h |  |
| 44 | 1.2.5.2 | Implantación Fase I | 0.5d | 2007-11-19 15:00 | 2007-11-20 16:24 | 43 | 0d |  | OP | 4h |  |
| 45 | 1.3 | **Gerencia de Proyecto** | 16.67d | 2007-10-26 11:00 | 2007-11-20 08:20 |  | 0.88d |  |  | 24h |  |
| 46 | 1.3.1 | Planificación | 0.5d | 2007-10-26 11:00 | 2007-10-26 16:00 | 8 | 17.05d |  | GP | 4h |  |
| 47 | 1.3.2 | Control y Seguimiento | 16.67d | 2007-10-26 11:00 | 2007-11-20 08:20 | 8 | 0.88d | start no earlier than 2006-10-18 08:00 | GP [15%] | 20h |  |
