# Cronograma CANTV

Schedule from MS Project, 2008-04-01 to 2009-05-15, costs in $.
GlobalWebTek

## Calendars

- Standard: Mon-Fri 08:00-12:00, 13:00-17:00; Sat-Sun off.

## Resources

| Resource | Rate |
| --- | --- |
| Programador |  |
| Analista | 70 |
| Lider Tecnico | 80 |
| Gerente de Proyecto | 100 |
| Disenador Grafico | 80 |
| Consultor de Infraestructura | 100 |
| Consultor de Proceso | 100 |
| Configurador Ambiente 1 | 80 |
| Transcriptor | 40 |
| Especialista de Calidad | 80 |
| Configurador Ambiente 2 | 80 |

## Schedule

| ID | WBS | Task | Type | Duration | Start | Finish | Predecessors | Total slack | Free slack | Resources | Work | Cost |
| --- | --- | --- | --- | --- | --- | --- | --- | --- | --- | --- | --- | --- |
| 1 | 1 | **Sistema SACAS** |  | 294d | 2008-04-01 | 2009-05-15 |  | 0d |  |  | 32689.5h | 2,466,610 |
| 2 | 1.1 | **Inicio** |  | 1d | 2008-04-01 | 2008-04-01 |  | 0d |  |  | 16h | 1,440 |
| 3 | 1.1.1 | Reunión de Arranque (Kickoff) |  | 1d | 2008-04-01 | 2008-04-01 |  | 0d |  | Gerente de Proyecto; Lider Tecnico | 16h | 1,440 |
| 4 | 1.2 | **Analisis Funcional y Diseno General** |  | 91d | 2008-04-02 | 2008-08-06 |  | 0d |  |  | 4446.24h | 360,996.97 |
| 5 | 1.2.1 | **Levantamiento de Información** |  | 59d | 2008-04-02 | 2008-06-23 |  | 0d |  |  | 1538.67h | 126,746.67 |
| 6 | 1.2.1.1 | Reuniones de Trabajo con personal de CANTV (2 por dia) |  | 20d | 2008-04-02 | 2008-04-29 | 3 | 0d |  | Lider Tecnico; Gerente de Proyecto; Analista [200%] | 640h | 51,200 |
| 7 | 1.2.1.2 | Revision del Sistema Actual |  | 10d | 2008-04-02 | 2008-04-15 | 3 | 283d |  | Lider Tecnico; Analista [200%]; Gerente de Proyecto | 213.33h | 18,133.33 |
| 8 | 1.2.1.3 | Analisis e Integracion de Informacion |  | 10d | 2008-04-23 | 2008-05-06 | 6FS-5d | 0d |  | Gerente de Proyecto; Lider Tecnico; Analista [400%] | 240h | 20,000 |
| 9 | 1.2.1.4 | Elaboración del Informe Esp. de Req. y Matriz de Req. |  | 5d | 2008-05-02 | 2008-05-08 | 8FS-3d | 0d |  | Gerente de Proyecto; Lider Tecnico; Analista [400%] | 120h | 10,000 |
| 10 | 1.2.1.5 | Presentacion a CANTV |  | 1d | 2008-05-09 | 2008-05-09 | 9 | 0d |  | Lider Tecnico; Gerente de Proyecto | 16h | 1,440 |
| 11 | 1.2.1.6 | Revisión y aprobacion por parte de CANTV |  | 10d | 2008-05-12 | 2008-05-23 | 10 | 0d |  | Lider Tecnico [50%] | 40h | 3,200 |
| 12 | 1.2.1.7 | Ajustes al Informe Especificación de Requerimientos |  | 10d | 2008-05-26 | 2008-06-06 | 11 | 0d |  | Lider Tecnico; Gerente de Proyecto; Analista [200%] | 213.33h | 18,133.33 |
| 13 | 1.2.1.8 | Presentacion a CANTV |  | 1d | 2008-06-09 | 2008-06-09 | 12 | 0d |  | Gerente de Proyecto; Lider Tecnico | 16h | 1,440 |
| 14 | 1.2.1.9 | Revisión y aprobacion final de CANTV |  | 10d | 2008-06-10 | 2008-06-23 | 13 | 0d |  | Lider Tecnico [50%] | 40h | 3,200 |
| 15 | 1.2.1.10 | Informe Especificación de Requerimientos Aprobado | milestone | 0d | 2008-06-23 | 2008-06-23 | 14 | 0d |  |  |  |  |
| 16 | 1.2.2 | **Diseno** |  | 53d | 2008-05-26 | 2008-08-06 |  | 21d |  |  | 2907.58h | 234,250.3 |
| 17 | 1.2.2.1 | Modelo de Datos |  | 19d | 2008-05-26 | 2008-06-19 | 11 | 236d |  | Gerente de Proyecto; Lider Tecnico; Analista [200%] | 608h | 48,640 |
| 18 | 1.2.2.2 | Pantallas de Entrada y Salida |  | 20d | 2008-05-26 | 2008-06-20 | 11 | 230d | 0d | Gerente de Proyecto; Lider Tecnico; Analista [200%]; Disenador Grafico | 800h | 64,000 |
| 19 | 1.2.2.3 | Reportes |  | 10d | 2008-05-26 | 2008-06-06 | 11 | 245d |  | Gerente de Proyecto; Lider Tecnico; Analista [200%] | 320h | 25,600 |
| 20 | 1.2.2.4 | Estadisticas |  | 5d | 2008-05-26 | 2008-05-30 | 11 | 250d |  | Gerente de Proyecto; Lider Tecnico; Analista [200%] | 160h | 12,800 |
| 21 | 1.2.2.5 | Interfaces |  | 10d | 2008-05-26 | 2008-06-06 | 11 | 245d |  | Gerente de Proyecto; Lider Tecnico; Analista [200%]; Disenador Grafico | 400h | 32,000 |
| 22 | 1.2.2.6 | Control de Calidad |  | 5d | 2008-06-23 | 2008-06-27 | 18 | 230d |  | Gerente de Proyecto; Lider Tecnico; Analista [400%] | 120h | 10,000 |
| 23 | 1.2.2.7 | Elaboración del Informe detallado de Especificacion y Diseno |  | 5d | 2008-06-24 | 2008-06-30 | 15 | 229d |  | Gerente de Proyecto; Lider Tecnico; Analista [400%] | 133.33h | 10,933.33 |
| 24 | 1.2.2.8 | Elaboración del Plan de Pruebas |  | 5d | 2008-06-24 | 2008-06-30 | 15 | 0d |  | Gerente de Proyecto; Lider Tecnico; Analista [400%] | 133.33h | 10,933.33 |
| 25 | 1.2.2.9 | Presentacion a CANTV |  | 1d | 2008-07-01 | 2008-07-01 | 24 | 0d |  | Gerente de Proyecto; Lider Tecnico | 16h | 1,440 |
| 26 | 1.2.2.10 | Revisión y aprobacion por parte de CANTV |  | 10d | 2008-07-02 | 2008-07-15 | 25 | 0d |  | Lider Tecnico [50%] | 40h | 3,200 |
| 27 | 1.2.2.11 | Ajustes a los documentos de Diseno y Plan de Pruebas |  | 5d | 2008-07-16 | 2008-07-22 | 26 | 0d |  | Gerente de Proyecto; Lider Tecnico; Analista [400%] | 120.91h | 10,063.64 |
| 28 | 1.2.2.12 | Presentacion a CANTV |  | 1d | 2008-07-23 | 2008-07-23 | 27 | 0d |  | Gerente de Proyecto; Lider Tecnico | 16h | 1,440 |
| 29 | 1.2.2.13 | Revisión y aprobacion final de CANTV |  | 10d | 2008-07-24 | 2008-08-06 | 28 | 0d |  | Lider Tecnico [50%] | 40h | 3,200 |
| 30 | 1.2.2.14 | Documento detallado de Especificacion y Diseno | milestone | 0d | 2008-08-06 | 2008-08-06 | 29 | 0d |  |  |  |  |
| 31 | 1.2.2.15 | Documento Plan de Pruebas | milestone | 0d | 2008-08-06 | 2008-08-06 | 29 | 202d |  |  |  |  |

| ID | WBS | Task | Type | Duration | Start | Finish | Predecessors | Total slack | Free slack | Resources | Work | Cost |
| --- | --- | --- | --- | --- | --- | --- | --- | --- | --- | --- | --- | --- |
| 32 | 1.3 | **Desarrollo** |  | 119d | 2008-08-07 | 2009-01-20 |  | 0d |  |  | 13225.2h | 866,520.62 |
| 33 | 1.3.1 | Programas Online |  | 61d | 2008-08-07 | 2008-10-30 | 30 | 0d |  | Programador [1000%]; Lider Tecnico; Gerente de Proyecto; Especialista de Calidad | 4771.49h | 313,153.66 |
| 34 | 1.3.2 | Programas Batch |  | 24d | 2008-10-28 | 2008-11-28 | 30, 33FS-3d | 0d |  | Programador [1000%]; Lider Tecnico; Gerente de Proyecto; Especialista de Calidad | 2049.39h | 134,149.57 |
| 35 | 1.3.3 | Interfaces |  | 38d | 2008-11-26 | 2009-01-16 | 30, 34FS-3d | 85d |  | Programador [1000%]; Lider Tecnico; Gerente de Proyecto; Especialista de Calidad | 3244.87h | 212,403.48 |
| 36 | 1.3.4 | Docuentacion de Programas |  | 37d | 2008-12-01 | 2009-01-20 | 34 | 0d |  | Programador [1000%]; Lider Tecnico; Gerente de Proyecto; Especialista de Calidad | 3159.48h | 206,813.91 |
| 37 | 1.3.5 | Sistema Desarrollado por Modulos | milestone | 0d | 2009-01-20 | 2009-01-20 | 33, 34, 36 | 0d |  |  |  |  |
| 38 | 1.4 | **Pruebas en Fabrica de Funcionalidades** |  | 20d | 2009-01-21 | 2009-02-17 |  | 63d |  |  | 747.77h | 56,659.31 |
| 39 | 1.4.1 | Preparación para las pruebas en ambiente de desarrollo |  | 1d | 2009-01-21 | 2009-01-21 | 37 | 63d | 0d | Configurador Ambiente 1; Consultor de Infraestructura; Gerente de Proyecto; Lider Tecnico | 32h | 2,880 |
| 40 | 1.4.2 | Realización de Pruebas de Funcionalidad |  | 14d | 2009-01-22 | 2009-02-10 | 39 | 63d | 0d | Programador [200%]; Lider Tecnico; Gerente de Proyecto; Especialista de Calidad | 529.1h | 39,779.31 |
| 41 | 1.4.3 | Realización de Ajustes recomendados |  | 5d | 2009-02-11 | 2009-02-17 | 40 | 63d | 0d | Programador [200%]; Lider Tecnico; Gerente de Proyecto; Especialista de Calidad | 186.67h | 14,000 |
| 42 | 1.4.4 | Pruebas de Certificación aprobada | milestone | 0d | 2009-02-17 | 2009-02-17 | 41 | 63d |  |  |  |  |
| 43 | 1.5 | **Pruebas en Fabrica de Interfaces** |  | 20d | 2009-01-21 | 2009-02-17 |  | 0d |  |  | 893.33h | 65,200 |
| 44 | 1.5.1 | Preparación para las pruebas en ambiente de desarrollo |  | 1d | 2009-01-21 | 2009-01-21 | 37 | 0d |  | Consultor de Infraestructura; Configurador Ambiente 1; Gerente de Proyecto; Lider Tecnico | 32h | 2,880 |
| 45 | 1.5.2 | Realización de Pruebas de Funcionalidad |  | 14d | 2009-01-22 | 2009-02-10 | 44 | 0d |  | Programador [300%]; Lider Tecnico; Gerente de Proyecto; Especialista de Calidad | 634.67h | 45,920 |
| 46 | 1.5.3 | Realización de Ajustes recomendados |  | 5d | 2009-02-11 | 2009-02-17 | 45 | 0d |  | Programador [300%]; Lider Tecnico; Gerente de Proyecto; Especialista de Calidad | 226.67h | 16,400 |
| 47 | 1.5.4 | Pruebas de Certificación aprobada | milestone | 0d | 2009-02-17 | 2009-02-17 | 46 | 0d |  |  |  |  |
| 48 | 1.6 | **Instalacion (en ambiente de Desarrollo CANTV)** |  | 10d | 2009-02-18 | 2009-03-03 |  | 0d |  |  | 288.84h | 24,742.99 |
| 49 | 1.6.1 | Configuración Infraestructura Técnica |  | 5d | 2009-02-18 | 2009-02-24 | 47 | 0d |  | Configurador Ambiente 1; Consultor de Infraestructura; Gerente de Proyecto; Lider Tecnico; Configurador Ambiente 2 | 151.04h | 12,947.64 |
| 50 | 1.6.2 | Instalacion del Sistema en la plataforma de desarrollo de CANTV |  | 5d | 2009-02-25 | 2009-03-03 | 49 | 0d |  | Configurador Ambiente 1; Consultor de Infraestructura; Lider Tecnico; Gerente de Proyecto; Configurador Ambiente 2 | 137.81h | 11,795.35 |
| 51 | 1.6.3 | Sistema instalado en plataforma de desarrollo de CANTV | milestone | 0d | 2009-03-03 | 2009-03-03 | 50 | 0d |  |  |  |  |
| 52 | 1.7 | **Pruebas Integrales en Sitio** |  | 20d | 2009-03-04 | 2009-03-31 |  | 0d |  |  | 1097.14h | 81,302.86 |
| 53 | 1.7.1 | Preparación para las pruebas en ambiente de desarrollo |  | 1d | 2009-03-04 | 2009-03-04 | 51 | 0d |  | Consultor de Infraestructura; Configurador Ambiente 1; Lider Tecnico; Gerente de Proyecto | 32h | 2,880 |
| 54 | 1.7.2 | Realización de Pruebas |  | 14d | 2009-03-05 | 2009-03-24 | 53 | 0d |  | Gerente de Proyecto; Lider Tecnico; Especialista de Calidad [200%]; Programador [500%] | 728h | 54,880 |
| 55 | 1.7.3 | Realización de Ajustes recomendados |  | 5d | 2009-03-25 | 2009-03-31 | 54 | 0d |  | Programador [500%]; Lider Tecnico; Gerente de Proyecto; Especialista de Calidad [200%] | 337.14h | 23,542.86 |
| 56 | 1.7.4 | Pruebas de Certificación aprobada | milestone | 0d | 2009-03-31 | 2009-03-31 | 55 | 0d |  |  |  |  |

| ID | WBS | Task | Type | Duration | Start | Finish | Predecessors | Total slack | Free slack | Resources | Work | Cost |
| --- | --- | --- | --- | --- | --- | --- | --- | --- | --- | --- | --- | --- |
| 57 | 1.8 | **Pruebas de Volumen y de Stress** |  | 20d | 2009-04-01 | 2009-04-28 |  | 0d |  |  | 1313.14h | 92,342.86 |
| 58 | 1.8.1 | Preparación para las pruebas en ambiente de desarrollo |  | 1d | 2009-04-01 | 2009-04-01 | 56 | 0d |  | Configurador Ambiente 1; Consultor de Infraestructura; Lider Tecnico; Gerente de Proyecto | 32h | 2,880 |
| 59 | 1.8.2 | Realización de Pruebas |  | 14d | 2009-04-02 | 2009-04-21 | 58 | 0d |  | Programador [500%]; Lider Tecnico; Gerente de Proyecto; Especialista de Calidad [200%] | 944h | 65,920 |
| 60 | 1.8.3 | Realización de Ajustes recomendados |  | 5d | 2009-04-22 | 2009-04-28 | 59 | 0d |  | Programador [500%]; Lider Tecnico; Gerente de Proyecto; Especialista de Calidad [200%] | 337.14h | 23,542.86 |
| 61 | 1.8.4 | Pruebas de Certificación aprobada | milestone | 0d | 2009-04-28 | 2009-04-28 | 60 | 0d |  |  |  |  |
| 62 | 1.9 | **Pase a Produccion, incluyendo las licencias correspondientes** |  | 12d | 2009-04-29 | 2009-05-14 |  | 0d |  |  | 380.38h | 32,790.97 |
| 63 | 1.9.1 | Configuración Infraestructura Técnica |  | 5d | 2009-04-29 | 2009-05-05 | 61 | 0d |  | Configurador Ambiente 1; Consultor de Infraestructura; Lider Tecnico; Gerente de Proyecto; Configurador Ambiente 2 | 177.34h | 15,334.41 |
| 64 | 1.9.2 | Instalacion del Sistema en la plataforma de produccion de CANTV |  | 7d | 2009-05-06 | 2009-05-14 | 63 | 0d |  | Configurador Ambiente 1; Consultor de Infraestructura; Lider Tecnico; Gerente de Proyecto; Configurador Ambiente 2 | 203.03h | 17,456.55 |
| 65 | 1.9.3 | Sistema instalado en plataforma de produccion de CANTV | milestone | 0d | 2009-05-14 | 2009-05-14 | 64 | 1d |  |  |  |  |
| 66 | 1.10 | **Documentación** |  | 158d | 2008-08-07 | 2009-03-16 |  | 34d |  |  | 7625.44h | 622,053.43 |
| 67 | 1.10.1 | Preparacion de Manuales y Documentos |  | 158d | 2008-08-07 | 2009-03-16 | 30 | 34d | 0d | Gerente de Proyecto; Lider Tecnico; Programador [500%]; Analista [400%]; Especialista de Calidad; Consultor de Infraestructura | 7625.44h | 622,053.43 |
| 68 | 1.10.2 | Documento de Trabajo | milestone | 0d | 2009-03-16 | 2009-03-16 | 67 | 44d |  |  |  |  |
| 69 | 1.10.3 | Protocolo de Pruebas | milestone | 0d | 2009-03-16 | 2009-03-16 | 67 | 44d |  |  |  |  |
| 70 | 1.10.4 | Manual de Usuario | milestone | 0d | 2009-03-16 | 2009-03-16 | 67 | 34d | 11d |  |  |  |
| 71 | 1.10.5 | Manual de Sistema | milestone | 0d | 2009-03-16 | 2009-03-16 | 67 | 34d | 11d |  |  |  |
| 72 | 1.10.6 | Manual de Programas | milestone | 0d | 2009-03-16 | 2009-03-16 | 67 | 34d | 11d |  |  |  |
| 73 | 1.10.7 | Codigo Fuente Documentado | milestone | 0d | 2009-03-16 | 2009-03-16 | 67 | 34d | 11d |  |  |  |
| 74 | 1.10.8 | Contenido de curso de Entrenamiento de los diferentes perfiles | milestone | 0d | 2009-03-16 | 2009-03-16 | 67 | 34d | 11d |  |  |  |
| 75 | 1.11 | **Capacitacion** |  | 10d | 2009-04-01 | 2009-04-14 |  | 23d |  |  | 256h | 23,040 |
| 76 | 1.11.1 | Curso de Usuario del Sistema |  | 2d | 2009-04-01 | 2009-04-02 | 70, 74, 71, 55 | 31d |  | Gerente de Proyecto; Lider Tecnico | 32h | 2,880 |
| 77 | 1.11.2 | Curso de Administrador del Sistema |  | 4d | 2009-04-01 | 2009-04-06 | 70, 74, 71, 55 | 29d |  | Gerente de Proyecto; Lider Tecnico | 64h | 5,760 |
| 78 | 1.11.3 | Curso de Mantenimiento |  | 10d | 2009-04-01 | 2009-04-14 | 70, 74, 71, 72, 73, 55 | 23d |  | Gerente de Proyecto; Lider Tecnico | 160h | 14,400 |
| 79 | 1.12 | **Cierre** |  | 3d | 2009-05-13 | 2009-05-15 |  | 0d |  |  | 48h | 4,320 |
| 80 | 1.12.1 | Preparación Presentación Cierre de Proyecto |  | 2d | 2009-05-13 | 2009-05-14 | 64FS-2d | 0d |  | Gerente de Proyecto; Lider Tecnico | 32h | 2,880 |
| 81 | 1.12.2 | Reunión Cierre de Proyecto |  | 1d | 2009-05-15 | 2009-05-15 | 80 | 0d |  | Gerente de Proyecto; Lider Tecnico | 16h | 1,440 |

| ID | WBS | Task | Duration | Start | Finish | Total slack | Resources | Work | Cost |
| --- | --- | --- | --- | --- | --- | --- | --- | --- | --- |
| 82 | 1.13 | **Gerencia de Proyecto** | 294d | 2008-04-01 | 2009-05-15 | 0d |  | 2352h | 235,200 |
| 83 | 1.13.1 | Planificacion | 294d | 2008-04-01 | 2009-05-15 | 0d | Consultor de Proceso | 2352h | 235,200 |
