# Planning Cines Unidos 08-03-2007.

Schedule from MS Project, 2008-01-02 to 2008-06-06, costs in €.
Globalwebtek Venezuela C.A.

## Calendars

- Estándar: Mon-Fri 09:00-13:00, 15:00-19:00; Sat-Sun off.

## Resources

| Resource | Rate |
| --- | --- |
| Gerente de Proyecto |  |
| Lider Tecnico | 60 |
| Analista | 60 |
| Programador | 60 |
| Disenador Grafico | 60 |
| Configurador Ambiente | 60 |
| Gerente de Operaciones | 60 |
| Consultor de Proyecto | 60 |

## Schedule

| ID | WBS | Task | Type | Duration | Start | Finish | Predecessors | Total slack | Free slack | Constraint | Resources | Work | Cost |
| --- | --- | --- | --- | --- | --- | --- | --- | --- | --- | --- | --- | --- | --- |
| 1 | 1 | **Proyecto Solución CDI - ETAPA 1** |  | 113d | 2008-01-02 | 2008-06-06 |  | 0d |  |  |  | 2556h | 153,360 |
| 2 | 1.1 | Reunión de Arranque |  | 0.5d | 2008-01-02 | 2008-01-02 |  | 114.5d |  |  | Gerente de Proyecto | 4h | 240 |
| 3 | 1.2 | **Fase I - Levantamiento de Información** |  | 20d | 2008-01-02 | 2008-01-29 |  | 0d |  |  |  | 112h | 6,720 |
| 4 | 1.2.1 | **Modelo de Procesos y Datos** |  | 6d | 2008-01-02 | 2008-01-09 |  | 0d |  |  |  | 44h | 2,640 |
| 5 | 1.2.1.1 | Mesa de Trabajo # 1 |  | 2d | 2008-01-02 | 2008-01-03 |  | 0d |  |  | Lider Tecnico | 16h | 960 |
| 6 | 1.2.1.2 | Mesa de Trabajo # 2 |  | 2d | 2008-01-04 | 2008-01-07 | 5 | 0d |  |  | Lider Tecnico | 16h | 960 |
| 7 | 1.2.1.3 | Mesa de Trabajo # 3 |  | 2d | 2008-01-08 | 2008-01-09 | 6 | 0d |  |  | Lider Tecnico [75%] | 12h | 720 |
| 8 | 1.2.2 | **Infraestructura y Crecimiento Futuro** |  | 2.5d | 2008-01-10 | 2008-01-14 |  | 104.5d |  |  |  | 20h | 1,200 |
| 9 | 1.2.2.1 | Investigación de requerimientos de infraestructura |  | 2d | 2008-01-10 | 2008-01-11 | 7 | 104.5d | 0d |  | Lider Tecnico | 16h | 960 |
| 10 | 1.2.2.2 | Elaborar informe de recomendaciones |  | 0.5d | 2008-01-14 | 2008-01-14 | 9 | 104.5d |  |  | Lider Tecnico | 4h | 240 |
| 11 | 1.2.3 | **Informe de Especificación de Requerimientos** |  | 14d | 2008-01-10 | 2008-01-29 |  | 0d |  |  |  | 48h | 2,880 |
| 12 | 1.2.3.1 | Elaboración del Informe de Especificación de Requerimientos |  | 2d | 2008-01-10 | 2008-01-11 | 7 | 0d |  |  | Gerente de Proyecto [50%]; Lider Tecnico | 24h | 1,440 |
| 13 | 1.2.3.2 | Entrega al Equipo de Proyecto CDI para su revisión | milestone | 0d | 2008-01-11 | 2008-01-11 | 12 | 0d |  | start no earlier than 2006-12-01 |  |  |  |
| 14 | 1.2.3.3 | Revisión por parte del Equipo de Proyecto CDI | milestone | 0d | 2008-01-11 | 2008-01-11 | 13 | 107d |  |  |  |  |  |
| 15 | 1.2.3.4 | Ajustes al Informe Especificación de Requerimientos |  | 2d | 2008-01-28 | 2008-01-29 | 13FS+10d | 0d |  |  | Gerente de Proyecto [50%]; Lider Tecnico | 24h | 1,440 |
| 16 | 1.2.3.5 | Entrega de Especificación de Req. para aprobación | milestone | 0d | 2008-01-29 | 2008-01-29 | 15 | 0d |  | start no earlier than 2006-12-07 |  |  |  |
| 17 | 1.2.3.6 | Aprobación del Informe Especificación de Requerimientos | milestone | 0d | 2008-01-29 | 2008-01-29 | 16 | 0d |  | start no earlier than 2007-04-05 |  |  |  |
| 18 | 1.2.4 | Informe Especificación de Requerimientos Aprobado | milestone | 0d | 2008-01-29 | 2008-01-29 | 17 | 0d |  |  |  |  |  |
| 19 | 1.2.5 | Modelo de Procesos y Datos Definido | milestone | 0d | 2008-01-29 | 2008-01-29 | 17 | 95d |  |  |  |  |  |
| 20 | 1.2.6 | Informe Infraestructura y Crecimiento Futuro | milestone | 0d | 2008-01-29 | 2008-01-29 | 17 | 95d |  |  |  |  |  |
| 21 | 1.3 | **Fase II - Modulo CRM** |  | 80d | 2008-01-30 | 2008-05-20 |  | 0d |  |  |  | 2260h | 135,600 |
| 22 | 1.3.1 | Directorio de Relacionados |  | 20d | 2008-01-30 | 2008-02-26 | 18 | 0d |  |  | Lider Tecnico [45.8%]; Programador [183.3%] | 220h | 13,200 |
| 23 | 1.3.2 | CRM |  | 20d | 2008-02-27 | 2008-03-25 | 22 | 55d |  |  | Lider Tecnico [50%]; Programador [200%] | 400h | 24,000 |
| 24 | 1.3.3 | Reportes de Relacionados |  | 12d | 2008-02-27 | 2008-03-13 | 22 | 63d |  |  | Lider Tecnico [50%]; Programador [200%] | 240h | 14,400 |
| 25 | 1.3.4 | Extranet con Aliados |  | 20d | 2008-02-27 | 2008-03-25 | 22 | 55d |  |  | Lider Tecnico [50%]; Programador [200%] | 400h | 24,000 |
| 26 | 1.3.5 | Integracion con Modulo de Gestion Documental |  | 60d | 2008-02-27 | 2008-05-20 | 22 | 0d |  |  | Lider Tecnico [48.6%]; Programador [194.4%] | 700h | 42,000 |
| 27 | 1.3.6 | Integracion con Aplicaciones de Gestion CDI |  | 25d | 2008-02-27 | 2008-04-01 | 22 | 50d |  |  | Lider Tecnico [50%]; Programador [200%] | 300h | 18,000 |

| ID | WBS | Task | Type | Duration | Start | Finish | Predecessors | Total slack | Resources | Work | Cost |
| --- | --- | --- | --- | --- | --- | --- | --- | --- | --- | --- | --- |
| 28 | 1.4 | **Fase III - Implantación** |  | 13d | 2008-05-21 | 2008-06-06 |  | 0d |  | 180h | 10,800 |
| 29 | 1.4.1 | Pruebas internas |  | 5d | 2008-05-21 | 2008-05-27 | 26, 23 | 0d | Configurador Ambiente [50%]; Programador [200%] | 100h | 6,000 |
| 30 | 1.4.2 | Documentación |  | 3d | 2008-05-28 | 2008-05-30 | 29 | 0d | Gerente de Operaciones [50%]; Lider Tecnico | 36h | 2,160 |
| 31 | 1.4.3 | Adiestramiento |  | 2d | 2008-06-02 | 2008-06-03 | 30 | 0d | Gerente de Operaciones [6.8%]; Lider Tecnico [68.2%] | 12h | 720 |
| 32 | 1.4.4 | Pruebas de Certificación |  | 2d | 2008-06-04 | 2008-06-05 | 31 | 0d | Gerente de Operaciones [50%]; Lider Tecnico | 24h | 1,440 |
| 33 | 1.4.5 | Directorios de Relacionados implantado | milestone | 0d | 2008-06-05 | 2008-06-05 | 32 | 1d |  |  |  |
| 34 | 1.4.6 | CRM implantado | milestone | 0d | 2008-06-05 | 2008-06-05 | 32 | 1d |  |  |  |
| 35 | 1.4.7 | Reportes de Relacionados implantado | milestone | 0d | 2008-06-05 | 2008-06-05 | 32 | 0d |  |  |  |
| 36 | 1.4.8 | Cierre |  | 1d | 2008-06-06 | 2008-06-06 | 35 | 0d | Gerente de Proyecto | 8h | 480 |
| 37 | 1.5 | **Gerencia de Proyectos** |  | 0d | 2008-01-02 | 2008-01-02 |  | 115d |  |  |  |
| 38 | 1.5.1 | Gerencia de Proyectos | milestone | 0d | 2008-01-02 | 2008-01-02 |  | 115d |  |  |  |
