# Planning Cines Unidos 08-03-2007.

Schedule from MS Project, 2008-01-02 to 2008-07-24, costs in €.
Globalwebtek Venezuela C.A.

## Calendars

- Estándar: Mon-Fri 09:00-13:00, 15:00-19:00; Sat-Sun off.

## Resources

| Resource | Rate | Cost per use |
| --- | --- | --- |
| Gerente de Proyecto |  | 200 |
| Lider Tecnico | 60 |  |
| Analista | 60 |  |
| Programador | 60 |  |
| Disenador Grafico | 60 |  |
| Configurador Ambiente | 60 |  |
| Gerente de Operaciones | 60 |  |
| Consultor de Proyecto | 60 |  |

## Schedule

| ID | WBS | Task | Type | Duration | Start | Finish | Predecessors | Total slack | Free slack | Constraint | Resources | Work | Cost |
| --- | --- | --- | --- | --- | --- | --- | --- | --- | --- | --- | --- | --- | --- |
| 1 | 1 | **Proyecto Solución CDI - ETAPA 2** |  | 147d | 2008-01-02 | 2008-07-24 |  | 0d |  |  |  | 3599.6h | 215,976 |
| 2 | 1.1 | Reunión de Arranque |  | 0.5d | 2008-01-02 | 2008-01-02 |  | 146.5d |  |  | Gerente de Proyecto [50%] | 2h | 120 |
| 3 | 1.2 | **Fase I - Levantamiento de Información** |  | 20d | 2008-01-02 | 2008-01-29 |  | 127d |  |  |  | 100h | 6,000 |
| 4 | 1.2.1 | **Modelo de Procesos y Datos** |  | 6d | 2008-01-02 | 2008-01-09 |  | 127d |  |  |  | 48h | 2,880 |
| 5 | 1.2.1.1 | Mesa de Trabajo # 1 |  | 2d | 2008-01-02 | 2008-01-03 |  | 127d | 0d |  | Lider Tecnico | 16h | 960 |
| 6 | 1.2.1.2 | Mesa de Trabajo # 2 |  | 2d | 2008-01-04 | 2008-01-07 | 5 | 127d | 0d |  | Lider Tecnico | 16h | 960 |
| 7 | 1.2.1.3 | Mesa de Trabajo # 3 |  | 2d | 2008-01-08 | 2008-01-09 | 6 | 127d | 0d |  | Lider Tecnico | 16h | 960 |
| 8 | 1.2.2 | **Infraestructura y Crecimiento Futuro** |  | 2.5d | 2008-01-10 | 2008-01-14 |  | 138.5d |  |  |  | 20h | 1,200 |
| 9 | 1.2.2.1 | Investigación de requerimientos de infraestructura |  | 2d | 2008-01-10 | 2008-01-11 | 7 | 138.5d | 0d |  | Lider Tecnico | 16h | 960 |
| 10 | 1.2.2.2 | Elaborar informe de recomendaciones |  | 0.5d | 2008-01-14 | 2008-01-14 | 9 | 138.5d |  |  | Lider Tecnico | 4h | 240 |
| 11 | 1.2.3 | **Informe de Especificación de Requerimientos** |  | 14d | 2008-01-10 | 2008-01-29 |  | 127d |  |  |  | 32h | 1,920 |
| 12 | 1.2.3.1 | Elaboración del Informe de Especificación de Requerimientos |  | 2d | 2008-01-10 | 2008-01-11 | 7 | 127d | 0d |  | Lider Tecnico | 16h | 960 |
| 13 | 1.2.3.2 | Entrega al Equipo de Proyecto CDI para su revisión | milestone | 0d | 2008-01-11 | 2008-01-11 | 12 | 127d | 0d | start no earlier than 2006-12-01 |  |  |  |
| 14 | 1.2.3.3 | Revisión por parte del Equipo de Proyecto CDI | milestone | 0d | 2008-01-11 | 2008-01-11 | 13 | 139d |  |  |  |  |  |
| 15 | 1.2.3.4 | Ajustes al Informe Especificación de Requerimientos |  | 2d | 2008-01-28 | 2008-01-29 | 13FS+10d | 127d | 0d |  | Lider Tecnico | 16h | 960 |
| 16 | 1.2.3.5 | Entrega de Especificación de Req. para aprobación | milestone | 0d | 2008-01-29 | 2008-01-29 | 15 | 127d | 0d | start no earlier than 2006-12-07 |  |  |  |
| 17 | 1.2.3.6 | Aprobación del Informe Especificación de Requerimientos | milestone | 0d | 2008-01-29 | 2008-01-29 | 16 | 127d | 0d | start no earlier than 2007-04-05 |  |  |  |
| 18 | 1.2.4 | Informe Especificación de Requerimientos Aprobado | milestone | 0d | 2008-01-29 | 2008-01-29 | 17 | 127d |  |  |  |  |  |
| 19 | 1.2.5 | Modelo de Procesos y Datos Definido | milestone | 0d | 2008-01-29 | 2008-01-29 | 17 | 127d |  |  |  |  |  |
| 20 | 1.3 | **Fase II - Sistema de Gestión CDI** |  | 60d | 2008-01-02 | 2008-03-25 |  | 0d |  |  |  | 1236h | 74,160 |
| 21 | 1.3.1 | Análisis y Diseño |  | 2d | 2008-01-02 | 2008-01-03 |  | 0d |  |  | Lider Tecnico; Gerente de Proyecto [50%] | 24h | 1,440 |
| 22 | 1.3.2 | Configuración y Desarrollo |  | 50d | 2008-01-04 | 2008-03-13 | 21 | 0d |  |  | Programador [200%]; Lider Tecnico [50%] | 1000h | 60,000 |
| 23 | 1.3.3 | **Implantación** |  | 8d | 2008-03-14 | 2008-03-25 |  | 0d |  |  |  | 212h | 12,720 |
| 24 | 1.3.3.1 | Pruebas internas |  | 5d | 2008-03-14 | 2008-03-20 | 22 | 90d |  |  | Programador [200%]; Lider Tecnico [50%] | 100h | 6,000 |
| 25 | 1.3.3.2 | Documentación |  | 3d | 2008-03-14 | 2008-03-18 | 22 | 0d |  |  | Lider Tecnico; Gerente de Proyecto [50%] | 36h | 2,160 |
| 26 | 1.3.3.3 | Adiestramiento |  | 2d | 2008-03-19 | 2008-03-20 | 25 | 0d |  |  | Lider Tecnico | 16h | 960 |
| 27 | 1.3.3.4 | Pruebas de Certificación |  | 3d | 2008-03-21 | 2008-03-25 | 26 | 0d |  |  | Lider Tecnico [50%]; Programador [200%] | 60h | 3,600 |
| 28 | 1.3.3.5 | Sistema de Gestión CDI implantado | milestone | 0d | 2008-03-25 | 2008-03-25 | 27 | 0d |  |  |  |  |  |

| ID | WBS | Task | Type | Duration | Start | Finish | Predecessors | Total slack | Resources | Work | Cost |
| --- | --- | --- | --- | --- | --- | --- | --- | --- | --- | --- | --- |
| 29 | 1.4 | **Fase III - Integración** |  | 87d | 2008-03-26 | 2008-07-24 |  | 0d |  | 2261.6h | 135,696 |
| 30 | 1.4.1 | **Fase 1 - Operación** |  | 73d | 2008-03-26 | 2008-07-04 |  | 0d |  | 2072h | 124,320 |
| 31 | 1.4.1.1 | CxP |  | 35d | 2008-03-26 | 2008-05-13 | 28 | 52d | Programador [200%]; Lider Tecnico [50%] | 700h | 42,000 |
| 32 | 1.4.1.2 | CxC |  | 35d | 2008-03-26 | 2008-05-13 | 28 | 0d | Programador [200%]; Lider Tecnico [50%] | 700h | 42,000 |
| 33 | 1.4.1.3 | Fase 2 - Integración con Great Plains |  | 48d | 2008-04-30 | 2008-07-04 | 32FS-10d | 0d | Programador [200%]; Lider Tecnico [50%] | 672h | 40,320 |
| 34 | 1.4.2 | **Implantación** |  | 14d | 2008-07-07 | 2008-07-24 |  | 0d |  | 189.6h | 11,376 |
| 35 | 1.4.2.1 | Pruebas internas |  | 5d | 2008-07-07 | 2008-07-11 | 33 | 0d | Programador [200%]; Lider Tecnico [50%] | 100h | 6,000 |
| 36 | 1.4.2.2 | Documentación |  | 3d | 2008-07-14 | 2008-07-16 | 35 | 0d | Lider Tecnico [60%]; Gerente de Proyecto [30%] | 21.6h | 1,296 |
| 37 | 1.4.2.3 | Adiestramiento |  | 2d | 2008-07-17 | 2008-07-18 | 36 | 0d | Lider Tecnico | 16h | 960 |
| 38 | 1.4.2.4 | Pruebas de Certificación |  | 3d | 2008-07-21 | 2008-07-23 | 37 | 0d | Lider Tecnico; Programador | 48h | 2,880 |
| 39 | 1.4.2.5 | Gestión de CxP y CxC implantado | milestone | 0d | 2008-07-23 | 2008-07-23 | 38 | 1d |  |  |  |
| 40 | 1.4.2.6 | Integración con Clientes y Afiliados | milestone | 0d | 2008-07-23 | 2008-07-23 | 38 | 1d |  |  |  |
| 41 | 1.4.2.7 | Cierre |  | 1d | 2008-07-24 | 2008-07-24 | 38 | 0d | Gerente de Proyecto [50%] | 4h | 240 |
| 42 | 1.5 | Gerencia de Proyectos | milestone | 0d | 2008-01-02 | 2008-01-02 |  | 147d |  |  |  |
