# Cronograma Fase 1

Schedule from MS Project, 2008-03-10 to 2008-04-07.
gwt

## Calendars

- Standard: Mon-Fri 08:00-12:00, 13:00-17:00; Sat-Sun off. Exceptions (off unless hours are given): 2008-03-20 to 2008-03-21.

## Resources

| Resource |
| --- |
| Mcolmenarez |
| Jsuarez |
| Falvarez |
| Programador |
| Operaciones |

## Schedule

| ID | WBS | Task | Type | Duration | Start | Finish | Predecessors | Total slack | Resources | Work |
| --- | --- | --- | --- | --- | --- | --- | --- | --- | --- | --- |
| 1 | 1 | **Fase 1: Web Site Amigo's Car Rental** |  | 19d | 2008-03-10 | 2008-04-07 |  | 0d |  | 176h |
| 2 | 1.1 | **Análisis y Diseño** |  | 7d | 2008-03-10 | 2008-03-18 |  | 0d |  | 64h |
| 3 | 1.1.1 | Análisis |  | 2d | 2008-03-10 | 2008-03-11 |  | 0d | Mcolmenarez | 16h |
| 4 | 1.1.2 | Tablas |  | 1d | 2008-03-12 | 2008-03-12 | 3 | 16d | Jsuarez | 8h |
| 5 | 1.1.3 | Propuesta Gráfica |  | 5d | 2008-03-12 | 2008-03-18 | 3 | 0d | Falvarez | 40h |
| 6 | 1.1.4 | Aprobación Propuesta Gráfica | milestone | 0d | 2008-03-18 | 2008-03-18 | 5 | 0d |  |  |
| 7 | 1.2 | **Desarrollo** |  | 11d | 2008-03-19 | 2008-04-04 |  | 0d |  | 88h |
| 8 | 1.2.1 | Pagina Principal |  | 5d | 2008-03-19 | 2008-03-27 | 6 | 0d | Jsuarez | 40h |
| 9 | 1.2.2 | Oferta del mes |  | 2d | 2008-03-28 | 2008-03-31 | 8 | 0d | Jsuarez | 16h |
| 10 | 1.2.3 | Nuestros vehículos |  | 3d | 2008-04-01 | 2008-04-03 | 9 | 0d | Jsuarez | 24h |
| 11 | 1.2.4 | Donde estamos |  | 1d | 2008-04-04 | 2008-04-04 | 10 | 0d | Jsuarez | 8h |
| 12 | 1.3 | **Operacionalización y puesta en servicio** |  | 1d | 2008-04-07 | 2008-04-07 |  | 0d |  | 8h |
| 13 | 1.3.1 | Operacionalización |  | 0.5d | 2008-04-07 | 2008-04-07 | 11 | 0d | Operaciones [150%] | 6h |
| 14 | 1.3.2 | Entrenamiento |  | 0.5d | 2008-04-07 | 2008-04-07 | 13 | 0d | Mcolmenarez [50%] | 2h |
| 15 | 1.4 | Gerencia Proyecto |  | 2d | 2008-03-10 | 2008-03-11 |  | 17d | Mcolmenarez | 16h |
