# Cronograma Fase 1

Schedule from MS Project, 2008-03-31 to 2008-04-21.
gwt

## Calendars

- Standard: Mon-Fri 08:00-12:00, 13:00-17:00; Sat-Sun off.

## Resources

| Resource |
| --- |
| Mcolmenarez |
| Flor |
| Falvarez |
| Programador |
| Operaciones |

## Schedule

| ID | WBS | Task | Type | Duration | Start | Finish | Predecessors | Total slack | Resources | Work |
| --- | --- | --- | --- | --- | --- | --- | --- | --- | --- | --- |
| 1 | 1 | **Web Site Bremmer Motors** |  | 15.75d | 2008-03-31 | 2008-04-21 |  | 0d |  | 57h |
| 2 | 1.1 | **Diseño** |  | 0.75d | 2008-03-31 | 2008-03-31 |  | 0d |  | 6h |
| 3 | 1.1.1 | Propuesta Gráfica |  | 0.75d | 2008-03-31 | 2008-03-31 |  | 0d | Falvarez | 6h |
| 4 | 1.1.2 | Aprobación Propuesta Gráfica | milestone | 0d | 2008-03-31 | 2008-03-31 | 3 | 0d |  |  |
| 5 | 1.2 | **Desarrollo** |  | 12d | 2008-03-31 | 2008-04-16 |  | 0d |  | 36h |
| 6 | 1.2.1 | **Formularios** |  | 8d | 2008-03-31 | 2008-04-10 | 4 | 0d |  | 18h |
| 7 | 1.2.1.1 | Cotizacioes |  | 5d | 2008-03-31 | 2008-04-07 | 4 | 0d | Flor [15%] | 6h |
| 8 | 1.2.1.2 | Accesorios |  | 2d | 2008-04-07 | 2008-04-09 | 7 | 0d | Flor [37.5%] | 6h |
| 9 | 1.2.1.3 | Contactenos |  | 1d | 2008-04-09 | 2008-04-10 | 8 | 0d |  | 6h |
| 10 | 1.2.2 | Banners |  | 3d | 2008-04-10 | 2008-04-15 | 9 | 0d | Flor [25%] | 6h |
| 11 | 1.2.3 | Googles Analyitics |  | 1d | 2008-04-15 | 2008-04-16 | 10 | 0d | Flor [150%] | 12h |
| 12 | 1.3 | Pruebas |  | 1d | 2008-04-16 | 2008-04-17 | 11 | 0d |  | 2h |
| 13 | 1.4 | Documentación |  | 1d | 2008-04-17 | 2008-04-18 | 12 | 0d |  | 4h |
| 14 | 1.5 | **Operacionalización y puesta en servicio** |  | 1d | 2008-04-18 | 2008-04-21 |  | 0d |  | 5h |
| 15 | 1.5.1 | Operacionalización |  | 0.5d | 2008-04-18 | 2008-04-21 | 13 | 0d | Operaciones [75%] | 3h |
| 16 | 1.5.2 | Entrenamiento |  | 0.5d | 2008-04-21 | 2008-04-21 | 15 | 0d | Mcolmenarez [50%] | 2h |
| 17 | 1.6 | Gerencia Proyecto |  | 0.5d | 2008-03-31 | 2008-03-31 |  | 15.25d | Mcolmenarez | 4h |
