# Cronograma Kitchen Fair

Schedule from MS Project, 2008-07-01 to 2008-12-23.

## Calendars

- Estándar: Mon-Fri 09:00-13:00, 15:00-19:00; Sat-Sun off.

## Schedule

| ID | WBS | Task | Duration | Start | Finish | Predecessors | Total slack | Work |
| --- | --- | --- | --- | --- | --- | --- | --- | --- |
| 1 | 1 | **Pagina Web y Sistema Gestion** | 126d? | 2008-07-01 | 2008-12-23 |  | 0d | 776h |
| 2 | 1.1 | **Levantamiento de Información** | 8d? | 2008-07-02 | 2008-07-11 |  | 0d | 66h |
| 3 | 1.1.1 | Reunion con el Cliente para levantar Información | 2d | 2008-07-02 | 2008-07-03 | 8 | 0d | 16h |
| 4 | 1.1.2 | Llamadas para levantar Información | 1d? | 2008-07-04 | 2008-07-04 | 3 | 122d | 2h |
| 5 | 1.1.3 | Analisis de Informacion | 1d? | 2008-07-04 | 2008-07-04 | 3 | 0d | 8h |
| 6 | 1.1.4 | Elaboración de informe de requerimientos | 5d | 2008-07-07 | 2008-07-11 | 5 | 0d | 40h |
| 7 | 1.2 | **Kick-Off del Proyecto** | 2d | 2008-07-01 | 2008-07-02 |  | 0d | 4h |
| 8 | 1.2.1 | Elaboración de Presentación del Kick-Off | 1d | 2008-07-01 | 2008-07-01 |  | 0d | 2h |
| 9 | 1.2.2 | Reunion de Kick-Off | 1d | 2008-07-02 | 2008-07-02 | 8 | 124d | 2h |
| 10 | 1.3 | **Diseño Propuesta Gráfica** | 6d? | 2008-07-14 | 2008-07-21 |  | 0d | 26h |
| 11 | 1.3.1 | Diseño de Elementos comunes | 1d? | 2008-07-14 | 2008-07-14 | 6 | 0d | 1h |
| 12 | 1.3.2 | Búsqueda de Imágenes en Internet | 1d? | 2008-07-15 | 2008-07-15 | 11 | 0d | 2h |
| 13 | 1.3.3 | Diseño Propuesta Gráfica - Home | 1d? | 2008-07-16 | 2008-07-16 | 12 | 0d | 4h |
| 14 | 1.3.4 | Diseño Propuesta Gráfica - Pagina de Contenido | 1d? | 2008-07-17 | 2008-07-17 | 13 | 0d | 3h |
| 15 | 1.3.5 | Diseño Propuesta Grafica Web Clientes | 1d? | 2008-07-18 | 2008-07-18 | 14 | 0d | 8h |
| 16 | 1.3.6 | Diseño Propuesta Grafica Web Consultores | 1d? | 2008-07-21 | 2008-07-21 | 15 | 0d | 8h |
| 17 | 1.4 | **Diseño Visual del Sitio** | 5d? | 2008-07-22 | 2008-07-28 |  | 0d | 13h |
| 18 | 1.4.1 | Procesado de Material Gráfico enviado por el Cliente | 1d? | 2008-07-22 | 2008-07-22 | 16 | 0d | 4h |
| 19 | 1.4.2 | Separación de piezas de Diseño | 1d? | 2008-07-23 | 2008-07-23 | 18 | 0d | 3h |
| 20 | 1.4.3 | Codificación de Colores | 1d? | 2008-07-24 | 2008-07-24 | 19 | 0d | 1h |
| 21 | 1.4.4 | Codificación de Textos | 1d? | 2008-07-25 | 2008-07-25 | 20 | 0d | 1h |
| 22 | 1.4.5 | Otros Ajustes | 1d? | 2008-07-28 | 2008-07-28 | 21 | 0d | 4h |
| 23 | 1.5 | **Diseño Estructural del Sitio** | 11d? | 2008-07-29 | 2008-08-12 |  | 0d | 32h |
| 24 | 1.5.1 | Programación Hoja de Estilos - Elementos Comunes | 1d? | 2008-07-29 | 2008-07-29 | 22 | 0d | 1h |
| 25 | 1.5.2 | Programación Hoja de Estilos - Elementos del Sitio | 1d? | 2008-07-30 | 2008-07-30 | 24 | 0d | 2h |
| 26 | 1.5.3 | Programación CSS - Sistema de Noticias | 1d? | 2008-07-31 | 2008-07-31 | 25 | 0d | 3h |
| 27 | 1.5.4 | Programación CSS - FAQ | 1d? | 2008-08-01 | 2008-08-01 | 26 | 0d | 2h |
| 28 | 1.5.5 | Programación CSS - Contacto | 1d? | 2008-08-04 | 2008-08-04 | 27 | 0d | 6h |
| 29 | 1.5.6 | Programación CSS – Estoy interesado en comprar | 1d? | 2008-08-05 | 2008-08-05 | 28 | 0d | 2h |
| 30 | 1.5.7 | Programación CSS – Estoy interesado en ser consultor | 1d? | 2008-08-06 | 2008-08-06 | 29 | 0d | 2h |
| 31 | 1.5.8 | Programación CSS - Prospecto y pedidos | 1d? | 2008-08-07 | 2008-08-07 | 30 | 0d | 2h |
| 32 | 1.5.9 | Programación CSS – Estadísticas de ventas | 1d? | 2008-08-08 | 2008-08-08 | 31 | 0d | 2h |
| 33 | 1.5.10 | Programación CSS - Prospecto y pedidos | 1d? | 2008-08-11 | 2008-08-11 | 32 | 0d | 4h |
| 34 | 1.5.11 | Otros Ajustes | 1d? | 2008-08-12 | 2008-08-12 | 33 | 0d | 6h |

| ID | WBS | Task | Duration | Start | Finish | Predecessors | Total slack | Work |
| --- | --- | --- | --- | --- | --- | --- | --- | --- |
| 35 | 1.6 | **Diseño Funcional del Sitio** | 7d? | 2008-08-13 | 2008-08-21 |  | 0d | 12h |
| 36 | 1.6.1 | Programación HTML - Testimoniales | 1d? | 2008-08-13 | 2008-08-13 | 34 | 0d | 2h |
| 37 | 1.6.2 | Programación HTML - Maestro / Detalle Ollas | 1d? | 2008-08-14 | 2008-08-14 | 36 | 0d | 2h |
| 38 | 1.6.3 | Programación HTML - Sistema de Colecciones | 1d? | 2008-08-15 | 2008-08-15 | 37 | 0d | 2h |
| 39 | 1.6.4 | CSS - Testimoniales | 1d? | 2008-08-18 | 2008-08-18 | 38 | 0d | 1h |
| 40 | 1.6.5 | CSS - Maestro / Detalle Ollas | 1d? | 2008-08-19 | 2008-08-19 | 39 | 0d | 1h |
| 41 | 1.6.6 | CSS - Sistema de Colecciones | 1d? | 2008-08-20 | 2008-08-20 | 40 | 0d | 1h |
| 42 | 1.6.7 | Ajustes Finales | 1d? | 2008-08-21 | 2008-08-21 | 41 | 0d | 3h |
| 43 | 1.7 | **Revision y Ajustes Finales** | 3d? | 2008-08-22 | 2008-08-26 |  | 0d | 11h |
| 44 | 1.7.1 | Contenidos dinámicos (Texto e Imágenes) | 1d? | 2008-08-22 | 2008-08-22 | 42 | 0d | 2h |
| 45 | 1.7.2 | Ajustes Gráficos Finales | 1d? | 2008-08-25 | 2008-08-25 | 44 | 0d | 6h |
| 46 | 1.7.3 | Validación y Certificación W3C | 1d? | 2008-08-26 | 2008-08-26 | 45 | 0d | 3h |
| 47 | 1.8 | **Desarrollo** | 64d? | 2008-08-27 | 2008-11-24 |  | 0d | 390h |
| 48 | 1.8.1 | **Web Publica** | 10d? | 2008-08-27 | 2008-09-09 |  | 0d | 62h |
| 49 | 1.8.1.1 | Creación de Tablas (Productos, Testimoniales,...) | 1d? | 2008-08-27 | 2008-08-27 | 46 | 0d | 4h |
| 50 | 1.8.1.2 | Información Corporativa | 1d? | 2008-08-28 | 2008-08-28 | 49 | 0d | 2h |
| 51 | 1.8.1.3 | Sistema de Testimoniales | 1d? | 2008-08-29 | 2008-08-29 | 50 | 0d | 8h |
| 52 | 1.8.1.4 | Maestro / Detalle de Productos | 1d? | 2008-09-01 | 2008-09-01 | 51 | 0d | 8h |
| 53 | 1.8.1.5 | Sistema de Colecciones | 1d? | 2008-09-02 | 2008-09-02 | 52 | 0d | 8h |
| 54 | 1.8.1.6 | Preguntas Frecuentes (FAQ) | 1d? | 2008-09-03 | 2008-09-03 | 53 | 0d | 8h |
| 55 | 1.8.1.7 | Sistema de Noticias | 1d? | 2008-09-04 | 2008-09-04 | 54 | 0d | 8h |
| 56 | 1.8.1.8 | Contáctenos | 1d? | 2008-09-05 | 2008-09-05 | 55 | 0d | 8h |
| 57 | 1.8.1.9 | Estoy interesado en comprar | 1d? | 2008-09-08 | 2008-09-08 | 56 | 0d | 6h |
| 58 | 1.8.1.10 | Estoy interesado en ser consultor | 1d? | 2008-09-09 | 2008-09-09 | 57 | 0d | 2h |

| ID | WBS | Task | Duration | Start | Finish | Predecessors | Total slack | Work |
| --- | --- | --- | --- | --- | --- | --- | --- | --- |
| 59 | 1.8.2 | **Web Consultores** | 8d? | 2008-09-10 | 2008-09-19 |  | 0d | 52h |
| 60 | 1.8.2.1 | Programación de búsqueda | 1d? | 2008-09-10 | 2008-09-10 | 58 | 0d | 8h |
| 61 | 1.8.2.2 | Ingreso de prospectos | 1d? | 2008-09-11 | 2008-09-11 | 60 | 0d | 2h |
| 62 | 1.8.2.3 | Ingreso de pedidos | 1d? | 2008-09-12 | 2008-09-12 | 61 | 0d | 2h |
| 63 | 1.8.2.4 | Programa de estadísticas | 5d | 2008-09-15 | 2008-09-19 | 62 | 0d | 40h |
| 64 | 1.8.3 | **Web Clientes** | 4d? | 2008-09-22 | 2008-09-25 |  | 0d | 24h |
| 65 | 1.8.3.1 | Mostrar compras y pedidos | 1d? | 2008-09-22 | 2008-09-22 | 63 | 0d | 4h |
| 66 | 1.8.3.2 | Estatus de pagos | 1d? | 2008-09-23 | 2008-09-23 | 65 | 0d | 4h |
| 67 | 1.8.3.3 | Ingreso y procesamiento de pagos fuera de fecha | 1d? | 2008-09-24 | 2008-09-24 | 66 | 0d | 8h |
| 68 | 1.8.3.4 | Oferta productos complementarios | 1d? | 2008-09-25 | 2008-09-25 | 67 | 0d | 8h |
| 69 | 1.8.4 | **Módulo de clientes** | 5d? | 2008-09-26 | 2008-10-02 |  | 0d | 17h |
| 70 | 1.8.4.1 | Creación de tablas | 1d? | 2008-09-26 | 2008-09-26 | 68 | 0d | 2h |
| 71 | 1.8.4.2 | Programas pre-post-formula | 1d? | 2008-09-29 | 2008-09-29 | 70 | 0d | 1h |
| 72 | 1.8.4.3 | Listas y Reportes | 1d? | 2008-09-30 | 2008-09-30 | 71 | 0d | 4h |
| 73 | 1.8.4.4 | Vistas extendidas y otros reportes | 2d | 2008-10-01 | 2008-10-02 | 72 | 0d | 10h |
| 74 | 1.8.5 | **Módulo de Consultores** | 5d? | 2008-10-03 | 2008-10-09 |  | 0d | 25h |
| 75 | 1.8.5.1 | Creación de tablas | 1d? | 2008-10-03 | 2008-10-03 | 73 | 0d | 2h |
| 76 | 1.8.5.2 | Programas pre-post-formula | 1d? | 2008-10-06 | 2008-10-06 | 75 | 0d | 3h |
| 77 | 1.8.5.3 | Listas y Reportes | 1d? | 2008-10-07 | 2008-10-07 | 76 | 0d | 4h |
| 78 | 1.8.5.4 | Vistas extendidas y otros reportes | 1d? | 2008-10-08 | 2008-10-08 | 77 | 0d | 8h |
| 79 | 1.8.5.5 | Cálculo de efectividad del consultor | 1d? | 2008-10-09 | 2008-10-09 | 78 | 0d | 8h |
| 80 | 1.8.6 | **Módulo de Ventas** | 12d? | 2008-10-10 | 2008-10-27 |  | 0d | 86h |
| 81 | 1.8.6.1 | Creación de tablas (Ventas, Comisiones...) | 1d? | 2008-10-10 | 2008-10-10 | 79 | 0d | 2h |
| 82 | 1.8.6.2 | Programas pre-post-formula | 3d | 2008-10-13 | 2008-10-15 | 81 | 0d | 24h |
| 83 | 1.8.6.3 | Listas y Reportes | 1d? | 2008-10-16 | 2008-10-16 | 82 | 0d | 4h |
| 84 | 1.8.6.4 | Vistas extendidas y otros reportes | 1d? | 2008-10-17 | 2008-10-17 | 83 | 0d | 8h |
| 85 | 1.8.6.5 | Pantalla principal para Analistas de crédito | 1d? | 2008-10-20 | 2008-10-20 | 84 | 0d | 8h |
| 86 | 1.8.6.6 | Captación de interacciones con bancos | 1d? | 2008-10-21 | 2008-10-21 | 85 | 0d | 8h |
| 87 | 1.8.6.7 | Preparación de datos en formato de c/ banco | 2d | 2008-10-22 | 2008-10-23 | 86 | 0d | 16h |
| 88 | 1.8.6.8 | Reporte comisiones semanales | 1d? | 2008-10-24 | 2008-10-24 | 87 | 0d | 8h |
| 89 | 1.8.6.9 | Reporte comisiones mensuales | 1d? | 2008-10-27 | 2008-10-27 | 88 | 0d | 8h |

| ID | WBS | Task | Duration | Start | Finish | Predecessors | Total slack | Work |
| --- | --- | --- | --- | --- | --- | --- | --- | --- |
| 90 | 1.8.7 | **Módulo de Cobranzas** | 13d? | 2008-10-28 | 2008-11-13 |  | 0d | 78h |
| 91 | 1.8.7.1 | Creación de tablas (Cuotas, llamadas, pagos) | 1d? | 2008-10-28 | 2008-10-28 | 89 | 0d | 2h |
| 92 | 1.8.7.2 | Programas pre-post-formula | 1d? | 2008-10-29 | 2008-10-29 | 91 | 0d | 2h |
| 93 | 1.8.7.3 | Listas y Reportes | 1d? | 2008-10-30 | 2008-10-30 | 92 | 0d | 8h |
| 94 | 1.8.7.4 | Vistas extendidas y otros reportes | 2d | 2008-10-31 | 2008-11-03 | 93 | 0d | 16h |
| 95 | 1.8.7.5 | Reportes de llamadas diarias | 1d? | 2008-11-04 | 2008-11-04 | 94 | 0d | 4h |
| 96 | 1.8.7.6 | Captación del resultado de la llamada | 1d? | 2008-11-05 | 2008-11-05 | 95 | 0d | 4h |
| 97 | 1.8.7.7 | Preparación de Transacciones para c/ banco | 3d | 2008-11-06 | 2008-11-10 | 96 | 0d | 24h |
| 98 | 1.8.7.8 | Cálculo de efectividad del cobrador | 2d | 2008-11-11 | 2008-11-12 | 97 | 0d | 16h |
| 99 | 1.8.7.9 | Pantalla principal para Analistas de cobranzas | 1d? | 2008-11-13 | 2008-11-13 | 98 | 0d | 2h |
| 100 | 1.8.8 | **Módulo de Apoyo al Cliente** | 6d? | 2008-11-14 | 2008-11-21 |  | 0d | 38h |
| 101 | 1.8.8.1 | Creación de tablas (Llamadas, Tickets) | 1d? | 2008-11-14 | 2008-11-14 | 99 | 0d | 2h |
| 102 | 1.8.8.2 | Programas pre-post-formula | 1d? | 2008-11-17 | 2008-11-17 | 101 | 0d | 4h |
| 103 | 1.8.8.3 | Listas y Reportes | 1d? | 2008-11-18 | 2008-11-18 | 102 | 0d | 8h |
| 104 | 1.8.8.4 | Vistas extendidas y otros reportes | 2d | 2008-11-19 | 2008-11-20 | 103 | 0d | 16h |
| 105 | 1.8.8.5 | Pantalla principal para Analistas de Apoyo al cliente | 1d? | 2008-11-21 | 2008-11-21 | 104 | 0d | 8h |
| 106 | 1.8.9 | **General** | 1d? | 2008-11-24 | 2008-11-24 |  | 0d | 8h |
| 107 | 1.8.9.1 | Panel y Pantalla Principal | 1d? | 2008-11-24 | 2008-11-24 | 105 | 0d | 8h |
| 108 | 1.9 | **Carga de datos** | 6d | 2008-11-25 | 2008-12-02 |  | 0d | 44h |
| 109 | 1.9.1 | Programas de carga | 3d | 2008-11-25 | 2008-11-27 | 107 | 0d | 24h |
| 110 | 1.9.2 | Carga y Revisión | 3d | 2008-11-28 | 2008-12-02 | 109 | 0d | 20h |
| 111 | 1.10 | Pruebas | 5d | 2008-12-03 | 2008-12-09 | 110 | 0d | 40h |
| 112 | 1.11 | Documentación | 4d | 2008-12-10 | 2008-12-15 | 111 | 0d | 32h |
| 113 | 1.12 | Operacionalización | 3d | 2008-12-16 | 2008-12-18 | 112 | 0d | 18h |
| 114 | 1.13 | Entrenamiento | 3d | 2008-12-19 | 2008-12-23 | 113 | 0d | 18h |
| 115 | 1.14 | Gerencia Proyecto | 9d | 2008-12-10 | 2008-12-22 | 111 | 1d | 70h |
