# Proyecto CRM - Corporacion Union

Schedule from MS Project, 2008-07-28 to 2008-11-18, status date 2007-03-19, A marks actual dates.

## Calendars

- Estándar: Mon-Fri 08:00-12:00, 13:00-17:00; Sat-Sun off. Exceptions (off unless hours are given): 2008-07-31 to 2008-08-05, 2008-08-27.

## Resources

| Resource |
| --- |
| R1 |
| Listbeth |
| Maribel |
| Aron |
| MR |
| JS |
| OP |

## Schedule

| ID | WBS | Task | Type | Duration | Start | Finish | Predecessors | Complete | Remaining | Baseline start | Baseline finish | Baseline duration | Total slack | Free slack | Constraint | Resources | Work | Actual work |
| --- | --- | --- | --- | --- | --- | --- | --- | --- | --- | --- | --- | --- | --- | --- | --- | --- | --- | --- |
| 1 | 1 | **Sito Web amigoscarental.com - Fase II** |  | 76.62d? | 2008-07-28 A | 2008-11-18 |  | 8% | 70.14d? | 2007-03-05 | 2007-05-29 | 57.31d | 0d |  |  |  | 304h | 14h |
| 2 | 1.1 | **Inicio** |  | 0.25d | 2008-07-28 A | 2008-07-28 A |  | 100% |  | 2007-03-05 | 2007-03-05 | 0.75d |  |  |  |  | 2h | 2h |
| 3 | 1.1.1 | Reunión de Arranque (Kickoff) |  | 0.25d | 2008-07-28 A | 2008-07-28 A |  | 100% |  | 2007-03-05 | 2007-03-05 | 0.25d |  |  | start no earlier than 2008-07-28 | MR | 2h | 2h |
| 4 | 1.2 | **Especificación de Requerimientos** |  | 12d | 2008-07-29 A | 2008-08-19 A |  | 100% |  | 2007-03-07 | 2007-03-19 | 8.75d |  |  |  |  | 12h | 12h |
| 5 | 1.2.1 | Elaboración del Informe Esp. de Req. y Matriz de Req. |  | 2d | 2008-07-29 A | 2008-07-30 A |  | 100% |  | 2007-03-07 | 2007-03-09 | 3d |  |  | start no earlier than 2008-07-29 | MR [50%] | 8h | 8h |
| 6 | 1.2.2 | Ajustes al Informe Especificación de Requerimientos |  | 1d | 2008-08-06 A | 2008-08-06 A | 5 | 100% |  | 2007-03-14 | 2007-03-15 | 2d |  |  |  | MR [50%] | 4h | 4h |
| 7 | 1.2.3 | Entrega de Especificación de Requerimientos para aprobación | milestone | 0d | 2008-08-06 A | 2008-08-06 A | 6 | 100% |  | 2007-03-15 | 2007-03-15 | 0d |  |  |  |  |  |  |
| 8 | 1.2.4 | Revisión por parte del Cliente |  | 9d | 2008-08-07 A | 2008-08-19 A | 7 | 100% |  | 2007-03-15 | 2007-03-19 | 2d |  |  |  |  |  |  |
| 9 | 1.2.5 | Aprobación del Informe Especificación de Requerimientos | milestone | 0d | 2008-08-19 A | 2008-08-19 A | 8 | 100% |  | 2007-03-19 | 2007-03-19 | 0d |  |  |  |  |  |  |
| 10 | 1.3 | Informe Especificación de Requerimientos Aprobado | milestone | 0d | 2008-08-19 | 2008-08-19 | 9 |  |  | 2007-03-19 | 2007-03-19 | 0d | 0d |  |  |  |  |  |
| 11 | 1.4 | **Configuración y Desarrollo** |  | 44.5d | 2008-08-21 | 2008-10-23 |  |  |  | 2007-03-07 | 2007-04-17 | 27.6d | 0.04d |  |  |  | 180h |  |
| 12 | 1.4.1 | Análisis y Diseño (incluye creación de tablas en BD) |  | 4d | 2008-08-21 | 2008-08-26 | 51 |  |  | 2007-03-07 | 2007-03-08 | 2d | 0.04d | 0d | finish no earlier than 2007-03-08 | JS [50%] | 16h |  |
| 13 | 1.4.2 | **Reestructuración visual (F-ACR-01)** |  | 12d | 2008-08-28 | 2008-09-12 |  |  |  | 2007-03-19 | 2007-03-23 | 4.06d | 0.04d | 0d |  |  | 48h |  |
| 14 | 1.4.2.1 | Modificación de estructura actual - tres columnas |  | 2d | 2008-08-28 | 2008-08-29 | 12 |  |  | 2007-03-19 | 2007-03-20 | 0.56d | 0.04d | 0d |  | JS [50%] | 8h |  |
| 15 | 1.4.2.2 | Reorganización de componentes existentes |  | 6d | 2008-09-01 | 2008-09-08 | 14 |  |  | 2007-03-20 | 2007-03-20 | 0.28d | 0.04d | 0d |  | JS [50%] | 24h |  |
| 16 | 1.4.2.3 | Ajustes en CSS |  | 4d | 2008-09-09 | 2008-09-12 | 15 |  |  |  |  |  | 0.04d |  |  | JS [50%] | 16h |  |
| 17 | 1.4.3 | **Reservación En-línea (F-ACR-02)** |  | 11d | 2008-09-15 | 2008-09-29 |  |  |  | 2007-03-23 | 2007-04-17 | 14.8d | 0.04d | 0d |  |  | 44h |  |
| 18 | 1.4.3.1 | Ajustes en Formulario de Solicitud de Reserva |  | 5d | 2008-09-15 | 2008-09-19 | 13 |  |  | 2007-03-23 | 2007-03-26 | 1d | 0.04d | 0d |  | JS [50%] | 20h |  |
| 19 | 1.4.3.2 | Detección de Usuario autenticado |  | 4d | 2008-09-22 | 2008-09-25 | 18 |  |  | 2007-04-11 | 2007-04-12 | 1d | 0.04d | 0d |  | JS [50%] | 16h |  |
| 20 | 1.4.3.3 | Email con Reservación |  | 2d | 2008-09-26 | 2008-09-29 | 19 |  |  | 2007-04-12 | 2007-04-13 | 1d | 0.04d |  |  | JS [50%] | 8h |  |
| 21 | 1.4.4 | **Consulta de Reservaciones (F- ACR-04 )** |  | 3d | 2008-09-30 | 2008-10-02 |  |  |  |  |  |  | 0.04d | 0d |  |  | 12h |  |
| 22 | 1.4.4.1 | Ajustes en la consulta de Reservaciones del Backoffice |  | 1d | 2008-09-30 | 2008-09-30 | 17 |  |  |  |  |  | 0.04d | 0d |  | JS [50%] | 4h |  |
| 23 | 1.4.4.2 | Ajustes en actualización de Reserva - Envío de Email a Cliente |  | 2d | 2008-10-01 | 2008-10-02 | 22 |  |  |  |  |  | 0.04d |  |  | JS [50%] | 8h |  |
| 24 | 1.4.5 | **Consulta de Reservaciones por Sitio Web (F- ACR-03)** |  | 3.5d | 2008-10-03 | 2008-10-08 |  |  |  |  |  |  | 0.04d | 0d |  |  | 14h |  |
| 25 | 1.4.5.1 | Creación de opción de consulta |  | 0.5d | 2008-10-03 | 2008-10-03 | 21 |  |  |  |  |  | 0.04d | 0d |  | JS [50%] | 2h |  |
| 26 | 1.4.5.2 | Listado de Reservas del Cliente (con su status y enlace a detalle) |  | 3d | 2008-10-03 | 2008-10-08 | 25 |  |  |  |  |  | 0.04d |  |  | JS [50%] | 12h |  |

| ID | WBS | Task | Type | Duration | Start | Finish | Predecessors | Baseline start | Baseline finish | Baseline duration | Total slack | Free slack | Resources | Work |
| --- | --- | --- | --- | --- | --- | --- | --- | --- | --- | --- | --- | --- | --- | --- |
| 27 | 1.4.6 | **Pago de Reservación por Internet (F- ACR-03)** |  | 11d | 2008-10-08 | 2008-10-23 |  |  |  |  | 0.04d | 0d |  | 46h |
| 28 | 1.4.6.1 | Configuración de Boton de Pago de Todo1 |  | 1d | 2008-10-08 | 2008-10-09 | 24 |  |  |  | 0.04d | 0d | OP [25%]; JS [50%] | 6h |
| 29 | 1.4.6.2 | Boton de Pago desde listado de Reservaciones (para pagos pendientes) |  | 4d | 2008-10-09 | 2008-10-15 | 28 |  |  |  | 0.04d | 0d | JS [50%] | 16h |
| 30 | 1.4.6.3 | Formulario para pago con TDC |  | 3d | 2008-10-15 | 2008-10-20 | 29 |  |  |  | 0.04d | 0d | JS [50%] | 12h |
| 31 | 1.4.6.4 | Pruebas de pago y ajustes (con data de prueba con el Banco) |  | 3d | 2008-10-20 | 2008-10-23 | 30 |  |  |  | 0.04d |  | JS [50%] | 12h |
| 32 | 1.5 | Pruebas Internas y Ajustes |  | 5d | 2008-10-23 | 2008-10-30 | 27 | 2007-04-17 | 2007-04-25 | 5d | 0.04d | 0d | JS [50%]; MR [30%] | 32h |
| 33 | 1.6 | **Documentación** |  | 6d? | 2008-10-30 | 2008-11-07 |  | 2007-04-25 | 2007-05-21 | 17.34d | 7.12d |  |  | 20h |
| 34 | 1.6.1 | Guia de Usuarios Módulo Reservaciones En Línea |  | 4d | 2008-10-30 | 2008-11-05 | 32 | 2007-04-25 | 2007-05-18 | 16.34d | 8.12d | 0d | JS [50%] | 16h |
| 35 | 1.6.2 | Ajustes en Documento Técnico realizado en Fase I |  | 1d? | 2008-11-05 | 2008-11-06 | 34 |  |  |  | 7.12d | 0d | JS [50%] | 4h |
| 36 | 1.6.3 | Documentos de Guía de Usuarios |  | 1d | 2008-11-06 | 2008-11-07 | 35 | 2007-05-18 | 2007-05-21 | 1d | 7.12d |  |  |  |
| 37 | 1.7 | **Adiestramiento** |  | 0.38d? | 2008-11-05 | 2008-11-05 |  | 2007-04-17 | 2007-05-28 | 27.34d | 8.75d |  |  | 3h |
| 38 | 1.7.1 | Presentación para adiestramiento |  | 0.12d? | 2008-11-05 | 2008-11-05 | 34 |  |  |  | 8.75d | 0d | MR | 1h |
| 39 | 1.7.2 | Adiestramiento Módulo de Reservaciones En-Linea |  | 0.25d | 2008-11-05 | 2008-11-05 | 38 |  |  |  | 8.75d |  | MR | 2h |
| 40 | 1.8 | Fase II de Sitio Web |  | 1d | 2008-10-30 | 2008-10-31 | 32 | 2007-04-25 | 2007-04-26 | 1d | 0.04d | 0d |  |  |
| 41 | 1.9 | **Pruebas de Certificación** |  | 9d | 2008-10-31 | 2008-11-13 |  | 2007-04-26 | 2007-05-10 | 9d | 0.04d | 0d |  | 16h |
| 42 | 1.9.1 | Realización de Pruebas de Funcionalidad por parte de Cliente |  | 5d | 2008-10-31 | 2008-11-07 | 40 | 2007-04-26 | 2007-05-04 | 5d | 0.04d | 0d |  |  |
| 43 | 1.9.2 | Realización de Ajustes recomendados |  | 4d | 2008-11-07 | 2008-11-13 | 42 | 2007-05-04 | 2007-05-10 | 4d | 0.04d | 0d | JS [50%] | 16h |
| 44 | 1.9.3 | Certificación del Sistema | milestone | 0d | 2008-11-13 | 2008-11-13 | 43 | 2007-05-10 | 2007-05-10 | 0d | 0.04d |  |  |  |
| 45 | 1.10 | **Puesta en Producción** |  | 2.67d | 2008-11-13 | 2008-11-18 |  | 2007-05-10 | 2007-05-18 | 6d | 0.04d | 0d |  | 4h |
| 46 | 1.10.1 | Implantación/Entonación |  | 1.67d | 2008-11-13 | 2008-11-17 | 41 | 2007-05-10 | 2007-05-11 | 1d | 0.04d | 0d | OP [30%] | 4h |
| 47 | 1.10.2 | Sistema en Producción |  | 1d | 2008-11-17 | 2008-11-18 | 46 | 2007-05-17 | 2007-05-18 | 1d | 0.04d |  |  |  |
| 48 | 1.11 | **Cierre** |  | 0.42d | 2008-11-18 | 2008-11-18 |  | 2007-05-28 | 2007-05-29 | 0.38d | 0.04d |  |  | 1h |
| 49 | 1.11.1 | Preparación y envio de Acta de Cierre |  | 0.42d | 2008-11-18 | 2008-11-18 | 45 | 2007-05-28 | 2007-05-29 | 0.12d | 0.04d |  | MR [30%] | 1h |
| 50 | 1.12 | **Gerencia de Proyecto** |  | 63.62d | 2008-08-20 | 2008-11-18 |  | 2007-03-09 | 2007-04-27 | 32.38d | 0d |  |  | 34h |
| 51 | 1.12.1 | Planificación |  | 1d | 2008-08-20 | 2008-08-20 | 10 | 2007-03-19 | 2007-03-20 | 1.11d | 0d |  | MR [50%] | 4h |
| 52 | 1.12.2 | Control y Seguimiento |  | 62.5d | 2008-08-21 | 2008-11-18 | 51 | 2007-03-09 | 2007-04-27 | 32.5d | 0d |  | MR [6%] | 30h |
