# Revensub

Schedule from MS Project, 2008-11-13 to 2008-12-26, A marks actual dates.
GlobalWebTek de Venezuela

## Calendars

- Estándar: Mon-Fri 09:00-13:00, 15:00-19:00; Sat-Sun off.

## Resources

| Resource |
| --- |
| Gerente de Proyecto |
| Diseñador Web |
| Desarrollador Web |
| Programador Web |
| OMS |
| Web Editor |

## Schedule

| ID | WBS | Task | Duration | Start | Finish | Predecessors | Complete | Remaining | Total slack | Free slack | Resources | Work | Actual work |
| --- | --- | --- | --- | --- | --- | --- | --- | --- | --- | --- | --- | --- | --- |
| 1 | 1 | **Proyecto:** | 31.45d? | 2008-11-13 A | 2008-12-26 |  | 2% | 30.67d? | 0d |  |  | 120h | 4h |
| 2 | 1.1 | **Esfuerzo de Ventas** | 3.1d? | 2008-11-13 A | 2008-11-18 |  | 32% | 2.1d? | 0d |  |  | 10h | 4h |
| 3 | 1.1.1 | Reunion para Levantamiento de Informacion | 1d? | 2008-11-13 A | 2008-11-13 A |  | 100% |  |  |  | Gerente de Proyecto [50%] | 4h | 4h |
| 4 | 1.1.2 | Elaboracion de la Propuesta | 1d? | 2008-11-14 | 2008-11-14 | 3 |  |  | 0d |  | Gerente de Proyecto [37.5%] | 3h |  |
| 5 | 1.1.3 | Reunion de Lineamientos y Consultas | 0.1d? | 2008-11-17 | 2008-11-17 | 4 |  |  | 0d |  | Gerente de Proyecto; Diseñador Web [50%]; Desarrollador Web [50%]; Programador Web [50%] | 2h |  |
| 6 | 1.1.4 | Seguimiento de la Propuesta | 1d? | 2008-11-17 | 2008-11-18 | 5 |  |  | 0d |  | Gerente de Proyecto [12.5%] | 1h |  |
| 7 | 1.2 | **Conceptualizacion** | 4.35d? | 2008-11-18 | 2008-11-24 | 2 |  |  | 0d |  |  | 13h |  |
| 8 | 1.2.1 | **Diseño de la Interfaz** | 3.35d? | 2008-11-18 | 2008-11-21 |  |  |  | 0d |  |  | 8h |  |
| 9 | 1.2.1.1 | Diseño del BluePrint | 0.25d? | 2008-11-18 | 2008-11-18 |  |  |  | 0d |  | Desarrollador Web [50%] | 1h |  |
| 10 | 1.2.1.2 | Diseño del Wireframe | 1d? | 2008-11-18 | 2008-11-19 | 9 |  |  | 0d |  | Desarrollador Web [50%] | 4h |  |
| 11 | 1.2.1.3 | Reunion para Lineamientos y Ajustes | 0.1d? | 2008-11-19 | 2008-11-19 | 10 |  |  | 0d |  | Diseñador Web [12.5%]; Gerente de Proyecto [12.5%]; Desarrollador Web [50%]; Programador Web [50%] | 1h |  |
| 12 | 1.2.1.4 | Creacion del Informe de Asignaciones | 1d? | 2008-11-19 | 2008-11-20 | 11 |  |  | 0d |  | Gerente de Proyecto [12.5%] | 1h |  |
| 13 | 1.2.1.5 | Paquetizacion, Envio y Seguimiento | 1d? | 2008-11-20 | 2008-11-21 | 12 |  |  | 0d |  | Gerente de Proyecto [12.5%] | 1h |  |
| 14 | 1.2.2 | **Diseño de la Propuesta Grafica** | 1d? | 2008-11-21 | 2008-11-24 | 8 |  |  | 0d |  |  | 5h |  |
| 15 | 1.2.2.1 | Reunion con Diseñadores Web | 1d? | 2008-11-21 | 2008-11-24 |  |  |  | 0d |  | Gerente de Proyecto [50%] | 4h |  |
| 16 | 1.2.2.2 | Paquetizacion, Envio y Seguimiento | 0.96d? | 2008-11-21 | 2008-11-24 |  |  |  | 0.04d |  | Gerente de Proyecto [13%] | 1h |  |
| 17 | 1.3 | **Desarrollo** | 14.75d? | 2008-11-24 | 2008-12-15 | 14 |  |  | 0d |  |  | 54h |  |
| 18 | 1.3.1 | **Diseño Visual del Sitio** | 3d? | 2008-11-24 | 2008-11-27 |  |  |  | 2d |  |  | 8h |  |
| 19 | 1.3.1.1 | Separacion de Componentes | 1d? | 2008-11-24 | 2008-11-25 |  |  |  | 2d | 0d | Diseñador Web [37.5%] | 3h |  |
| 20 | 1.3.1.2 | Recepcion y Procesado de Componentes Graficos | 1d? | 2008-11-25 | 2008-11-26 | 19 |  |  | 2d | 0d | Diseñador Web [50%] | 4h |  |
| 21 | 1.3.1.3 | Revision y Adecuacion de Material Escrito | 1d? | 2008-11-26 | 2008-11-27 | 20 |  |  | 2d |  | Diseñador Web [12.5%] | 1h |  |
| 22 | 1.3.2 | **Diseño Estructural del Sitio** | 5d? | 2008-11-24 | 2008-12-01 |  |  |  | 0d |  |  | 13h |  |
| 23 | 1.3.2.1 | Creacion de la Hoja de Estilos | 1d? | 2008-11-24 | 2008-11-25 |  |  |  | 0d |  | Desarrollador Web [50%] | 4h |  |
| 24 | 1.3.2.2 | Desarrollo de XHTML para aplicación (1) - Menu de Productos con Subnivel | 1d? | 2008-11-25 | 2008-11-26 | 23 |  |  | 0d |  | Desarrollador Web [25%] | 2h |  |
| 25 | 1.3.2.3 | Desarrollo XHTML para Aplicación Ubicación de Distribuidores Geograficamente | 1d? | 2008-11-26 | 2008-11-27 | 24 |  |  | 0d |  |  | 2h |  |
| 26 | 1.3.2.4 | Desarrollo XHTML para Aplicación de Testimoniales | 1d? | 2008-11-27 | 2008-11-28 | 25 |  |  | 0d |  |  | 3h |  |
| 27 | 1.3.2.5 | Implementacion y Ajustes en WIB de la Hoja de Estilos | 1d? | 2008-11-28 | 2008-12-01 | 26 |  |  | 0d |  | Desarrollador Web [25%] | 2h |  |

| ID | WBS | Task | Duration | Start | Finish | Predecessors | Total slack | Resources | Work |
| --- | --- | --- | --- | --- | --- | --- | --- | --- | --- |
| 28 | 1.3.3 | **Diseño Funcional del Sitio** | 9.75d? | 2008-12-01 | 2008-12-15 | 18, 22 | 0d |  | 33h |
| 29 | 1.3.3.1 | Setup y Activacion del Sitio | 1d? | 2008-12-01 | 2008-12-02 |  | 0d | OMS [12.5%] | 1h |
| 30 | 1.3.3.2 | Creacion de Tablas | 1d? | 2008-12-02 | 2008-12-03 | 29 | 0d | Programador Web [12.5%] | 1h |
| 31 | 1.3.3.3 | Programacion de Aplicación No WIB - Menu de Productos con Subnivel | 2d? | 2008-12-03 | 2008-12-05 | 30 | 0d | Programador Web [50%] | 8h |
| 32 | 1.3.3.4 | Programacion de Aplicación No WIB - Ubicación de Distribuidores Geograficamente | 1.5d? | 2008-12-05 | 2008-12-08 | 31 | 0d | Programador Web [50%] | 6h |
| 33 | 1.3.3.5 | Programacion de Aplicación No WIB - Experiencias y Testimoniales | 2d? | 2008-12-08 | 2008-12-10 | 32 | 0d | Programador Web [50%] | 8h |
| 34 | 1.3.3.6 | Programacion Aplicación WIB - Noticias, Reseñas y Eventos | 1d? | 2008-12-10 | 2008-12-11 | 33 | 0d | Programador Web [50%] | 4h |
| 35 | 1.3.3.7 | Programacion de Aplicación WIB - Contacto | 1d? | 2008-12-11 | 2008-12-12 | 34 | 0d | Programador Web [50%] | 4h |
| 36 | 1.3.3.8 | Programacion de Aplicaciones WIB Automatizada - Barra de Navegacion | 0.25d? | 2008-12-12 | 2008-12-15 | 35 | 0d | Desarrollador Web [50%] | 1h |
| 37 | 1.4 | **Implementacion** | 5.25d? | 2008-12-15 | 2008-12-22 | 14, 17 | 0d |  | 18h |
| 38 | 1.4.1 | **Carga de Contenidos** | 2d? | 2008-12-15 | 2008-12-17 |  | 0d |  | 9h |
| 39 | 1.4.1.1 | Carga de Contenidos Estaticos - 2 Idiomas ( 5 Documentos en PL) | 0.75d? | 2008-12-15 | 2008-12-15 |  | 1.25d | Web Editor [50%] | 3h |
| 40 | 1.4.1.2 | Carga de Contenidos Dinamicos para Familia de Productos ( 6 Registros) - 2 Idiomas | 2d? | 2008-12-15 | 2008-12-17 |  | 0d | Web Editor [12.5%] | 2h |
| 41 | 1.4.1.3 | Carga de Contenidos Dinamicos para Ubicación de Distribuidores (6 Registros ) - 2 Idiomas | 1d? | 2008-12-15 | 2008-12-16 |  | 1d |  | 2h |
| 42 | 1.4.1.4 | Carga de Contenidos Dinamicos para Testimoniales ( 6 Registros ) - 2 Idiomas | 1d? | 2008-12-15 | 2008-12-16 |  | 1d |  | 2h |
| 43 | 1.4.2 | Optimizacion y Ajustes para Buscadores | 1d? | 2008-12-17 | 2008-12-18 | 38 | 0d |  | 4h |
| 44 | 1.4.3 | Ajustes de Programacion y Diseño | 1d? | 2008-12-18 | 2008-12-19 | 43 | 0d | Desarrollador Web [25%] | 2h |
| 45 | 1.4.4 | Pruebas de Certificacion | 0.25d? | 2008-12-19 | 2008-12-19 | 44 | 0d | Gerente de Proyecto | 2h |
| 46 | 1.4.5 | Revision final | 1d? | 2008-12-19 | 2008-12-22 | 45 | 0d | Gerente de Proyecto [12.5%] | 1h |
| 47 | 1.5 | **Pase a Produccion** | 2d? | 2008-12-22 | 2008-12-24 | 17, 37 | 0d |  | 5h |
| 48 | 1.5.1 | Tramites Administrativos | 1d? | 2008-12-22 | 2008-12-23 |  | 0d | OMS [12.5%] | 1h |
| 49 | 1.5.2 | Adiestramiento a usuarios | 1d? | 2008-12-23 | 2008-12-24 | 48 | 0d | Gerente de Proyecto [50%] | 4h |
| 50 | 1.6 | **Cierre del Proyecto** | 2d? | 2008-12-24 | 2008-12-26 | 47 | 0d |  | 2h |
| 51 | 1.6.1 | Reunion de Cierre | 1d? | 2008-12-24 | 2008-12-25 |  | 0d | Gerente de Proyecto [12.5%] | 1h |
| 52 | 1.6.2 | Tramites Administrativos | 1d? | 2008-12-25 | 2008-12-26 | 51 | 0d | Gerente de Proyecto [12.5%] | 1h |
| 53 | 1.7 | Gerencia de Proyectos | 2.25d? | 2008-11-18 | 2008-11-20 |  | 26d | Gerente de Proyecto | 18h |

Notes:
- 31: Cada Aplicación No WIB que sea Necesario Programar, estimar tiempo de Programacion, sin el XHTML
- 35: Cada Aplicación WIB que sea Necesario Programar, estimar tiempo de Programacion en N2C
- 36: Cada Aplicación WIB que sea Necesario Programar, sin Conectar con Tablas
- 39: Se cargaran en Parrafo Libre el Contenido acordado con el Cliente durante el Levantamiento de la Informacion
- 40: Se cargaran 5 registros por aplicacion solicitada
