# Nuevo Pendientes-Factibles

Schedule from MS Project, 2008-09-23 to 2009-02-06, A marks actual dates.
KATET

## Calendars

- Estándar: Mon-Fri 09:00-13:00, 15:00-19:00; Sat-Sun off. Exceptions (off unless hours are given): 2008-12-19 to 2009-01-13.

## Resources

| Resource |
| --- |
| GP |
| OP |
| DS |
| DS2 |

## Schedule

| ID | WBS | Task | Type | Duration | Start | Finish | Predecessors | Complete | Remaining | Total slack | Free slack | Constraint | Resources | Work | Actual work |
| --- | --- | --- | --- | --- | --- | --- | --- | --- | --- | --- | --- | --- | --- | --- | --- |
| 1 | 1 | **Cines Unidos** |  | 80.75d? | 2008-09-23 A | 2009-02-06 |  | 11% | 71.89d? | 0d |  |  |  | 461h | 34.6h |
| 2 | 1.1 | **Fase III - Integración** |  | 66.04d? | 2008-09-23 A | 2009-01-19 |  | 7% | 61.65d? | 0.71d | 0d |  |  | 368h | 24h |
| 3 | 1.1.1 | Análisis de integraciones (ambiente local y directorios virtuales) |  | 4d? | 2008-09-23 A | 2008-09-26 A |  | 100% |  |  |  | start no earlier than 2008-09-23 | DS [50%] | 16h | 16h |
| 4 | 1.1.2 | Migración a N2C 5.1 (en pippin y en tecnologiainternet) |  | 1.82d? | 2008-10-01 | 2008-10-02 |  |  |  | 59.68d |  | start no earlier than 2008-10-01 | OP [50%]; DS [10%] | 8h |  |
| 5 | 1.1.3 | Ajustes de CRM por cambio de versión y por ambiente Windows |  | 8.33d? | 2008-10-06 | 2008-10-16 | 10 |  |  | 49.42d |  |  | DS [50%]; DS2 [30%] | 40h |  |
| 6 | 1.1.4 | **Cambios Módulo Contacto** |  | 11d? | 2008-09-29 A | 2008-10-13 |  | 18% | 9d? | 51.75d |  |  |  | 24h | 8h |
| 7 | 1.1.4.1 | Datos nuevos en Formulario |  | 1d? | 2008-09-29 A | 2008-09-29 A | 3 | 100% |  |  |  |  | DS [50%] | 4h | 4h |
| 8 | 1.1.4.2 | Datos nuevos en detalle de contacto y en email |  | 1d? | 2008-09-30 A | 2008-09-30 A | 7 | 100% |  |  |  |  | DS [50%] | 4h | 4h |
| 9 | 1.1.4.3 | Cambio en valores de Lista de Categorías y asociación grupos contactos |  | 2d? | 2008-10-01 | 2008-10-02 | 8 |  |  | 0.71d | 0d |  | DS [50%] | 8h |  |
| 10 | 1.1.4.4 | Pruebas y ajustes |  | 1d? | 2008-10-03 | 2008-10-03 | 9 |  |  | 0.71d | 0d |  | DS [50%] | 4h |  |
| 11 | 1.1.4.5 | Pruebas certificación por parte de Cines Unidos |  | 4d | 2008-10-06 | 2008-10-09 | 10 |  |  | 53.75d |  |  |  |  |  |
| 12 | 1.1.4.6 | Puesta en producción |  | 1d? | 2008-10-10 | 2008-10-10 | 15 |  |  | 0.71d | 0d |  | DS [50%] | 4h |  |
| 13 | 1.1.4.7 | Módulo de Contacto en producción |  | 1d? | 2008-10-13 | 2008-10-13 | 12 |  |  | 51.75d |  |  |  |  |  |
| 14 | 1.1.5 | **Integración Sitio Web** |  | 7d? | 2008-10-06 | 2008-10-14 |  |  |  | 0.71d | 0d |  |  | 24h |  |
| 15 | 1.1.5.1 | Ajustes |  | 4d? | 2008-10-06 | 2008-10-09 | 10 |  |  | 0.71d | 0d |  | DS [50%] | 16h |  |
| 16 | 1.1.5.2 | Implantación y pruebas en Pippin |  | 2d? | 2008-10-13 | 2008-10-14 | 12 |  |  | 0.71d |  |  | DS [50%] | 8h |  |
| 17 | 1.1.6 | **Integración Tiendas Cines Unidos** |  | 7d? | 2008-10-10 | 2008-10-20 |  |  |  | 46.75d |  |  |  | 28h |  |
| 18 | 1.1.6.1 | Ajustes |  | 5d? | 2008-10-10 | 2008-10-16 | 15 |  |  | 46.75d | 0d |  | DS2 [50%] | 20h |  |
| 19 | 1.1.6.2 | Implantación y pruebas en Pippin |  | 2d? | 2008-10-17 | 2008-10-20 | 18 |  |  | 46.75d |  |  | DS2 [50%] | 8h |  |
| 20 | 1.1.7 | **Integración Transacciones** |  | 8d? | 2008-10-15 | 2008-10-24 |  |  |  | 0.71d | 0d |  |  | 32h |  |
| 21 | 1.1.7.1 | Desarrollo |  | 6d? | 2008-10-15 | 2008-10-22 | 14 |  |  | 0.71d | 0d |  | DS [50%] | 24h |  |
| 22 | 1.1.7.2 | Implantación y Pruebas en Pippin |  | 2d? | 2008-10-23 | 2008-10-24 | 21 |  |  | 0.71d |  |  | DS [50%] | 8h |  |
| 23 | 1.1.8 | Documentación Diccionario de Datos Vista |  | 1d? | 2008-10-03 | 2008-10-03 |  |  |  | 17.4d | 16d | start no earlier than 2008-10-03 |  |  |  |
| 24 | 1.1.9 | Integración Vista (Transacciones de Sitio Web) |  | 16.67d? | 2008-10-27 | 2008-11-18 | 23, 20 |  |  | 0.71d | 0d |  | DS [50%]; DS2 [30%] | 80h |  |
| 25 | 1.1.10 | Documentación Diccionario de Datos Vista |  | 1d? | 2008-10-10 | 2008-10-10 |  |  |  | 29.07d | 27.67d | start no earlier than 2008-10-10 |  |  |  |
| 26 | 1.1.11 | Integración CC-Vista (Clientes) |  | 16.67d? | 2008-11-18 | 2008-12-11 | 25, 24 |  |  | 0.71d | 0d |  | DS [50%]; DS2 [30%] | 80h |  |
| 27 | 1.1.12 | Documento Guia de Configuración de Integraciones |  | 4d? | 2008-12-11 | 2008-12-17 | 26 |  |  | 0.71d | 0d |  | DS [50%] | 16h |  |
| 28 | 1.1.13 | Pruebas internas y Ajustes |  | 4.71d | 2008-12-17 | 2009-01-19 | 27 |  |  | 0.71d |  |  | GP [10%]; DS [50%] | 20h |  |
| 29 | 1.2 | Migración de Programas de Integración a Pippin (dir desarrollo) |  | 2d | 2009-01-19 | 2009-01-21 | 2 |  |  | 0.71d | 0d |  | DS [50%]; OP [25%] | 8h |  |
| 30 | 1.3 | Preparación Pruebas de Certificación |  | 3d | 2009-01-21 | 2009-01-26 | 29 |  |  | 0.71d | 0d |  | DS [50%] | 12h |  |
| 31 | 1.4 | Apoyo en Pruebas de Certificación |  | 5d | 2009-01-26 | 2009-02-02 | 30 |  |  | 4.71d |  |  | DS [10%] | 4h |  |
| 32 | 1.5 | Pruebas de Certificación por parte de Cines Unidos |  | 5d | 2009-01-26 | 2009-02-02 | 30 |  |  | 0.71d | 0d |  |  |  |  |
| 33 | 1.6 | Ajustes |  | 2d? | 2009-02-02 | 2009-02-04 | 32 |  |  | 0.71d | 0d |  | DS [50%] | 8h |  |
| 34 | 1.7 | Verificación de Ajustes por parte de Cines Unidos |  | 1d | 2009-02-04 | 2009-02-05 | 33 |  |  | 0.71d | 0d |  |  |  |  |
| 35 | 1.8 | Pase a Producción de Integraciones |  | 1d | 2009-02-05 | 2009-02-06 | 34 |  |  | 0.71d | 0d |  | OP [50%]; DS [50%] | 8h |  |
| 36 | 1.9 | CRM completo en Producción | milestone | 0d | 2009-02-06 | 2009-02-06 | 35 |  |  | 0.71d |  |  |  |  |  |
| 37 | 1.10 | Gerencia de Proyectos |  | 66.25d | 2008-09-23 A | 2009-02-06 |  | 20% | 53d | 0d |  | start no earlier than 2008-09-23 | GP [10%] | 53h | 10.6h |
