# Sitio web para Cyngular

Schedule from MS Project, 2008-12-12 to 2009-05-26, A marks actual dates.
GWT

## Calendars

- Estándar: Mon-Fri 09:00-13:00, 15:00-19:00; Sat-Sun off. Exceptions (off unless hours are given): 2008-12-22 to 2009-01-13 (Vacaciones), 2009-01-14 09:00-13:00, 15:00-19:00, 2009-01-15 (Vacaciones), 2009-02-23 to 2009-02-24 (Carnavales), 2009-04-09 to 2009-04-10 (Semana santa), 2009-05-01 (Día del trabajador).

## Resources

| Resource |
| --- |
| Diseñador |
| P1 |
| GP |
| OP |
| D1 |

## Schedule

| ID | WBS | Task | Type | Duration | Start | Finish | Predecessors | Complete | Remaining | Total slack | Free slack | Constraint | Resources | Work | Actual work |
| --- | --- | --- | --- | --- | --- | --- | --- | --- | --- | --- | --- | --- | --- | --- | --- |
| 1 | 1 | **Proyecto locosporloslibros.com** |  | 94.12d? | 2008-12-12 09:00 A | 2009-05-26 10:00 |  | 22% | 73.55d? | 0d |  |  |  | 696h | 53.4h |
| 2 | 1.1 | Análisis |  | 3d? | 2008-12-12 09:00 A | 2008-12-16 19:00 A |  | 100% |  |  |  | finish no earlier than 2008-12-16 19:00 |  | 20h | 20h |
| 3 | 1.2 | Modelaje de Datos |  | 3d? | 2009-02-05 09:00 A | 2009-02-09 19:00 |  | 30% | 2.1d? | 0d |  | start no earlier than 2009-02-05 09:00 | P1 [50%]; GP [50%] | 24h | 7.2h |
| 4 | 1.3 | Estructura del repositorio de datos del Site |  | 1d? | 2009-02-10 09:00 | 2009-02-10 19:00 | 3 |  |  | 0d |  |  | P1 | 8h |  |
| 5 | 1.4 | **Sitio Web** |  | 73.5d? | 2008-12-12 09:00 A | 2009-04-24 13:00 |  | 23% | 56.23d? | 20.62d |  |  |  | 344h |  |
| 6 | 1.4.1 | **Diseño Gráfico** |  | 54d? | 2008-12-12 09:00 A | 2009-03-25 19:00 |  | 41% | 31.74d? | 40.12d |  |  |  | 120h |  |
| 7 | 1.4.1.1 | Coordinación con diseñador gráfico |  | 23d? | 2008-12-12 09:00 A | 2009-02-06 19:00 |  | 95% | 1.15d? | 41.12d | 0d | start no earlier than 2008-12-12 09:00 |  |  |  |
| 8 | 1.4.1.2 | Recepción imágenes y manual de diseño | milestone | 0d | 2009-02-09 09:00 | 2009-02-09 09:00 | 7 |  |  | 41.12d | 1d | start no earlier than 2009-02-09 09:00 | P1 |  |  |
| 9 | 1.4.1.3 | Creación hojas de Estilo |  | 15d? | 2009-02-10 09:00 | 2009-03-04 19:00 | 8, 3 |  |  | 40.12d | 0d |  | D1 [50%] | 60h |  |
| 10 | 1.4.1.4 | Estructuración del sitio |  | 15d? | 2009-03-05 09:00 | 2009-03-25 19:00 | 9 |  |  | 40.12d |  |  | D1 [50%] | 60h |  |
| 11 | 1.4.2 | **Programación** |  | 42d? | 2009-02-19 15:00 | 2009-04-24 13:00 |  |  |  | 0d |  |  |  | 224h |  |
| 12 | 1.4.2.1 | **Secciones públicas** |  | 21d? | 2009-02-19 15:00 | 2009-03-24 13:00 |  |  |  | 0d |  |  |  | 120h |  |
| 13 | 1.4.2.1.1 | **Página principal** |  | 2d? | 2009-02-19 15:00 | 2009-02-25 13:00 |  |  |  | 0d |  |  |  | 16h |  |
| 14 | 1.4.2.1.1.1 | Enlaces de Interés |  | 0.25d? | 2009-02-19 15:00 | 2009-02-19 17:00 | 78 |  |  | 0d |  |  | P1 | 2h |  |
| 15 | 1.4.2.1.1.2 | Noticia Destacada |  | 0.25d? | 2009-02-19 17:00 | 2009-02-19 19:00 | 14 |  |  | 0d |  |  | P1 | 2h |  |
| 16 | 1.4.2.1.1.3 | Listado de Noticias recientes |  | 0.5d? | 2009-02-20 09:00 | 2009-02-20 13:00 | 15 |  |  | 0d |  |  | P1 | 4h |  |
| 17 | 1.4.2.1.1.4 | Autores |  | 0.25d? | 2009-02-20 15:00 | 2009-02-20 17:00 | 16 |  |  | 0d |  |  | P1 | 2h |  |
| 18 | 1.4.2.1.1.5 | Novedades |  | 0.25d? | 2009-02-20 17:00 | 2009-02-20 19:00 | 17 |  |  | 0d |  |  | P1 | 2h |  |
| 19 | 1.4.2.1.1.6 | El Librero |  | 0.25d? | 2009-02-25 09:00 | 2009-02-25 11:00 | 18 |  |  | 0d |  |  | P1 | 2h |  |
| 20 | 1.4.2.1.1.7 | Blogoteca |  | 0.25d? | 2009-02-25 11:00 | 2009-02-25 13:00 | 19 |  |  | 0d |  |  | P1 | 2h |  |
| 21 | 1.4.2.1.2 | **Novedades** |  | 4.5d? | 2009-02-25 15:00 | 2009-03-03 19:00 |  |  |  | 0d |  |  |  | 36h |  |
| 22 | 1.4.2.1.2.1 | Página de novedades |  | 1.5d? | 2009-02-25 15:00 | 2009-02-26 19:00 | 13 |  |  | 0d |  |  | P1 | 12h |  |
| 23 | 1.4.2.1.2.2 | Buscador de libros |  | 2d? | 2009-02-27 09:00 | 2009-03-02 19:00 | 22 |  |  | 0d |  |  | P1 | 16h |  |
| 24 | 1.4.2.1.2.3 | Detalle de Libro |  | 1d? | 2009-03-03 09:00 | 2009-03-03 19:00 | 23 |  |  | 0d |  |  | P1 | 8h |  |

| ID | WBS | Task | Duration | Start | Finish | Predecessors | Total slack | Resources | Work |
| --- | --- | --- | --- | --- | --- | --- | --- | --- | --- |
| 25 | 1.4.2.1.3 | **Noticias** | 1.75d? | 2009-03-04 09:00 | 2009-03-05 17:00 |  | 0d |  | 14h |
| 26 | 1.4.2.1.3.1 | Página de Noticias | 1d? | 2009-03-04 09:00 | 2009-03-04 19:00 | 21 | 0d | P1 | 8h |
| 27 | 1.4.2.1.3.2 | Organización de Noticias por año y mes | 0.5d? | 2009-03-05 09:00 | 2009-03-05 13:00 | 26 | 0d | P1 | 4h |
| 28 | 1.4.2.1.3.3 | Detalle Noticia | 0.25d? | 2009-03-05 15:00 | 2009-03-05 17:00 | 27 | 0d | P1 | 2h |
| 29 | 1.4.2.1.4 | Blogoteca | 1d? | 2009-03-05 17:00 | 2009-03-06 17:00 | 25 | 0d | P1 | 8h |
| 30 | 1.4.2.1.5 | Contacto | 1.5d? | 2009-03-06 17:00 | 2009-03-10 11:00 | 29 | 0d | P1 | 12h |
| 31 | 1.4.2.1.6 | Despliegue de logos de Aliados | 0.5d? | 2009-03-10 11:00 | 2009-03-10 17:00 | 30 | 0d | P1 | 4h |
| 32 | 1.4.2.1.7 | Banners | 2.5d? | 2009-03-12 11:00 | 2009-03-16 17:00 | 79 | 0d | P1 | 20h |
| 33 | 1.4.2.1.8 | Pie de página | 0.25d? | 2009-03-17 11:00 | 2009-03-17 13:00 | 80 | 0d | P1 | 2h |
| 34 | 1.4.2.1.9 | Revisión por parte de Cyngular | 3d | 2009-03-17 15:00 | 2009-03-20 13:00 | 33 | 0d |  |  |
| 35 | 1.4.2.1.10 | Ajustes | 1d? | 2009-03-20 15:00 | 2009-03-23 13:00 | 34 | 0d | P1 | 8h |
| 36 | 1.4.2.1.11 | ENTREGA 1: SITIO WEB PÚBLICO en ambiente de desarrollo | 1d? | 2009-03-23 15:00 | 2009-03-24 13:00 | 35 | 0d |  |  |
| 37 | 1.4.2.2 | **Registro y secciones privadas** | 15d? | 2009-03-24 15:00 | 2009-04-16 13:00 |  | 0d |  | 88h |
| 38 | 1.4.2.2.1 | **Autenticación de usuario** | 2d? | 2009-03-24 15:00 | 2009-03-26 13:00 |  | 0d |  | 16h |
| 39 | 1.4.2.2.1.1 | Registro | 0.5d? | 2009-03-24 15:00 | 2009-03-24 19:00 | 12 | 0d | P1 | 4h |
| 40 | 1.4.2.2.1.2 | Ingreso de usuario | 0.5d? | 2009-03-25 09:00 | 2009-03-25 13:00 | 39 | 0d | P1 | 4h |
| 41 | 1.4.2.2.1.3 | Olvido de contraseña | 0.5d? | 2009-03-25 15:00 | 2009-03-25 19:00 | 40 | 0d | P1 | 4h |
| 42 | 1.4.2.2.1.4 | Detección de usuario autenticado | 0.5d? | 2009-03-26 09:00 | 2009-03-26 13:00 | 41 | 0d | P1 | 4h |
| 43 | 1.4.2.2.2 | **Autores** | 2d? | 2009-03-26 15:00 | 2009-03-30 13:00 |  | 0d |  | 16h |
| 44 | 1.4.2.2.2.1 | Listado de Autores | 1d? | 2009-03-26 15:00 | 2009-03-27 13:00 | 38 | 0d | P1 | 8h |
| 45 | 1.4.2.2.2.2 | Detalle de Autor | 1d? | 2009-03-27 15:00 | 2009-03-30 13:00 | 44 | 0d | P1 | 8h |
| 46 | 1.4.2.2.3 | **Eventos** | 2d? | 2009-03-30 15:00 | 2009-04-01 13:00 |  | 0d |  | 16h |
| 47 | 1.4.2.2.3.1 | Calendario Eventos | 0.5d? | 2009-03-30 15:00 | 2009-03-30 19:00 | 43 | 0d | P1 | 4h |
| 48 | 1.4.2.2.3.2 | Detalle Eventos | 0.5d? | 2009-03-31 09:00 | 2009-03-31 13:00 | 47 | 0d | P1 | 4h |
| 49 | 1.4.2.2.3.3 | Proposición de evento | 1d? | 2009-03-31 15:00 | 2009-04-01 13:00 | 48 | 0d | P1 | 8h |

| ID | WBS | Task | Duration | Start | Finish | Predecessors | Total slack | Free slack | Resources | Work |
| --- | --- | --- | --- | --- | --- | --- | --- | --- | --- | --- |
| 50 | 1.4.2.2.4 | **Noticias** | 1d? | 2009-04-01 15:00 | 2009-04-02 13:00 |  | 0d |  |  | 8h |
| 51 | 1.4.2.2.4.1 | Proposición de noticia | 1d? | 2009-04-01 15:00 | 2009-04-02 13:00 | 46 | 0d |  | P1 | 8h |
| 52 | 1.4.2.2.5 | **Novedades** | 1d? | 2009-04-02 15:00 | 2009-04-03 13:00 |  | 0d |  |  | 8h |
| 53 | 1.4.2.2.5.1 | Valoración para libros | 0.5d? | 2009-04-02 15:00 | 2009-04-02 19:00 | 50 | 0d |  | P1 | 4h |
| 54 | 1.4.2.2.5.2 | Comentarios para libros | 0.5d? | 2009-04-03 09:00 | 2009-04-03 13:00 | 53 | 0d |  | P1 | 4h |
| 55 | 1.4.2.2.6 | **Blogoteca** | 0.5d? | 2009-04-03 15:00 | 2009-04-03 19:00 |  | 0d |  |  | 4h |
| 56 | 1.4.2.2.6.1 | Recomendar blog al editor | 0.5d? | 2009-04-03 15:00 | 2009-04-03 19:00 | 52 | 0d |  | P1 | 4h |
| 57 | 1.4.2.2.7 | **El Librero** | 1.5d? | 2009-04-06 09:00 | 2009-04-07 13:00 |  | 0d |  |  | 12h |
| 58 | 1.4.2.2.7.1 | Edición reciente | 0.5d? | 2009-04-06 09:00 | 2009-04-06 13:00 | 55 | 0d |  | P1 | 4h |
| 59 | 1.4.2.2.7.2 | Ediciones anteriores | 1d? | 2009-04-06 15:00 | 2009-04-07 13:00 | 58 | 0d |  | P1 | 8h |
| 60 | 1.4.2.2.8 | Revisión por parte de Cyngular | 2d | 2009-04-07 15:00 | 2009-04-13 13:00 | 57 | 0d |  |  |  |
| 61 | 1.4.2.2.9 | Ajustes | 2d? | 2009-04-13 15:00 | 2009-04-15 13:00 | 60 | 0d |  | P1 [50%] | 8h |
| 62 | 1.4.2.2.10 | ENTREGA 2: SITIO WEB CON REGISTRO en ambiente de desarrollo | 1d? | 2009-04-15 15:00 | 2009-04-16 13:00 | 61 | 0d |  |  |  |
| 63 | 1.4.2.3 | **Suscripción** | 2d? | 2009-04-16 15:00 | 2009-04-20 13:00 |  | 0d |  |  | 8h |
| 64 | 1.4.2.3.1 | Formulario de suscripción | 1d? | 2009-04-16 15:00 | 2009-04-17 13:00 | 62 | 0d |  | P1 [50%] | 4h |
| 65 | 1.4.2.3.2 | Formulario para registro de pago | 1d? | 2009-04-17 15:00 | 2009-04-20 13:00 | 64 | 0d |  | P1 [50%] | 4h |
| 66 | 1.4.2.4 | Revisión por parte de Cyngular | 1d | 2009-04-20 15:00 | 2009-04-21 13:00 | 63 | 20.62d | 0d |  |  |
| 67 | 1.4.2.5 | Ajustes | 2d? | 2009-04-21 15:00 | 2009-04-23 13:00 | 66 | 20.62d | 0d | P1 [50%] | 8h |
| 68 | 1.4.2.6 | ENTREGA 3: SITIO WEB COMPLETO en ambiente de desarrollo | 1d? | 2009-04-23 15:00 | 2009-04-24 13:00 | 67 | 20.62d |  |  |  |
| 69 | 1.5 | **Backoffice** | 53.75d? | 2009-02-11 09:00 | 2009-05-04 17:00 |  | 0d |  |  | 139h |
| 70 | 1.5.1 | Manejo de Enlaces de interés | 0.25d? | 2009-02-11 09:00 | 2009-02-11 11:00 | 4 | 0d |  | P1 | 2h |
| 71 | 1.5.2 | Manejo de Noticias | 0.5d? | 2009-02-11 11:00 | 2009-02-11 17:00 | 70 | 0d |  | P1 | 4h |
| 72 | 1.5.3 | Manejo de Autores | 0.5d? | 2009-02-11 17:00 | 2009-02-12 11:00 | 71 | 0d |  | P1 | 4h |
| 73 | 1.5.4 | Manejo de Eventos | 1d? | 2009-02-12 11:00 | 2009-02-13 11:00 | 72 | 0d |  | P1 | 8h |
| 74 | 1.5.5 | Manejo de Libros | 1d? | 2009-02-13 11:00 | 2009-02-16 11:00 | 73 | 0d |  | P1 | 8h |
| 75 | 1.5.6 | Manejo de Números de El Librero | 1d? | 2009-02-16 11:00 | 2009-02-17 11:00 | 74 | 0d |  | P1 | 8h |
| 76 | 1.5.7 | Manejo de Blogs | 1d? | 2009-02-17 11:00 | 2009-02-18 11:00 | 75 | 0d |  | P1 | 8h |
| 77 | 1.5.8 | Manejo de Contactos | 1d? | 2009-02-18 11:00 | 2009-02-19 11:00 | 76 | 0d |  | P1 | 8h |
| 78 | 1.5.9 | Manejo de Aliados | 0.25d? | 2009-02-19 11:00 | 2009-02-19 13:00 | 77 | 0d |  | P1 | 2h |
| 79 | 1.5.10 | Administración de banners | 1.5d? | 2009-03-10 17:00 | 2009-03-12 11:00 | 31 | 0d |  | P1 | 12h |
| 80 | 1.5.11 | Contenido Pie de página | 0.5d? | 2009-03-16 17:00 | 2009-03-17 11:00 | 32 | 0d |  | P1 | 4h |
| 81 | 1.5.12 | Manejo de Usuarios registrados | 0.12d? | 2009-04-07 15:00 | 2009-04-07 16:00 | 59 | 10.12d | 0d | P1 | 1h |
| 82 | 1.5.13 | Módulo de manejo de contenido publicado por usuarios | 6d? | 2009-04-07 16:00 | 2009-04-17 16:00 | 81 | 10.12d |  | P1 [50%] | 24h |
| 83 | 1.5.14 | Manejo de Suscripciones | 3d? | 2009-04-20 15:00 | 2009-04-23 13:00 | 63 | 0d |  | P1 [50%] | 12h |
| 84 | 1.5.15 | Manejo de Pagos pendientes y aprobación de pagos | 4d? | 2009-04-23 15:00 | 2009-04-29 13:00 | 83 | 0d |  | P1 [50%] | 16h |
| 85 | 1.5.16 | Reportes básicos por tabla | 1.5d? | 2009-04-29 15:00 | 2009-04-30 19:00 | 84 | 0d |  | P1 | 12h |
| 86 | 1.5.17 | Administración de usuarios Backoffice | 0.25d? | 2009-05-04 09:00 | 2009-05-04 11:00 | 85 | 0d |  | P1 | 2h |
| 87 | 1.5.18 | Configuración de perfiles de usuarios del Backoffice | 0.5d? | 2009-05-04 11:00 | 2009-05-04 17:00 | 86 | 0d |  | P1 | 4h |
| 88 | 1.6 | Pruebas internas y ajustes | 2d? | 2009-05-04 17:00 | 2009-05-06 17:00 | 69 | 0d |  | P1 | 16h |
| 89 | 1.7 | Guia de Usuario | 3d? | 2009-05-06 17:00 | 2009-05-11 17:00 | 88 | 0d |  | P1 | 24h |
| 90 | 1.8 | Adiestramiento Usuario Backoffice | 0.25d? | 2009-05-11 17:00 | 2009-05-11 19:00 | 89 | 0d |  | P1; GP | 4h |
| 91 | 1.9 | Adiestramiento Administrador Backoffice | 0.12d? | 2009-05-12 09:00 | 2009-05-12 10:00 | 90 | 0d |  | P1; GP | 2h |
| 92 | 1.10 | Pruebas de Certificación de Cyngular | 5d | 2009-05-12 10:00 | 2009-05-19 10:00 | 91 | 0d |  |  |  |
| 93 | 1.11 | Ingreso de Contenido por parte de Cyngular | 5d | 2009-05-19 10:00 | 2009-05-26 10:00 | 92 | 0d |  |  |  |
| 94 | 1.12 | Ajustes | 2d? | 2009-05-19 10:00 | 2009-05-21 10:00 | 92 | 1.62d | 0d | P1 | 16h |
| 95 | 1.13 | Puesta en producción | 1d? | 2009-05-21 10:00 | 2009-05-22 10:00 | 94 | 1.62d | 0d | OP | 8h |
| 96 | 1.14 | Google analytics | 0.12d? | 2009-05-22 10:00 | 2009-05-22 11:00 | 95 | 1.88d |  | P1 | 1h |

| ID | WBS | Task | Duration | Start | Finish | Predecessors | Complete | Remaining | Total slack | Constraint | Resources | Work | Actual work |
| --- | --- | --- | --- | --- | --- | --- | --- | --- | --- | --- | --- | --- | --- |
| 97 | 1.15 | **Gerencia de proyectos** | 90.5d? | 2008-12-16 09:00 A | 2009-05-22 13:00 |  | 27% | 66.06d? | 1.62d |  |  | 90h | 26.2h |
| 98 | 1.15.1 | Planificación | 0.5d? | 2008-12-16 09:00 A | 2008-12-16 13:00 A |  | 100% |  |  |  | GP | 4h | 4h |
| 99 | 1.15.2 | Control y Seguimiento | 86.25d? | 2009-01-14 09:00 A | 2009-05-22 11:00 |  | 20% | 69d? | 1.88d | start no earlier than 2009-01-14 09:00 | GP [10%] | 69h | 13.8h |
| 100 | 1.15.3 | Levantamiento de Información | 17.5d? | 2009-01-23 09:00 A | 2009-02-17 13:00 |  | 60% | 7d? | 64.62d | start no earlier than 2009-01-14 09:00 | GP [10%] | 14h | 8.4h |
| 101 | 1.15.4 | Cierre (Acta y Reunión) | 0.38d? | 2009-05-22 10:00 | 2009-05-22 13:00 | 95 |  |  | 1.62d |  | GP | 3h |  |
