# Cronograma

Schedule from MS Project, 2008-10-03 to 2009-03-18, A marks actual dates.
KATET

## Calendars

- Estándar: Mon-Fri 09:00-13:00, 15:00-19:00; Sat-Sun off. Exceptions (off unless hours are given): 2008-12-15 to 2009-01-16.

## Resources

| Resource |
| --- |
| DR |
| OP |
| GP |

## Schedule

| ID | WBS | Task | Duration | Start | Finish | Predecessors | Complete | Remaining | Total slack | Free slack | Constraint | Resources | Work | Actual work |
| --- | --- | --- | --- | --- | --- | --- | --- | --- | --- | --- | --- | --- | --- | --- |
| 1 | 1 | **CRM Revensub** | 93.88d? | 2008-10-03 A | 2009-03-18 |  | 30% | 65.35d? | 0d |  |  |  | 363h | 113.2h |
| 2 | 1.1 | Análisis y modelaje de datos | 5d? | 2008-10-03 A | 2008-10-09 A |  | 100% |  |  |  | start no earlier than 2008-10-03 | DR [50%] | 20h | 20h |
| 3 | 1.2 | Documento de Especificaciones | 4d? | 2008-10-29 A | 2008-11-03 A |  | 100% |  |  |  | start no earlier than 2008-10-29 | DR [50%] | 16h | 16h |
| 4 | 1.3 | **Desarrollo** | 38.5d? | 2008-11-06 A | 2009-02-03 |  | 43% | 21.9d? | 0d |  |  |  | 160h | 66.4h |
| 5 | 1.3.1 | Validaciones Formularios | 5d? | 2008-11-06 A | 2008-11-12 A |  | 100% |  |  |  | start no earlier than 2008-11-06 | DR [50%] | 20h | 20h |
| 6 | 1.3.2 | Ajustes Nexus | 6d? | 2008-11-13 A | 2008-11-20 A | 5 | 100% |  |  |  |  | DR [50%] | 24h | 24h |
| 7 | 1.3.3 | Página Principal | 5d? | 2008-11-21 A | 2008-11-27 A | 6 | 100% |  |  |  |  | DR [50%] | 20h | 20h |
| 8 | 1.3.4 | Uso de plantillas | 6d? | 2008-11-28 A | 2008-12-05 | 7 | 10% | 5.4d? | 0d |  |  | DR [50%] | 24h | 2.4h |
| 9 | 1.3.5 | Asignación de Responsables | 3d? | 2008-12-08 | 2008-12-10 | 8 |  |  | 0d |  |  | DR [50%] | 12h |  |
| 10 | 1.3.6 | Mis Tareas | 2d? | 2008-12-11 | 2008-12-12 | 9 |  |  | 0d |  |  | DR [50%] | 8h |  |
| 11 | 1.3.7 | Vista extendida Empresas | 1.5d? | 2009-01-19 | 2009-01-20 | 10 |  |  | 0d |  |  | DR [50%] | 6h |  |
| 12 | 1.3.8 | Vista extendida Contactos | 1.5d? | 2009-01-20 | 2009-01-21 | 11 |  |  | 0d |  |  | DR [50%] | 6h |  |
| 13 | 1.3.9 | Vista extendida Eventos | 1.5d? | 2009-01-22 | 2009-01-23 | 12 |  |  | 0d |  |  | DR [50%] | 6h |  |
| 14 | 1.3.10 | Ingreso de Tareas a Interacicones, Eventos y Empresas | 3d? | 2009-01-23 | 2009-01-28 | 13 |  |  | 0d |  |  | DR [50%] | 12h |  |
| 15 | 1.3.11 | Historial de cambios en tablas | 1d? | 2009-01-28 | 2009-01-29 | 14 |  |  | 0d |  |  | DR [50%] | 4h |  |
| 16 | 1.3.12 | Perfiles de acceso | 2d? | 2009-01-29 | 2009-02-02 | 15 |  |  | 0d |  |  | DR [50%] | 8h |  |
| 17 | 1.3.13 | Manejo Multiempresa | 1d? | 2009-02-02 | 2009-02-03 | 16 |  |  | 0d |  |  |  | 10h |  |
| 18 | 1.4 | **Reportes** | 6d? | 2009-02-03 | 2009-02-11 |  |  |  | 0d |  |  |  | 24h |  |
| 19 | 1.4.1 | Gestión de usuarios | 4d? | 2009-02-03 | 2009-02-09 | 4 |  |  | 0d |  |  | DR [50%] | 16h |  |
| 20 | 1.4.2 | Prospectos | 2d? | 2009-02-09 | 2009-02-11 | 19 |  |  | 0d |  |  | DR [50%] | 8h |  |
| 21 | 1.5 | Carga de datos de Contactos | 2d? | 2009-02-11 | 2009-02-13 | 18 |  |  | 0.38d | 0d |  | DR [50%] | 8h |  |
| 22 | 1.6 | Guia de Usuario | 4d? | 2009-02-13 | 2009-02-19 | 21 |  |  | 0.38d | 0d |  | DR [50%] | 16h |  |
| 23 | 1.7 | Certificación Cliente | 10d | 2009-02-19 | 2009-03-05 | 22 |  |  | 0.38d | 0d |  |  | 40h |  |
| 24 | 1.8 | Ajustes | 4d? | 2009-03-05 | 2009-03-11 | 23 |  |  | 0.38d | 0d |  | DR [50%] | 16h |  |
| 25 | 1.9 | Documentación Técnica | 5d? | 2009-03-11 | 2009-03-18 | 24 |  |  | 0.38d |  |  | DR [40%] | 16h |  |
| 26 | 1.10 | Puesta en Producción | 5d? | 2009-03-11 | 2009-03-18 | 24 |  |  | 0.38d |  |  | DR [10%]; OP [50%] | 8h |  |

| ID | WBS | Task | Duration | Start | Finish | Predecessors | Complete | Remaining | Total slack | Constraint | Resources | Work | Actual work |
| --- | --- | --- | --- | --- | --- | --- | --- | --- | --- | --- | --- | --- | --- |
| 27 | 1.11 | **Gerencia de Proyectos** | 31.38d? | 2009-02-03 A | 2009-03-18 | 20 | 30% | 22.08d? | 0d |  |  | 39h | 10.8h |
| 28 | 1.11.1 | Control y Seguimiento | 30d? | 2009-02-03 A | 2009-03-18 | 3 | 30% | 21d? | 0d | start no earlier than 2008-11-06 | GP [15%] | 36h | 10.8h |
| 29 | 1.11.2 | Cierre | 0.38d? | 2009-03-18 | 2009-03-18 | 28 |  |  | 0d |  | GP | 3h |  |
