# Cronograma

Schedule from MS Project, 2008-10-06 to 2008-12-03, A marks actual dates.
KATET

## Calendars

- Estándar: Mon-Fri 09:00-13:00, 15:00-19:00; Sat-Sun off.

## Resources

| Resource |
| --- |
| DR |
| OP |
| GP |

## Schedule

| ID | WBS | Task | Duration | Start | Finish | Predecessors | Complete | Remaining | Total slack | Constraint | Resources | Work | Actual work |
| --- | --- | --- | --- | --- | --- | --- | --- | --- | --- | --- | --- | --- | --- |
| 1 | 1 | **CRM HiveFoods** | 43d? | 2008-10-06 A | 2008-12-03 |  | 91% | 3.66d? | 0d |  |  | 175h | 156h |
| 2 | 1.1 | Ajustes Registro Sanitario | 2d? | 2008-10-06 A | 2008-10-07 A |  | 100% |  |  | start no earlier than 2008-10-06 | DR [50%] | 8h | 8h |
| 3 | 1.2 | Inclusión de Importador | 4d? | 2008-10-08 A | 2008-10-13 A | 2 | 100% |  |  |  | DR [50%] | 16h | 16h |
| 4 | 1.3 | Inclusión de Presentación | 4d? | 2008-10-14 A | 2008-10-17 A | 3 | 100% |  |  |  | DR [50%] | 16h | 16h |
| 5 | 1.4 | Proceso de Análisis de Laboratorio | 5d? | 2008-10-20 A | 2008-10-24 A | 4 | 100% |  |  |  | DR [50%] | 20h | 20h |
| 6 | 1.5 | Registro y proceso de CPE | 5d? | 2008-10-27 A | 2008-11-03 A | 5 | 100% |  |  |  | DR [50%] | 20h | 20h |
| 7 | 1.6 | Reportes | 5d? | 2008-11-03 A | 2008-11-10 A | 6 | 100% |  |  |  | DR [50%] | 20h | 20h |
| 8 | 1.7 | Alarmas | 5d? | 2008-11-10 A | 2008-11-14 A | 7 | 100% |  |  |  | DR [50%] | 20h | 20h |
| 9 | 1.8 | Pruebas y ajustes | 3d? | 2008-11-17 A | 2008-11-19 A | 8 | 100% |  |  |  | DR [50%] | 12h | 12h |
| 10 | 1.9 | Documento Guía de Usuario | 4d? | 2008-11-20 A | 2008-11-25 A | 9 | 100% |  |  |  | DR [50%] | 16h | 16h |
| 11 | 1.10 | Pruebas de Certificación del Cliente | 4d | 2008-11-26 A | 2008-12-01 A | 10 | 100% |  |  |  |  |  |  |
| 12 | 1.11 | Documento Técnico | 4d? | 2008-11-26 A | 2008-12-01 | 10 | 50% | 2d? | 0d |  | DR [50%] | 16h | 8h |
| 13 | 1.12 | Puesta en Producción | 1d? | 2008-12-02 | 2008-12-02 | 12 |  |  | 0d |  | OP | 8h |  |
| 14 | 1.13 | Cierre | 1d? | 2008-12-03 | 2008-12-03 | 13 |  |  | 0d |  | GP [37.5%] | 3h |  |
