# Planning Cines Unidos baseline

Schedule from MS Project, 2007-05-03 to 2008-02-22.
Globalwebtek Venezuela C.A.

## Calendars

- Estándar: Mon-Fri 09:00-13:00, 15:00-19:00; Sat-Sun off. Exceptions (off unless hours are given): 2007-07-05, 2007-07-24, 2007-10-12, 2007-12-24 to 2007-12-25, 2007-12-31.

## Resources

| Resource |
| --- |
| LR |
| AB |
| JP |
| OP |
| HR |
| GS |
| VR |
| GP |
| K1 |
| K2 |
| R3 |
| R4 |
| AP |

## Schedule

| ID | WBS | Task | Duration | Start | Finish | Predecessors | Total slack | Free slack | Constraint | Resources | Work |
| --- | --- | --- | --- | --- | --- | --- | --- | --- | --- | --- | --- |
| 1 | 1 | **Cines Unidos** | 205.5d | 2007-05-03 | 2008-02-22 |  | 0d |  |  |  | 5146h |
| 2 | 1.1 | Reunión de Arranque (Kickoff) | 0.25d | 2007-05-03 | 2007-05-03 |  | 205.12d |  | start no earlier than 2007-05-03 | LR; GS; VR; GP | 8h |
| 3 | 1.2 | **Etapa I - Preparandonos para la Independencia** | 101.1d | 2007-05-04 | 2007-09-26 |  | 98.89d |  |  |  | 2670h |
| 4 | 1.2.1 | **Fase I - Levantamiento de Información** | 30d | 2007-05-04 | 2007-06-15 |  | 174.38d |  |  |  | 450h |
| 5 | 1.2.1.1 | Levantamiento Info (Visita al Cine) | 0.5d | 2007-05-04 | 2007-05-04 |  | 203.88d |  | start no earlier than 2007-05-04 | LR; AB; OP; GS; VR; GP | 24h |
| 6 | 1.2.1.2 | Inducción Cines Unidos | 2d | 2007-05-09 | 2007-05-11 |  | 199.38d |  | start no earlier than 2007-05-09 | AB [50%]; JP [50%]; LR [50%] | 24h |
| 7 | 1.2.1.3 | Presentación N2C y CRM | 0.38d | 2007-05-09 | 2007-05-09 |  | 201d |  | start no earlier than 2007-05-09 | GP; HR; VR | 9h |
| 8 | 1.2.1.4 | **Modelo de Procesos** | 7.5d | 2007-05-14 | 2007-05-23 |  | 190.88d |  |  |  | 64h |
| 9 | 1.2.1.4.1 | Preparación para Mesas de Trabajo | 0.25d | 2007-05-14 | 2007-05-14 |  | 198.12d |  | start no earlier than 2007-05-14 | LR; JP; AB; GP | 8h |
| 10 | 1.2.1.4.2 | Mesa de Trabajo # 1 | 0.5d | 2007-05-15 | 2007-05-15 |  | 196.88d |  | start no earlier than 2007-05-15 | LR; GP; JP; AB | 16h |
| 11 | 1.2.1.4.3 | Mesa de Trabajo # 2 | 0.5d | 2007-05-17 | 2007-05-17 |  | 194.88d |  | start no earlier than 2007-05-17 | LR; AB; GP; JP | 16h |
| 12 | 1.2.1.4.4 | Mesa de Trabajo # 3 | 0.5d | 2007-05-23 | 2007-05-23 |  | 190.88d |  | start no earlier than 2007-05-23 | GP; LR; AB; JP | 16h |
| 13 | 1.2.1.4.5 | Documentación Modelo de Procesos | 4d | 2007-05-17 | 2007-05-23 |  | 191.38d |  | start no earlier than 2007-05-17 | GP [25%] | 8h |
| 14 | 1.2.1.5 | **Modelo de Datos** | 9.88d | 2007-05-22 | 2007-06-04 |  | 182.5d |  |  |  | 72h |
| 15 | 1.2.1.5.1 | Análisis Modelo de Datos Actual | 0.25d | 2007-05-22 | 2007-05-22 |  | 192.12d |  | start no earlier than 2007-05-22 | LR; AB; JP; GP | 8h |
| 16 | 1.2.1.5.2 | Elaboración Modelo de Datos Preliminar | 1d | 2007-05-24 | 2007-05-25 |  | 189.38d |  | start no earlier than 2007-05-24 | LR [50%]; AB [50%]; GP [50%]; JP [50%] | 16h |
| 17 | 1.2.1.5.3 | Mesa de Trabajo - Kernel | 0.5d | 2007-05-30 | 2007-05-30 |  | 185.88d |  | start no earlier than 2007-05-30 | LR; AB; JP; GP; K1; K2 | 24h |
| 18 | 1.2.1.5.4 | Mesa de Trabajo # 4 (Sist CU - GWT) | 0.5d | 2007-05-31 | 2007-05-31 |  | 181.88d | 0d | start no earlier than 2007-05-31 | LR; GP; AB; JP | 16h |
| 19 | 1.2.1.5.5 | Ajustes al Modelo | 2d | 2007-06-01 | 2007-06-04 |  | 182.5d |  | finish no earlier than 2007-06-04 | LR [50%] | 8h |
| 20 | 1.2.1.6 | **Configuración Ambiente de Desarrollo** | 10d | 2007-05-29 | 2007-06-12 |  | 177.38d |  |  |  | 152h |
| 21 | 1.2.1.6.1 | Análisis Req. Adiestramiento configuración e instalación de Vista y MegaSoft | 2d | 2007-05-29 | 2007-05-31 |  | 185.38d |  | start no earlier than 2007-05-29 | LR; AB; OP; JP | 64h |
| 22 | 1.2.1.6.2 | Instalación y configuración de ambiente a imágen y semejanza de ambiente de producción de Cines Unidos | 6d | 2007-06-04 | 2007-06-12 |  | 177.38d |  | start no earlier than 2007-06-04 | OP [75%]; AB [75%] | 72h |
| 23 | 1.2.1.6.3 | Configuración de VPN para acceso remoto | 5.33d | 2007-06-04 | 2007-06-11 |  | 178.04d |  | start no earlier than 2007-06-04 | OP [25%]; AB [20%] | 16h |
| 24 | 1.2.1.7 | **Infraestructura a Futuro** | 20d | 2007-05-14 | 2007-06-11 |  | 178.38d |  |  |  | 77h |
| 25 | 1.2.1.7.1 | Investigación de requerimientos de infraestructura | 15d | 2007-05-14 | 2007-06-04 |  | 178.38d | 0d | start no earlier than 2007-05-14 | AP [50%] | 60h |
| 26 | 1.2.1.7.2 | Elaborar informe | 5d | 2007-06-04 | 2007-06-11 | 25 | 178.38d |  |  | AP [42.5%] | 17h |

| ID | WBS | Task | Type | Duration | Start | Finish | Predecessors | Total slack | Free slack | Constraint | Resources | Work |
| --- | --- | --- | --- | --- | --- | --- | --- | --- | --- | --- | --- | --- |
| 27 | 1.2.1.8 | **Informe de Especificación de Requerimientos** |  | 10.5d | 2007-05-31 | 2007-06-15 |  | 174.38d |  |  |  | 28h |
| 28 | 1.2.1.8.1 | Elaboración del Informe de Especificación de Requerimientos |  | 3d | 2007-05-31 | 2007-06-05 | 18 | 181.88d | 0d |  | LR [69.4%]; GP [15%] | 20h |
| 29 | 1.2.1.8.2 | Entrega al Equipo de Proyecto CU para su revisión | milestone | 0d | 2007-06-05 | 2007-06-05 | 28 | 181.88d |  | start no earlier than 2006-12-01 | GP |  |
| 30 | 1.2.1.8.3 | Revisión por parte del Equipo de Proyecto CU |  | 2d | 2007-06-06 | 2007-06-08 |  | 173.38d | 0.88d | start no earlier than 2007-06-06 |  |  |
| 31 | 1.2.1.8.4 | Ajustes al Informe Especificación de Requerimientos |  | 2d | 2007-06-11 | 2007-06-12 | 30 | 172.5d | 0d | finish no earlier than 2007-06-12 | LR [45.7%]; GP [7.8%] | 8h |
| 32 | 1.2.1.8.5 | Entrega de Especificación de Req. para aprobación | milestone | 0d | 2007-06-12 | 2007-06-12 | 31 | 172.5d | 2.12d | start no earlier than 2006-12-07 | GP |  |
| 33 | 1.2.1.8.6 | Aprobación del Informe Especificación de Requerimientos | milestone | 0d | 2007-06-15 | 2007-06-15 | 32 | 170.38d | 0d | start no earlier than 2007-06-15 |  |  |
| 34 | 1.2.2 | Informe Especificación de Requerimientos Aprobado | milestone | 0d | 2007-06-15 | 2007-06-15 | 33 | 174.38d |  |  |  |  |
| 35 | 1.2.3 | Modelo de Procesos Definido | milestone | 0d | 2007-06-15 | 2007-06-15 | 33 | 174.38d |  |  |  |  |
| 36 | 1.2.4 | Modelo de Datos Definido | milestone | 0d | 2007-06-15 | 2007-06-15 | 33 | 170.38d | 0d |  |  |  |
| 37 | 1.2.5 | Informe Infraestructura y Crecimiento Futuro | milestone | 0d | 2007-06-15 | 2007-06-15 | 33 | 174.38d |  |  |  |  |
| 38 | 1.2.6 | **Fase II - Conformación de las bases** |  | 38.5d | 2007-06-06 | 2007-08-01 |  | 124.88d |  |  |  | 546h |
| 39 | 1.2.6.1 | **Directorio de Clientes y CRM** |  | 13d | 2007-06-06 | 2007-06-25 |  | 124.88d |  |  |  | 250h |
| 40 | 1.2.6.1.1 | Análisis de Base de Datos de Clientes y Transacciones del proveedor actual (BD) |  | 0.5d | 2007-06-06 | 2007-06-06 |  | 180.88d |  | start no earlier than 2007-06-06 | LR; AB; JP; GP; HR | 20h |
| 41 | 1.2.6.1.2 | Equivalencia entre la base de datos del Proveedor Actual vs. lo levantado |  | 0.5d | 2007-06-07 | 2007-06-07 |  | 169.88d | 0d | start no earlier than 2007-06-07 | LR; AB; JP; GP; HR | 20h |
| 42 | 1.2.6.1.3 | Crear en N2C la nueva estructura de la B.D de Clientes |  | 1d | 2007-06-07 | 2007-06-08 | 41 | 2.88d | 0d |  | OP [90%]; AB [90%]; LR | 18h |
| 43 | 1.2.6.1.4 | Configuración Directorio de Clientes |  | 4d | 2007-06-08 | 2007-06-14 | 42 | 169.88d | 0d |  | LR [10.2%]; JP [89.8%] | 32h |
| 44 | 1.2.6.1.5 | Carga inicial de datos de Clientes y Transacciones en N2C |  | 3d | 2007-06-14 | 2007-06-19 | 43 | 169.88d | 0d |  | LR [81.4%]; GP [4.1%]; JP [81.2%] | 40h |
| 45 | 1.2.6.1.6 | Implementar mecanismo de carga diaria de datos provenientes del Proveedor Actual a Cines Unidos |  | 1d | 2007-06-19 | 2007-06-20 | 44 | 169.88d | 0d |  | LR; AB | 16h |
| 46 | 1.2.6.1.7 | Implementar facilidad de monitoreo quincenal de los datos para su depuración |  | 1d | 2007-06-20 | 2007-06-21 | 45 | 169.88d |  |  | LR; AB; JP | 24h |
| 47 | 1.2.6.1.8 | Envio de correos masivos con políticas de colas y administración de mensajes devueltos |  | 4d | 2007-06-15 | 2007-06-21 | 36 | 170.38d |  |  | K1 [50%]; K2 [50%] | 32h |
| 48 | 1.2.6.1.9 | **Reportes de Clientes** |  | 7d | 2007-06-14 | 2007-06-25 |  | 118.88d |  |  |  | 48h |
| 49 | 1.2.6.1.9.1 | Implementación de 10 reportes básicos |  | 4d | 2007-06-14 | 2007-06-20 |  | 10.88d | 0d | start no earlier than 2007-06-14 | JP; LR [15%] | 24h |
| 50 | 1.2.6.1.9.2 | Implementación de 3 reportes estadísticos |  | 3d | 2007-06-20 | 2007-06-25 | 49 | 118.88d | 0d |  | LR [8.9%]; JP [91.1%] | 24h |
| 51 | 1.2.6.2 | CRM |  | 16d | 2007-06-25 | 2007-07-18 | 50 | 118.88d | 0d |  | JP; LR [25%] | 160h |

| ID | WBS | Task | Type | Duration | Start | Finish | Predecessors | Total slack | Free slack | Constraint | Resources | Work |
| --- | --- | --- | --- | --- | --- | --- | --- | --- | --- | --- | --- | --- |
| 52 | 1.2.6.3 | **Implantación** |  | 9.5d | 2007-07-18 | 2007-08-01 |  | 118.88d |  |  |  | 136h |
| 53 | 1.2.6.3.1 | Pruebas internas |  | 2d | 2007-07-18 | 2007-07-20 | 51 | 148.38d | 0d |  | LR; GP | 32h |
| 54 | 1.2.6.3.2 | Ajustes recomendados |  | 2d | 2007-07-20 | 2007-07-25 | 53 | 148.38d |  |  | JP | 16h |
| 55 | 1.2.6.3.3 | Documentación |  | 5d | 2007-07-18 | 2007-07-26 | 51 | 118.88d | 0d |  | LR [66.7%]; GP [50%] | 40h |
| 56 | 1.2.6.3.4 | Adiestramiento |  | 1.5d | 2007-07-26 | 2007-07-27 | 55 | 118.88d | 0d |  | LR; GP | 24h |
| 57 | 1.2.6.3.5 | Pruebas de Certificación |  | 3d | 2007-07-27 | 2007-08-01 | 56 | 118.88d | 0d |  | LR [50%]; JP [50%] | 24h |
| 58 | 1.2.7 | Directorios de Clientes implantado | milestone | 0d | 2007-08-01 | 2007-08-01 | 57 | 142.88d |  |  |  |  |
| 59 | 1.2.8 | Reportes y Estadísticas de Clientes implantado | milestone | 0d | 2007-08-01 | 2007-08-01 | 57 | 142.88d |  |  |  |  |
| 60 | 1.2.9 | CRM implantado | milestone | 0d | 2007-08-01 | 2007-08-01 | 57 | 142.88d |  |  |  |  |
| 61 | 1.2.10 | Adiestramiento Asterisk |  | 3d | 2007-06-18 | 2007-06-21 |  | 170.38d |  | start no earlier than 2007-06-18 |  |  |
| 62 | 1.2.11 | **Fase III - Integración** |  | 62.1d | 2007-06-21 | 2007-09-19 |  | 64.89d |  |  |  | 1490h |
| 63 | 1.2.11.1 | Vista |  | 40d | 2007-06-21 | 2007-08-20 |  | 113.38d | 0d | start no earlier than 2007-06-21 | AB; LR [47.5%]; R3 | 650h |
| 64 | 1.2.11.2 | MegaSoft |  | 24d | 2007-08-01 | 2007-09-04 | 57 | 118.88d |  |  | LR; R4; JP | 480h |
| 65 | 1.2.11.3 | Pagina Web |  | 15.5d | 2007-08-01 | 2007-09-11 |  | 114.5d |  | start no earlier than 2007-08-01 | R3; LR; GP [79.9%] | 200h |
| 66 | 1.2.11.4 | **Implantación** |  | 22.1d | 2007-08-20 | 2007-09-19 |  | 24.89d |  |  |  | 160h |
| 67 | 1.2.11.4.1 | Pruebas internas |  | 15d | 2007-08-20 | 2007-09-10 | 63 | 113.38d | 0d |  | LR [6.7%]; GP [6.7%] | 16h |
| 68 | 1.2.11.4.2 | Ajustes recomendados |  | 2d | 2007-09-10 | 2007-09-12 | 67 | 113.38d |  |  | AB [83.3%]; JP [83.3%]; R3 [83.3%] | 40h |
| 69 | 1.2.11.4.3 | Documentación |  | 15d | 2007-08-20 | 2007-09-10 | 63 | 115.38d |  |  | LR [16.7%]; GP [16.7%] | 40h |
| 70 | 1.2.11.4.4 | Adiestramiento |  | 1.1d | 2007-09-13 | 2007-09-14 |  | 6.89d | 0d | start no earlier than 2007-09-13 | LR; GP; AB | 24h |
| 71 | 1.2.11.4.5 | Pruebas de Certificación |  | 3d | 2007-09-14 | 2007-09-19 | 70 | 108.28d | 0d |  | AB [33.3%]; LR [33.3%]; JP [33.3%]; R3 [33.3%]; R4 [33.3%] | 40h |
| 72 | 1.2.12 | N2C y Vista Integrados | milestone | 0d | 2007-09-19 | 2007-09-19 | 71 | 108.28d |  |  |  |  |
| 73 | 1.2.13 | N2C y Merchant integrados | milestone | 0d | 2007-09-19 | 2007-09-19 | 71 | 108.28d |  |  |  |  |
| 74 | 1.2.14 | N2C y Página web integrados | milestone | 0d | 2007-09-19 | 2007-09-19 | 71 | 108.28d |  |  |  |  |
| 75 | 1.2.15 | **Fase IV - Independencia** |  | 8d | 2007-09-14 | 2007-09-26 |  | 6.89d |  |  |  | 184h |
| 76 | 1.2.15.1 | Pruebas Independencia |  | 5d | 2007-09-14 | 2007-09-21 | 70 | 6.89d | 0d |  | LR; AB; JP; GP | 160h |
| 77 | 1.2.15.2 | Independizarse del proveedor actual |  | 3d | 2007-09-21 | 2007-09-26 | 76 | 6.89d | 0d |  | LR [33.3%]; AB [33.3%]; JP [33.3%] | 24h |
| 78 | 1.2.16 | Cines Unidos independizado de Proveedor Actual | milestone | 0d | 2007-09-26 | 2007-09-26 | 77 | 2.28d | 0d |  |  |  |

| ID | WBS | Task | Type | Duration | Start | Finish | Predecessors | Total slack | Free slack | Constraint | Resources | Work |
| --- | --- | --- | --- | --- | --- | --- | --- | --- | --- | --- | --- | --- |
| 79 | 1.3 | **Etapa II - Hacia al e_Business** |  | 56.38d | 2007-09-26 | 2007-12-14 |  | 6.89d |  |  |  | 1042h |
| 80 | 1.3.1 | Cartelera Cinematográfica |  | 12d | 2007-09-26 | 2007-10-15 | 78 | 67.28d | 0d |  | R3; LR [25%] | 120h |
| 81 | 1.3.2 | Integración Call Center |  | 30d | 2007-09-26 | 2007-11-08 | 78 | 6.89d | 0d |  | JP [64.1%]; LR [19.2%] | 200h |
| 82 | 1.3.3 | Integración con Asterisk (**) |  | 13d | 2007-11-08 | 2007-11-27 | 81 | 60.28d |  |  | OP [80.1%]; JP [80.1%]; LR [80.1%] | 250h |
| 83 | 1.3.4 | Integración Tienda Cines Unidos |  | 24d | 2007-10-15 | 2007-11-16 | 80 | 67.28d |  |  | R3 [62.5%]; LR [26%] | 100h |
| 84 | 1.3.5 | Integración Taquilla |  | 15.38d | 2007-11-08 | 2007-11-29 | 81 | 6.89d | 0d |  | LR [62.5%]; R3 | 200h |
| 85 | 1.3.6 | Pruebas internas |  | 2.5d | 2007-11-29 | 2007-12-04 | 84 | 6.89d | 0d |  | LR; GP | 40h |
| 86 | 1.3.7 | Documentación |  | 2.5d | 2007-12-04 | 2007-12-06 | 85 | 6.89d | 0d |  | LR; GP | 40h |
| 87 | 1.3.8 | Adiestramiento |  | 2d | 2007-12-06 | 2007-12-10 | 86 | 6.89d | 0d |  | LR; GP | 32h |
| 88 | 1.3.9 | Pruebas de Certificación |  | 4d | 2007-12-10 | 2007-12-14 | 87 | 6.89d | 0d |  | LR [62.5%]; JP [62.5%]; R3 [62.5%] | 60h |
| 89 | 1.3.10 | Cartelera Cinematográfica implantada | milestone | 0d | 2007-12-14 | 2007-12-14 | 88 | 46.89d |  |  |  |  |
| 90 | 1.3.11 | Integración Call Center implantado | milestone | 0d | 2007-12-14 | 2007-12-14 | 88 | 46.89d |  |  |  |  |
| 91 | 1.3.12 | Integración Tienda Cines Unidos implantado | milestone | 0d | 2007-12-14 | 2007-12-14 | 88 | 6.89d | 0d |  |  |  |
| 92 | 1.4 | **Etapa III - Inteligencia de Negocio** |  | 40d | 2007-12-14 | 2008-02-13 |  | 6.89d |  |  |  | 548h |
| 93 | 1.4.1 | Integración con InfoWorks |  | 40d | 2007-12-14 | 2008-02-13 | 91 | 6.89d |  | start no earlier than 2007-11-01 | LR [70.3%]; JP [70.3%] | 450h |
| 94 | 1.4.2 | Evaluación tecnológica de Pentaho |  | 10d | 2007-12-14 | 2008-01-02 | 91 | 36.89d |  | start no earlier than 2007-11-01 | GS [30.6%]; HR [30.6%]; LR [30.6%]; GP [30.6%] | 98h |
| 95 | 1.5 | Gerencia de Proyectos |  | 205d | 2007-05-03 | 2008-02-21 |  | 0d |  | finish no earlier than 2008-02-21 | GP [30%]; GS [16.2%]; HR [4.9%]; VR [5.4%] | 870h |
| 96 | 1.6 | Cierre |  | 0.5d | 2008-02-22 | 2008-02-22 | 95 | 0d |  |  | LR [54.5%]; GP [55%]; GS [54.5%]; VR [54.5%] | 8h |
