# Futsal

Schedule from MS Project, 2009-02-19 to 2009-04-30.
gm

## Calendars

- Estándar: Mon-Fri 09:00-13:00, 15:00-19:00; Sat-Sun off.

## Resources

| Resource |
| --- |
| Operaciones |
| R1 |
| r2 |

## Schedule

| ID | WBS | Task | Duration | Start | Finish | Predecessors | Total slack | Constraint | Resources | Work |
| --- | --- | --- | --- | --- | --- | --- | --- | --- | --- | --- |
| 1 | 1 | **Futsal** | 51d? | 2009-02-19 09:00 | 2009-04-30 19:00 |  | 0d |  |  | 560h |
| 2 | 1.1 | Preparación ambiente | 4h | 2009-03-02 09:00 | 2009-03-02 13:00 |  | 43.5d | start no earlier than 2009-03-02 09:00 | Operaciones | 4h |
| 3 | 1.2 | Análisis | 40h | 2009-03-02 09:00 | 2009-03-06 19:00 |  | 0d | start no earlier than 2009-03-02 09:00 | R1 | 40h |
| 4 | 1.3 | Diseño Gráfico | 120h | 2009-03-04 09:00 | 2009-03-24 19:00 |  | 27d | start no earlier than 2009-03-04 09:00 | r2 | 120h |
| 5 | 1.4 | Diseño Datos y Sistema | 40h | 2009-03-09 09:00 | 2009-03-13 19:00 | 3 | 0d |  | R1 | 40h |
| 6 | 1.5 | **Construcción** | 51d? | 2009-02-19 09:00 | 2009-04-30 19:00 |  | 0d |  |  | 356h |
| 7 | 1.5.1 | **Programación Site** | 7.5d | 2009-03-16 09:00 | 2009-03-25 13:00 |  | 0d |  |  | 60h |
| 8 | 1.5.1.1 | FAQ | 4h | 2009-03-16 09:00 | 2009-03-16 13:00 | 5 | 0d |  | R1 | 4h |
| 9 | 1.5.1.2 | Contactenos | 4h | 2009-03-16 15:00 | 2009-03-16 19:00 | 8 | 0d |  | R1 | 4h |
| 10 | 1.5.1.3 | Botón Pago | 32h | 2009-03-17 09:00 | 2009-03-20 19:00 | 9 | 0d |  | R1 | 32h |
| 11 | 1.5.1.4 | Banner | 4h | 2009-03-23 09:00 | 2009-03-23 13:00 | 10 | 0d |  | R1 | 4h |
| 12 | 1.5.1.5 | Noticias | 4h | 2009-03-23 15:00 | 2009-03-23 19:00 | 11 | 0d |  | R1 | 4h |
| 13 | 1.5.1.6 | Blog | 4h | 2009-03-24 09:00 | 2009-03-24 13:00 | 12 | 0d |  | R1 | 4h |
| 14 | 1.5.1.7 | Eventos | 4h | 2009-03-24 15:00 | 2009-03-24 19:00 | 13 | 0d |  | R1 | 4h |
| 15 | 1.5.1.8 | navegación | 4h | 2009-03-25 09:00 | 2009-03-25 13:00 | 14 | 0d |  | R1 | 4h |
| 16 | 1.5.2 | **Programación Backoffice** | 15d? | 2009-03-25 15:00 | 2009-04-15 13:00 |  | 0d |  |  | 120h |
| 17 | 1.5.2.1 | Reservaciones | 40h | 2009-03-25 15:00 | 2009-04-01 13:00 | 15 | 0d |  | R1 | 40h |
| 18 | 1.5.2.2 | gestión Academia | 16h | 2009-04-01 15:00 | 2009-04-03 13:00 | 17 | 0d |  | R1 | 16h |
| 19 | 1.5.2.3 | gestión Futbolada | 16h | 2009-04-03 15:00 | 2009-04-07 13:00 | 18 | 0d |  | R1 | 16h |
| 20 | 1.5.2.4 | gestión Alquiler Canchas | 8h? | 2009-04-07 15:00 | 2009-04-08 13:00 | 19 | 0d |  | R1 | 8h |
| 21 | 1.5.2.5 | Gestión Plan Vacacional | 8h? | 2009-04-08 15:00 | 2009-04-09 13:00 | 20 | 0d |  | R1 | 8h |
| 22 | 1.5.2.6 | Gestión Torneos | 16h | 2009-04-09 15:00 | 2009-04-13 13:00 | 21 | 0d |  | R1 | 16h |
| 23 | 1.5.2.7 | Pagos | 16h | 2009-04-13 15:00 | 2009-04-15 13:00 | 22 | 0d |  | R1 | 16h |
| 24 | 1.5.3 | **Pogramación Extranet** | 3.5d | 2009-04-15 15:00 | 2009-04-20 19:00 |  | 0d |  |  | 28h |
| 25 | 1.5.3.1 | Inscripciones a los distintos eventos | 4h | 2009-04-15 15:00 | 2009-04-15 19:00 | 23 | 0d |  | R1 | 4h |
| 26 | 1.5.3.2 | Enlace a Pagos por tipo evento | 4h | 2009-04-16 09:00 | 2009-04-16 13:00 | 25 | 0d |  | R1 | 4h |
| 27 | 1.5.3.3 | Cosnulta de reservacione sy pagos | 4h | 2009-04-16 15:00 | 2009-04-16 19:00 | 26 | 0d |  | R1 | 4h |
| 28 | 1.5.3.4 | Consulta torneos, fotos | 8h | 2009-04-17 09:00 | 2009-04-17 19:00 | 27 | 0d |  | R1 | 8h |
| 29 | 1.5.3.5 | Comentarios y galerías fotos | 8h | 2009-04-20 09:00 | 2009-04-20 19:00 | 28 | 0d |  | R1 | 8h |
| 30 | 1.5.4 | Pruebas Internas | 16h | 2009-04-21 09:00 | 2009-04-22 19:00 | 29 | 0d |  | R1 | 16h |
| 31 | 1.5.5 | Pruebas Certificación | 32h | 2009-04-23 09:00 | 2009-04-28 19:00 | 30 | 0d |  | R1 | 32h |
| 32 | 1.5.6 | Documentación | 8h | 2009-04-29 09:00 | 2009-04-29 19:00 | 31 | 0d | start no earlier than 2009-03-10 09:00 | R1 | 8h |
| 33 | 1.5.7 | Adiestramiento | 8h | 2009-04-30 09:00 | 2009-04-30 19:00 | 32 | 0d |  | R1 | 8h |
| 34 | 1.5.8 | Puesta Producción | 4h | 2009-04-29 09:00 | 2009-04-29 13:00 | 31 | 1.5d |  | Operaciones | 4h |
| 35 | 1.5.9 | Gcia Proyecto | 80h | 2009-02-19 09:00 | 2009-03-04 19:00 |  | 41d |  | r2 | 80h |

Notes:
- 7: SITE PÚBLICO
- 17: Manejo de emails automáticos para confirmación en línea de las reservaciones
