# Sitio web para Cyngular

Schedule from MS Project, 2009-11-01 to 2010-02-26, status date 2009-07-14.
GWT

## Calendars

- Estándar: Mon-Fri 09:00-13:00, 15:00-19:00; Sat-Sun off. Exceptions (off unless hours are given): 2009-12-25 (Navidad), 2009-12-30 (Año Viejo), 2010-01-01 (Ano Nuevo).

## Resources

| Resource |
| --- |
| Diseñador |
| Programador |
| Analista |
| Operación |
| Gerente Proyecto |
| C |

## Schedule

| ID | WBS | Task | Duration | Start | Finish | Predecessors | Total slack | Resources | Work |
| --- | --- | --- | --- | --- | --- | --- | --- | --- | --- |
| 1 | 1 | **Inicio Proyecto** | 82d | 2009-11-01 09:00 | 2010-02-26 19:00 |  | 0d |  | 553h |
| 2 | 1.1 | Crear Ambiente de Desarrollo | 8h | 2009-11-02 09:00 | 2009-11-02 19:00 |  | 0d | Operación | 8h |
| 3 | 1.2 | **Análisis Especificaciones** | 11d | 2009-11-03 09:00 | 2009-11-17 19:00 | 2 | 0d |  | 88h |
| 4 | 1.2.1 | Levantar Información (Sitio Web, Interfaz) | 24h | 2009-11-03 09:00 | 2009-11-05 19:00 |  | 0d | Analista | 24h |
| 5 | 1.2.2 | Analsis de Información | 16h | 2009-11-06 09:00 | 2009-11-09 19:00 | 4 | 0d | Analista | 16h |
| 6 | 1.2.3 | Documentación | 8h | 2009-11-10 09:00 | 2009-11-10 19:00 | 5 | 0d | Analista | 8h |
| 7 | 1.2.4 | Revisión del Cliente | 8h | 2009-11-11 09:00 | 2009-11-11 19:00 | 6 | 0d | C | 8h |
| 8 | 1.2.5 | Ajustes al Informe | 8h | 2009-11-12 09:00 | 2009-11-12 19:00 | 7 | 0d | Analista | 8h |
| 9 | 1.2.6 | Aprobación del Cliente | 8h | 2009-11-13 09:00 | 2009-11-13 19:00 | 8 | 0d | C | 8h |
| 10 | 1.2.7 | Modelaje de Datos | 8h | 2009-11-16 09:00 | 2009-11-16 19:00 | 9 | 0d | Analista | 8h |
| 11 | 1.2.8 | Estructura del repositorio de datos del Site | 8h | 2009-11-17 09:00 | 2009-11-17 19:00 | 10 | 0d | Analista | 8h |
| 12 | 1.3 | **Sitio Web** | 57.75d | 2009-11-18 09:00 | 2010-02-10 17:00 | 3 | 0d |  | 361h |
| 13 | 1.3.1 | **Diseño Gráfico** | 9d | 2009-11-18 09:00 | 2009-11-30 19:00 |  | 0d |  | 44h |
| 14 | 1.3.1.1 | Diseño del Feel | 16h | 2009-11-18 09:00 | 2009-11-19 19:00 |  | 0d | Diseñador [50%] | 8h |
| 15 | 1.3.1.2 | Revisión y Aprobación del Cliente | 8h | 2009-11-20 09:00 | 2009-11-20 19:00 | 14 | 0d | C | 8h |
| 16 | 1.3.1.3 | Diseño del Look | 16h | 2009-11-23 09:00 | 2009-11-24 19:00 | 15 | 0d | Diseñador [50%] | 8h |
| 17 | 1.3.1.4 | Revisión y Aprobación del Cliente | 8h | 2009-11-25 09:00 | 2009-11-25 19:00 | 16 | 0d | C | 8h |
| 18 | 1.3.1.5 | Creación hojas de Estilo | 8h | 2009-11-26 09:00 | 2009-11-26 19:00 | 17 | 0d | Diseñador [25%] | 2h |
| 19 | 1.3.1.6 | Estructuración del sitio | 8h | 2009-11-27 09:00 | 2009-11-27 19:00 | 18 | 0d | Diseñador [25%] | 2h |
| 20 | 1.3.1.7 | Revisión y Aprobación del Cliente | 8h | 2009-11-30 09:00 | 2009-11-30 19:00 | 19 | 0d | C | 8h |
| 21 | 1.3.2 | **Secciones públicas** | 17.75d | 2009-12-01 09:00 | 2009-12-24 17:00 | 13 | 0d |  | 131h |
| 22 | 1.3.2.1 | **Página principal** | 3d | 2009-12-01 09:00 | 2009-12-03 19:00 |  | 0d |  | 24h |
| 23 | 1.3.2.1.1 | Mensaje Contenido | 4h | 2009-12-01 09:00 | 2009-12-01 13:00 |  | 0d | Programador | 4h |
| 24 | 1.3.2.1.2 | Noticias Destacadas | 2h | 2009-12-01 15:00 | 2009-12-01 17:00 | 23 | 0d | Programador | 2h |
| 25 | 1.3.2.1.3 | Invitación | 4h | 2009-12-01 17:00 | 2009-12-02 11:00 | 24 | 0d | Programador | 4h |
| 26 | 1.3.2.1.4 | Selección de País | 2h | 2009-12-02 11:00 | 2009-12-02 13:00 | 25 | 0d | Programador | 2h |
| 27 | 1.3.2.1.5 | Header | 8h | 2009-12-02 15:00 | 2009-12-03 13:00 | 26 | 0d | Programador | 8h |
| 28 | 1.3.2.1.6 | Footer | 4h | 2009-12-03 15:00 | 2009-12-03 19:00 | 27 | 0d | Programador | 4h |

| ID | WBS | Task | Type | Duration | Start | Finish | Predecessors | Total slack | Resources | Work |
| --- | --- | --- | --- | --- | --- | --- | --- | --- | --- | --- |
| 29 | 1.3.2.2 | **Pagina Regional** |  | 4d | 2009-12-04 09:00 | 2009-12-09 19:00 | 22 | 0d |  | 25h |
| 30 | 1.3.2.2.1 | Mensaje de Contenido |  | 4h | 2009-12-04 09:00 | 2009-12-04 13:00 |  | 0d | Programador | 4h |
| 31 | 1.3.2.2.2 | Noticias destacadas |  | 4h | 2009-12-04 15:00 | 2009-12-04 19:00 | 30 | 0d | Programador | 4h |
| 32 | 1.3.2.2.3 | Invitación |  | 4h | 2009-12-07 09:00 | 2009-12-07 13:00 | 31 | 0d | Programador | 4h |
| 33 | 1.3.2.2.4 | Encuesta |  | 4h | 2009-12-07 15:00 | 2009-12-07 19:00 | 32 | 0d | Programador | 4h |
| 34 | 1.3.2.2.5 | Certificaciones |  | 4h | 2009-12-08 09:00 | 2009-12-08 13:00 | 33 | 0d | Programador | 4h |
| 35 | 1.3.2.2.6 | Banners |  | 4h | 2009-12-08 15:00 | 2009-12-08 19:00 | 34 | 0d | Programador [50%] | 2h |
| 36 | 1.3.2.2.7 | Fotos de Productos |  | 4h | 2009-12-09 09:00 | 2009-12-09 13:00 | 35 | 0d | Programador [50%] | 2h |
| 37 | 1.3.2.2.8 | Menu Navegación |  | 4h | 2009-12-09 15:00 | 2009-12-09 19:00 | 36 | 0d | Programador [25%] | 1h |
| 38 | 1.3.2.3 | **Menú de Navegación** |  | 8.75d | 2009-12-10 09:00 | 2009-12-22 17:00 | 29 | 0d |  | 66h |
| 39 | 1.3.2.3.1 | Inicio |  | 2h | 2009-12-10 09:00 | 2009-12-10 11:00 |  | 0d | Programador | 2h |
| 40 | 1.3.2.3.2 | Quienes Somos |  | 4h | 2009-12-10 11:00 | 2009-12-10 17:00 | 39 | 0d | Programador | 4h |
| 41 | 1.3.2.3.3 | Productos |  | 8h | 2009-12-10 17:00 | 2009-12-11 17:00 | 40 | 0d | Programador | 8h |
| 42 | 1.3.2.3.4 | Nuestras Tiendas |  | 8h | 2009-12-11 17:00 | 2009-12-14 17:00 | 41 | 0d | Programador | 8h |
| 43 | 1.3.2.3.5 | Mis Datos |  | 4h | 2009-12-14 17:00 | 2009-12-15 11:00 | 42 | 0d | Programador | 4h |
| 44 | 1.3.2.3.6 | Preguntas Frecuentes |  | 4h | 2009-12-15 11:00 | 2009-12-15 17:00 | 43 | 0d | Programador [50%] | 2h |
| 45 | 1.3.2.3.7 | Contactenos |  | 4h | 2009-12-15 17:00 | 2009-12-16 11:00 | 44 | 0d | Programador | 4h |
| 46 | 1.3.2.3.8 | Busqueda rápida de Productos |  | 4h | 2009-12-16 11:00 | 2009-12-16 17:00 | 45 | 0d | Programador [50%] | 2h |
| 47 | 1.3.2.3.9 | Mostrar Productos con Foto y Precio/Oferta |  | 8h | 2009-12-16 17:00 | 2009-12-17 17:00 | 46 | 0d | Programador | 8h |
| 48 | 1.3.2.3.10 | Consultar Cotizaciòn |  | 4h | 2009-12-17 17:00 | 2009-12-18 11:00 | 47 | 0d | Programador | 4h |
| 49 | 1.3.2.3.11 | Cotizar Productos |  | 8h | 2009-12-18 11:00 | 2009-12-21 11:00 | 48 | 0d | Programador | 8h |
| 50 | 1.3.2.3.12 | Configurar Producto |  | 12h | 2009-12-21 11:00 | 2009-12-22 17:00 | 49 | 0d | Programador | 12h |
| 51 | 1.3.2.4 | Revisión del Cliente |  | 8h | 2009-12-22 17:00 | 2009-12-23 17:00 | 50 | 0d | C | 8h |
| 52 | 1.3.2.5 | Ajustes Sección Pública |  | 8h | 2009-12-23 17:00 | 2009-12-24 17:00 | 51 | 0d | Programador | 8h |
| 53 | 1.3.2.6 | ENTREGA 1: SITIO WEB PÚBLICO en ambiente de desarrollo | milestone | 0h | 2009-12-24 17:00 | 2009-12-24 17:00 | 52 | 0d | Operación [75%] |  |

| ID | WBS | Task | Type | Duration | Start | Finish | Predecessors | Total slack | Resources | Work |
| --- | --- | --- | --- | --- | --- | --- | --- | --- | --- | --- |
| 54 | 1.3.3 | **Secciones Privadas** |  | 18d | 2009-12-24 17:00 | 2010-01-22 17:00 | 21 | 0d |  | 84h |
| 55 | 1.3.3.1 | Autenticación de usuario |  | 32h | 2009-12-24 17:00 | 2010-01-04 17:00 |  | 0d | Programador [50%] | 16h |
| 56 | 1.3.3.2 | Mis Datos |  | 8h | 2010-01-04 17:00 | 2010-01-05 17:00 | 55 | 0d | Programador [50%] | 4h |
| 57 | 1.3.3.3 | Mi Cotizacion |  | 8h | 2010-01-05 17:00 | 2010-01-06 17:00 | 56 | 0d | Programador [50%] | 4h |
| 58 | 1.3.3.4 | Seguimiento de Cotizaciones |  | 64h | 2010-01-06 17:00 | 2010-01-18 17:00 | 57 | 0d | Programador [50%] | 32h |
| 59 | 1.3.3.5 | Revisión del Cliente |  | 3d | 2010-01-18 17:00 | 2010-01-21 17:00 | 58 | 0d | C | 24h |
| 60 | 1.3.3.6 | Ajustes Secciones Privadas |  | 8h | 2010-01-21 17:00 | 2010-01-22 17:00 | 59 | 0d | Programador [50%] | 4h |
| 61 | 1.3.3.7 | ENTREGA 2: SITIO WEB Privado en ambiente de desarrollo | milestone | 0h | 2010-01-22 17:00 | 2010-01-22 17:00 | 60 | 0d | Operación [75%] |  |
| 62 | 1.3.4 | **BackOffice** |  | 13d | 2010-01-22 17:00 | 2010-02-10 17:00 | 54 | 0d |  | 102h |
| 63 | 1.3.4.1 | Manejo de Enlaces de interés |  | 4h | 2010-01-22 17:00 | 2010-01-25 11:00 |  | 0d | Programador | 4h |
| 64 | 1.3.4.2 | Manejo de Noticias |  | 4h | 2010-01-25 11:00 | 2010-01-25 17:00 | 63 | 0d | Programador | 4h |
| 65 | 1.3.4.3 | Manejo de Quienes Somos |  | 4h | 2010-01-25 17:00 | 2010-01-26 11:00 | 64 | 0d | Programador | 4h |
| 66 | 1.3.4.4 | Manejo de Productos |  | 4h | 2010-01-26 11:00 | 2010-01-26 17:00 | 65 | 0d | Programador | 4h |
| 67 | 1.3.4.5 | Manejo de Interacciones |  | 4h | 2010-01-26 17:00 | 2010-01-27 11:00 | 66 | 0d | Programador | 4h |
| 68 | 1.3.4.6 | Manejo de Mis Datos |  | 4h | 2010-01-27 11:00 | 2010-01-27 17:00 | 67 | 0d | Programador | 4h |
| 69 | 1.3.4.7 | Manejo de Administración de Usuarios |  | 4h | 2010-01-27 17:00 | 2010-01-28 11:00 | 68 | 0d | Programador | 4h |
| 70 | 1.3.4.8 | Manejo de Cotizaciones |  | 4h | 2010-01-28 11:00 | 2010-01-28 17:00 | 69 | 0d | Programador | 4h |
| 71 | 1.3.4.9 | Manejo de Paginas Regionales |  | 4h | 2010-01-28 17:00 | 2010-01-29 11:00 | 70 | 0d | Programador | 4h |
| 72 | 1.3.4.10 | Manejo de Preguntas Frecuentes |  | 4h | 2010-01-29 11:00 | 2010-01-29 17:00 | 71 | 0d | Programador | 4h |
| 73 | 1.3.4.11 | Administración de banners |  | 4h | 2010-01-29 17:00 | 2010-02-01 11:00 | 72 | 0d | Programador | 4h |
| 74 | 1.3.4.12 | Contenido Pie de página |  | 4h | 2010-02-01 11:00 | 2010-02-01 17:00 | 73 | 0d | Programador | 4h |
| 75 | 1.3.4.13 | Manejo de Usuarios registrados |  | 4h | 2010-02-01 17:00 | 2010-02-02 11:00 | 74 | 0d | Programador | 4h |
| 76 | 1.3.4.14 | Administracion de Cotizaciones |  | 4h | 2010-02-02 11:00 | 2010-02-02 17:00 | 75 | 0d | Programador | 4h |
| 77 | 1.3.4.15 | Reportes básicos por tabla |  | 4h | 2010-02-02 17:00 | 2010-02-03 11:00 | 76 | 0d | Programador | 4h |
| 78 | 1.3.4.16 | Administración de usuarios Backoffice |  | 4h | 2010-02-03 11:00 | 2010-02-03 17:00 | 77 | 0d | Programador | 4h |
| 79 | 1.3.4.17 | Adminstración de Clientes |  | 4h | 2010-02-03 17:00 | 2010-02-04 11:00 | 78 | 0d | Programador | 4h |
| 80 | 1.3.4.18 | Administración de Disponibilidad y Precios |  | 4h | 2010-02-04 11:00 | 2010-02-04 17:00 | 79 | 0d | Programador | 4h |
| 81 | 1.3.4.19 | Administración de Soliciitud de Pedidio |  | 4h | 2010-02-04 17:00 | 2010-02-05 11:00 | 80 | 0d | Programador | 4h |
| 82 | 1.3.4.20 | Configuración de perfiles de usuarios del Backoffice |  | 4h | 2010-02-05 11:00 | 2010-02-05 17:00 | 81 | 0d | Programador | 4h |
| 83 | 1.3.4.21 | Administración de Contactenos |  | 4h | 2010-02-05 17:00 | 2010-02-08 11:00 | 82 | 0d | Programador | 4h |
| 84 | 1.3.4.22 | Revisión del Cliente |  | 8h | 2010-02-08 11:00 | 2010-02-09 11:00 | 83 | 0d | C | 8h |
| 85 | 1.3.4.23 | Ajuste BackOffice |  | 4h | 2010-02-09 11:00 | 2010-02-09 17:00 | 84 | 0d | Programador | 4h |
| 86 | 1.3.4.24 | ENTREGA 3:Sitio Web Backoffice |  | 8h | 2010-02-09 17:00 | 2010-02-10 17:00 | 85 | 0d | Operación [75%] | 6h |

| ID | WBS | Task | Type | Duration | Start | Finish | Predecessors | Total slack | Resources | Work |
| --- | --- | --- | --- | --- | --- | --- | --- | --- | --- | --- |
| 87 | 1.4 | **Carga de Datos** |  | 4d | 2010-02-10 17:00 | 2010-02-16 17:00 | 62 | 0d |  | 30h |
| 88 | 1.4.1 | Carga de Productos |  | 8h | 2010-02-10 17:00 | 2010-02-11 17:00 |  | 0d | Programador | 8h |
| 89 | 1.4.2 | Revisión del Cliente |  | 8h | 2010-02-11 17:00 | 2010-02-12 17:00 | 88 | 0d | C | 8h |
| 90 | 1.4.3 | Ajustes de Carga de Datos |  | 8h | 2010-02-12 17:00 | 2010-02-15 17:00 | 89 | 0d | Programador | 8h |
| 91 | 1.4.4 | ENTREGA 4: Interfaz en ambiente de desarrollo |  | 8h | 2010-02-15 17:00 | 2010-02-16 17:00 | 90 | 0d | Operación [75%] | 6h |
| 92 | 1.5 | **Adiestramiento** |  | 1.25d | 2010-02-16 17:00 | 2010-02-17 19:00 |  | 0d |  | 10h |
| 93 | 1.5.1 | Crear Guia de Usuario |  | 4h | 2010-02-16 17:00 | 2010-02-17 11:00 | 87 | 0d | Analista | 4h |
| 94 | 1.5.2 | Adiestramiento Usuario Backoffice |  | 2h | 2010-02-17 11:00 | 2010-02-17 13:00 | 93 | 0d | Analista | 2h |
| 95 | 1.5.3 | Adiestramiento Administrador Backoffice |  | 4h | 2010-02-17 15:00 | 2010-02-17 19:00 | 94 | 0d | Analista | 4h |
| 96 | 1.6 | **Certificacion y Carga del Cliente** |  | 5d | 2010-02-18 09:00 | 2010-02-24 19:00 |  | 0d |  | 40h |
| 97 | 1.6.1 | Pruebas de Certificación Cliente |  | 16h | 2010-02-18 09:00 | 2010-02-19 19:00 | 95 | 0d | C | 16h |
| 98 | 1.6.2 | Ingreso de Contenido |  | 8h | 2010-02-22 09:00 | 2010-02-22 19:00 | 97 | 0d | C | 8h |
| 99 | 1.6.3 | Ajustes Finales |  | 16h | 2010-02-23 09:00 | 2010-02-24 19:00 | 98 | 0d | Programador | 16h |
| 100 | 1.7 | **Producción** |  | 1.75d | 2010-02-25 09:00 | 2010-02-26 17:00 |  | 0d |  | 14h |
| 101 | 1.7.1 | Crear Ambiente de Producción |  | 8h | 2010-02-25 09:00 | 2010-02-25 19:00 | 99 | 0d | Operación | 8h |
| 102 | 1.7.2 | Migrar Ambiente de Desarrollo a Producción |  | 4h | 2010-02-26 09:00 | 2010-02-26 13:00 | 101 | 0d | Operación | 4h |
| 103 | 1.7.3 | Google Analytics |  | 2h | 2010-02-26 15:00 | 2010-02-26 17:00 | 102 | 0d | Programador | 2h |
| 104 | 1.8 | Gerencia de proyectos | milestone | 0h | 2009-11-01 09:00 | 2009-11-01 09:00 |  | 81.75d | Gerente Proyecto [10%] |  |
| 105 | 1.9 | Cierre de Proyecto | milestone | 2h | 2010-02-26 17:00 | 2010-02-26 19:00 | 104, 100 | 0d | Gerente Proyecto | 2h |
